# Calendário do Projeto

Schedule from MS Project, 2023-07-31 to 2025-12-21, status date 2023-06-12, 8.8 hours a day, costs in R$.

## Calendars

- Curso Unichristus: Mon-Fri 07:00-12:00, 13:00-16:48; Sat-Sun off. Exceptions (off unless hours are given): 2023-01-01 to 2032-01-01 (Confraternização Mundial, recurring), 2023-03-19 to 2032-03-19 (São José, recurring), 2023-03-25 to 2032-03-25 (Carta Magna, recurring), 2023-04-21 to 2032-04-21 (Tiradentes, recurring), 2023-05-01 to 2032-05-01 (Dia do Trabalho, recurring), 2023-09-07 to 2032-09-07 (Independência do Brasil, recurring), 2023-10-12 to 2032-10-12 (Nossa Senhora Aparecida, recurring), 2023-11-02 to 2032-11-02 (Finado, recurring), 2023-11-15 to 2032-11-15 (Proclamação da República, recurring), 2023-12-25 to 2032-12-25 (Natal, recurring), 2023-12-26 to 2023-12-29 (Recesso fim de ano 2023), 2024-02-12 to 2024-02-14 (Carnaval 2024), 2024-03-29 (Paixão de Cristo 2024), 2024-05-30 to 2024-05-31 (Corpus Christi 2024), 2025-03-03 to 2025-03-05 (Carnaval 2025), 2025-04-18 (Paixão de Cristo 2025), 2025-06-19 to 2025-06-20 (Corpus Christi 2025).

## Resources

| Resource |
| --- |
| carpinteiro |
| ferreiro |
| servente estrutura |
| aux. Carpinteiro |
| aux. ferreiro |
| enc. carpinteiro |
| enc. ferreiro |
| pedreiro alv. |
| servente alv. |
| gesseiro |
| aux. gesseiro |
| aplicador de manta |
| aux. aplicador |
| pedreiro acab. |
| servente acab. |
| pedreiro fac. |
| servente fac. |
| montador esquadrias |
| aux.Marceneiro |
| marceneiro |
| aux. eletricista |
| eletricista |
| pintor |
| aux. Pintor |
| aux. bombeiro |
| bombeiro |
| Diarista |
| mecânico |
| servente geral |
| pedreiro |
| servente |
| aux.pintor |

## Schedule

| ID | WBS | Task | Duration | Start | Finish | Predecessors | Total slack | Free slack | Work | Cost |
| --- | --- | --- | --- | --- | --- | --- | --- | --- | --- | --- |
| 1 | 1 | **Curso PO CREA-CE 2023** | 593d | 2023-07-31 | 2025-12-21 |  | 0d |  | 132537h | 9,173,149.99 |
| 2 | 1.1 | **Suprimentos** | 413d | 2023-09-20 | 2025-05-30 |  | 144d |  |  |  |
| 3 | 1.1.1 | **Cerâmica de piso e parede** | 90d | 2024-05-08 | 2024-09-13 |  | 318d |  |  |  |
| 4 | 1.1.1.1 | Solicitação | 2d | 2024-05-08 | 2024-05-10 | 5SF | 406d |  |  |  |
| 5 | 1.1.1.2 | Coleta | 8d | 2024-05-10 | 2024-05-22 | 6SF | 398d | 0d |  |  |
| 6 | 1.1.1.3 | Análise/Negociação | 10d | 2024-05-22 | 2024-06-07 | 7SF | 388d | 0d |  |  |
| 7 | 1.1.1.4 | Contrato/Pedido | 10d | 2024-06-07 | 2024-06-21 | 8SF | 378d | 0d |  |  |
| 8 | 1.1.1.5 | Fabricação | 45d | 2024-06-21 | 2024-08-23 | 9SF | 333d | 0d |  |  |
| 9 | 1.1.1.6 | Transporte/Entrega | 15d | 2024-08-23 | 2024-09-13 | 129SF | 318d | 0d |  |  |
| 10 | 1.1.2 | **Porta-pronta** | 82d | 2024-09-27 | 2025-01-24 |  | 226d |  |  |  |
| 11 | 1.1.2.1 | Solicitação | 2d | 2024-09-27 | 2024-10-01 | 12SF | 306d |  |  |  |
| 12 | 1.1.2.2 | Coleta | 4d | 2024-10-01 | 2024-10-07 | 13SF | 302d | 0d |  |  |
| 13 | 1.1.2.3 | Análise/Negociação | 8d | 2024-10-07 | 2024-10-17 | 14SF | 294d | 0d |  |  |
| 14 | 1.1.2.4 | Contrato/Pedido | 8d | 2024-10-17 | 2024-10-29 | 15SF | 286d | 0d |  |  |
| 15 | 1.1.2.5 | Fabricação | 45d | 2024-10-29 | 2025-01-03 | 16SF | 241d | 0d |  |  |
| 16 | 1.1.2.6 | Transporte/Entrega | 15d | 2025-01-03 | 2025-01-24 | 133SF | 226d | 0d |  |  |
| 17 | 1.1.3 | **Esquadrias de alumínio com vidro** | 93d | 2024-09-10 | 2025-01-22 |  | 228d |  |  |  |
| 18 | 1.1.3.1 | Solicitação | 3d | 2024-09-10 | 2024-09-13 | 19SF | 318d |  |  |  |
| 19 | 1.1.3.2 | Coleta | 10d | 2024-09-13 | 2024-09-27 | 20SF | 308d | 0d |  |  |
| 20 | 1.1.3.3 | Análise/Negociação | 10d | 2024-09-27 | 2024-10-11 | 21SF | 298d | 0d |  |  |
| 21 | 1.1.3.4 | Contrato/Pedido | 10d | 2024-10-11 | 2024-10-25 | 22SF | 288d | 0d |  |  |
| 22 | 1.1.3.5 | Fabricação | 45d | 2024-10-25 | 2024-12-31 | 23SF | 243d | 0d |  |  |
| 23 | 1.1.3.6 | Transporte/Entrega | 15d | 2024-12-31 | 2025-01-22 | 132SF | 228d | 0d |  |  |
| 24 | 1.1.4 | **Contramarcos** | 32d | 2023-09-28 | 2023-11-16 |  | 519d |  |  |  |
| 25 | 1.1.4.1 | Solicitação | 2d | 2023-09-28 | 2023-10-02 | 26SF | 549d |  |  |  |
| 26 | 1.1.4.2 | Coleta | 5d | 2023-10-02 | 2023-10-09 | 27SF | 544d | 0d |  |  |
| 27 | 1.1.4.3 | Análise/Negociação | 5d | 2023-10-09 | 2023-10-17 | 28SF | 539d | 0d |  |  |
| 28 | 1.1.4.4 | Contrato/Pedido | 5d | 2023-10-17 | 2023-10-24 | 29SF | 534d | 0d |  |  |
| 29 | 1.1.4.5 | Fabricação | 10d | 2023-10-24 | 2023-11-08 | 30SF | 524d | 0d |  |  |
| 30 | 1.1.4.6 | Transporte/Entrega | 5d | 2023-11-08 | 2023-11-16 | 120SF | 519d | 0d |  |  |

| ID | WBS | Task | Duration | Start | Finish | Predecessors | Total slack | Free slack |
| --- | --- | --- | --- | --- | --- | --- | --- | --- |
| 31 | 1.1.5 | **Ferragens de portas** | 58d | 2024-10-31 | 2025-01-24 |  | 226d |  |
| 32 | 1.1.5.1 | Solicitação | 2d | 2024-10-31 | 2024-11-04 | 33SF | 282d |  |
| 33 | 1.1.5.2 | Coleta | 5d | 2024-11-04 | 2024-11-11 | 34SF | 277d | 0d |
| 34 | 1.1.5.3 | Análise/Negociação | 4d | 2024-11-11 | 2024-11-18 | 35SF | 273d | 0d |
| 35 | 1.1.5.4 | Contrato/Pedido | 2d | 2024-11-18 | 2024-11-20 | 36SF | 271d | 0d |
| 36 | 1.1.5.5 | Fabricação | 30d | 2024-11-20 | 2025-01-03 | 37SF | 241d | 0d |
| 37 | 1.1.5.6 | Transporte/Entrega | 15d | 2025-01-03 | 2025-01-24 | 16FF | 226d | 0d |
| 38 | 1.1.6 | **Impermeabilização (Manta)** | 47d | 2024-04-18 | 2024-06-27 |  | 374d |  |
| 39 | 1.1.6.1 | Solicitação | 2d | 2024-04-18 | 2024-04-22 | 40SF | 419d |  |
| 40 | 1.1.6.2 | Coleta | 5d | 2024-04-22 | 2024-04-29 | 41SF | 414d | 0d |
| 41 | 1.1.6.3 | Análise/Negociação | 5d | 2024-04-29 | 2024-05-07 | 42SF | 409d | 0d |
| 42 | 1.1.6.4 | Contrato/Pedido | 5d | 2024-05-07 | 2024-05-14 | 43SF | 404d | 0d |
| 43 | 1.1.6.5 | Fabricação | 20d | 2024-05-14 | 2024-06-13 | 44SF | 384d | 0d |
| 44 | 1.1.6.6 | Transporte/Entrega | 10d | 2024-06-13 | 2024-06-27 | 123SF | 374d | 0d |
| 45 | 1.1.7 | **Impermeabilização (Arg. Polimérica)** | 48d | 2024-04-17 | 2024-06-27 |  | 374d |  |
| 46 | 1.1.7.1 | Solicitação | 3d | 2024-04-17 | 2024-04-22 | 47SF | 419d |  |
| 47 | 1.1.7.2 | Coleta | 5d | 2024-04-22 | 2024-04-29 | 48SF | 414d | 0d |
| 48 | 1.1.7.3 | Análise/Negociação | 5d | 2024-04-29 | 2024-05-07 | 49SF | 409d | 0d |
| 49 | 1.1.7.4 | Contrato/Pedido | 5d | 2024-05-07 | 2024-05-14 | 50SF | 404d | 0d |
| 50 | 1.1.7.5 | Fabricação | 20d | 2024-05-14 | 2024-06-13 | 51SF | 384d | 0d |
| 51 | 1.1.7.6 | Transporte/Entrega | 10d | 2024-06-13 | 2024-06-27 | 44FF | 374d | 0d |
| 52 | 1.1.8 | **Fios e cabos** | 48d | 2024-11-19 | 2025-01-28 |  | 224d |  |
| 53 | 1.1.8.1 | Solicitação | 3d | 2024-11-19 | 2024-11-22 | 54SF | 269d |  |
| 54 | 1.1.8.2 | Coleta | 5d | 2024-11-22 | 2024-11-29 | 55SF | 264d | 0d |
| 55 | 1.1.8.3 | Análise/Negociação | 5d | 2024-11-29 | 2024-12-06 | 56SF | 259d | 0d |
| 56 | 1.1.8.4 | Contrato/Pedido | 5d | 2024-12-06 | 2024-12-13 | 57SF | 254d | 0d |
| 57 | 1.1.8.5 | Fabricação | 20d | 2024-12-13 | 2025-01-14 | 58SF | 234d | 0d |
| 58 | 1.1.8.6 | Transporte/Entrega | 10d | 2025-01-14 | 2025-01-28 | 876SF | 224d | 0d |

| ID | WBS | Task | Duration | Start | Finish | Predecessors | Total slack | Free slack | Cor |
| --- | --- | --- | --- | --- | --- | --- | --- | --- | --- |
| 59 | 1.1.9 | **Forro de gesso** | 48d | 2024-11-08 | 2025-01-20 |  | 230d |  |  |
| 60 | 1.1.9.1 | Solicitação | 3d | 2024-11-08 | 2024-11-13 | 61SF | 275d |  | 10 |
| 61 | 1.1.9.2 | Coleta | 5d | 2024-11-13 | 2024-11-21 | 62SF | 270d | 0d | 10 |
| 62 | 1.1.9.3 | Análise/Negociação | 5d | 2024-11-21 | 2024-11-28 | 63SF | 265d | 0d | 10 |
| 63 | 1.1.9.4 | Contrato/Pedido | 5d | 2024-11-28 | 2024-12-05 | 64SF | 260d | 0d | 10 |
| 64 | 1.1.9.5 | Fabricação | 20d | 2024-12-05 | 2025-01-06 | 65SF | 240d | 0d | 10 |
| 65 | 1.1.9.6 | Transporte/Entrega | 10d | 2025-01-06 | 2025-01-20 | 131SF | 230d | 0d | 10 |
| 66 | 1.1.10 | **Revestimentos de granitos / bancadas** | 48d | 2025-03-17 | 2025-05-29 |  | 145d |  |  |
| 67 | 1.1.10.1 | Solicitação | 3d | 2025-03-17 | 2025-03-21 | 68SF | 190d |  | 11 |
| 68 | 1.1.10.2 | Coleta | 5d | 2025-03-21 | 2025-03-31 | 69SF | 185d | 0d | 11 |
| 69 | 1.1.10.3 | Análise/Negociação | 5d | 2025-03-31 | 2025-04-07 | 70SF | 180d | 0d | 11 |
| 70 | 1.1.10.4 | Contrato/Pedido | 5d | 2025-04-07 | 2025-04-14 | 71SF | 175d | 0d | 11 |
| 71 | 1.1.10.5 | Fabricação | 20d | 2025-04-14 | 2025-05-15 | 72SF | 155d | 0d | 11 |
| 72 | 1.1.10.6 | Transporte/Entrega | 10d | 2025-05-15 | 2025-05-29 | 135SF | 145d | 0d | 11 |
| 73 | 1.1.11 | **Material de Pintura** | 24d | 2025-02-05 | 2025-03-14 |  | 194d |  |  |
| 74 | 1.1.11.1 | Solicitação | 2d | 2025-02-05 | 2025-02-07 | 75SF | 216d |  | 12 |
| 75 | 1.1.11.2 | Coleta | 5d | 2025-02-07 | 2025-02-14 | 76SF | 211d | 0d | 12 |
| 76 | 1.1.11.3 | Análise/Negociação | 5d | 2025-02-14 | 2025-02-21 | 77SF | 206d | 0d | 12 |
| 77 | 1.1.11.4 | Contrato/Pedido | 5d | 2025-02-21 | 2025-02-28 | 78SF | 201d | 0d | 12 |
| 78 | 1.1.11.5 | Fabricação | 5d | 2025-02-28 | 2025-03-12 | 79SF | 196d | 0d | 12 |
| 79 | 1.1.11.6 | Transporte/Entrega | 2d | 2025-03-12 | 2025-03-14 | 134SF | 194d | 0d | 12 |
| 80 | 1.1.12 | **Peitoril, Soleiras e Filetes** | 38d | 2023-09-20 | 2023-11-16 |  | 519d |  |  |
| 81 | 1.1.12.1 | Solicitação | 5d | 2023-09-20 | 2023-09-27 | 82SF | 552d |  | 13 |
| 82 | 1.1.12.2 | Coleta | 5d | 2023-09-27 | 2023-10-04 | 83SF | 547d | 0d | 13 |
| 83 | 1.1.12.3 | Análise/Negociação | 5d | 2023-10-04 | 2023-10-11 | 84SF | 542d | 0d | 13 |
| 84 | 1.1.12.4 | Contrato/Pedido | 5d | 2023-10-11 | 2023-10-19 | 85SF | 537d | 0d | 13 |
| 85 | 1.1.12.5 | Fabricação | 15d | 2023-10-19 | 2023-11-10 | 86SF | 522d | 0d | 13 |
| 86 | 1.1.12.6 | Transporte/Entrega | 3d | 2023-11-10 | 2023-11-16 | 120SF | 519d | 0d | 13 |

| ID | WBS | Task | Duration | Start | Finish | Predecessors | Total slack | Free slack | Cost | Cor |
| --- | --- | --- | --- | --- | --- | --- | --- | --- | --- | --- |
| 87 | 1.1.13 | **Metais e acabamentos** | 35d | 2025-04-08 | 2025-05-30 |  | 144d |  |  |  |
| 88 | 1.1.13.1 | Solicitação | 2d | 2025-04-08 | 2025-04-10 | 89SF | 177d |  |  | 14 |
| 89 | 1.1.13.2 | Coleta | 3d | 2025-04-10 | 2025-04-15 | 90SF | 174d | 0d |  | 14 |
| 90 | 1.1.13.3 | Análise/Negociação | 5d | 2025-04-15 | 2025-04-24 | 91SF | 169d | 0d |  | 14 |
| 91 | 1.1.13.4 | Contrato/Pedido | 5d | 2025-04-24 | 2025-05-01 | 92SF | 164d | 0d |  | 14 |
| 92 | 1.1.13.5 | Fabricação | 15ed | 2025-05-01 | 2025-05-16 | 93SF | 598.39d | 0d |  | 14 |
| 93 | 1.1.13.6 | Transporte/Entrega | 10d | 2025-05-16 | 2025-05-30 | 879SF | 144d | 0d |  | 14 |
| 94 | 1.1.14 | **Louças** | 108d | 2024-12-17 | 2025-05-30 |  | 144d |  |  |  |
| 95 | 1.1.14.1 | Solicitação | 3d | 2024-12-17 | 2024-12-20 | 96SF | 249d |  |  | 15 |
| 96 | 1.1.14.2 | Coleta | 5d | 2024-12-20 | 2024-12-30 | 97SF | 244d | 0d |  | 15 |
| 97 | 1.1.14.3 | Análise/Negociação | 5d | 2024-12-30 | 2025-01-07 | 98SF | 239d | 0d |  | 15 |
| 98 | 1.1.14.4 | Contrato/Pedido | 5d | 2025-01-07 | 2025-01-14 | 99SF | 234d | 0d |  | 15 |
| 99 | 1.1.14.5 | Fabricação | 75d | 2025-01-14 | 2025-05-09 | 100SF | 159d | 0d |  | 15 |
| 100 | 1.1.14.6 | Transporte/Entrega | 15d | 2025-05-09 | 2025-05-30 | 93FF | 144d | 0d |  | 15 |
| 101 | 1.1.15 | **Interruptores, Tomadas e Disjuntores** | 58d | 2025-02-05 | 2025-05-08 |  | 160d |  |  |  |
| 102 | 1.1.15.1 | Solicitação | 3d | 2025-02-05 | 2025-02-10 | 103SF | 215d |  |  | 17 |
| 103 | 1.1.15.2 | Coleta | 5d | 2025-02-10 | 2025-02-17 | 104SF | 210d | 0d |  | 17 |
| 104 | 1.1.15.3 | Análise/Negociação | 5d | 2025-02-17 | 2025-02-24 | 105SF | 205d | 0d |  | 17 |
| 105 | 1.1.15.4 | Contrato/Pedido | 5d | 2025-02-24 | 2025-03-06 | 106SF | 200d | 0d |  | 17 |
| 106 | 1.1.15.5 | Fabricação | 30d | 2025-03-06 | 2025-04-23 | 107SF | 170d | 0d |  | 17 |
| 107 | 1.1.15.6 | Transporte/Entrega | 10d | 2025-04-23 | 2025-05-08 | 877SF | 160d | 0d |  | 17 |
| 108 | 1.2 | Custo Indireto | 508d | 2023-07-31 | 2025-08-22 |  | 85d |  | 2,083,229.72 |  |
| 109 | 1.3 | Áreas Comuns | 250d | 2024-06-19 | 2025-06-18 | 859FF | 130d |  | 520,807.43 |  |
| 110 | 1.4 | Mobilização | 21d | 2023-07-31 | 2023-08-28 |  | 1d | 0d |  |  |

| ID | WBS | Task | Type | Duration | Start | Finish | Predecessors | Total slack | Free slack | Resources | Work | Cost | Casa | Pav | Equipe | Empresa | Pacote | Cor | LB |
| --- | --- | --- | --- | --- | --- | --- | --- | --- | --- | --- | --- | --- | --- | --- | --- | --- | --- | --- | --- |
| 111 | 1.5 | **Pulmão da obra** |  | 64d | 2025-09-22 | 2025-12-21 |  | 0d |  |  |  |  |  |  |  |  |  |  |  |
| 112 | 1.5.1 | Início | milestone | 0d | 2025-09-22 | 2025-09-22 | 862 | 0d |  |  |  |  |  |  |  |  |  |  |  |
| 113 | 1.5.2 | Término | milestone | 0d | 2025-12-21 | 2025-12-21 | 112FS+90ed | 0d |  |  |  |  |  |  |  |  |  |  |  |
| 114 | 1.6 | **Obra Civil** |  | 508d | 2023-08-29 | 2025-09-22 |  | 1d |  |  | 121273h | 5,416,318.92 |  |  |  |  |  |  |  |
| 115 | 1.6.1 | **1. Casa 1** |  | 478d | 2023-08-29 | 2025-08-12 |  | 1d |  |  | 7568h | 338,552.33 |  |  |  |  |  |  |  |
| 116 | 1.6.1.1 | **0. Térreo** |  | 477d | 2023-08-29 | 2025-08-11 |  | 1d |  |  | 3801.6h | 165,509.25 |  |  |  |  |  |  |  |
| 117 | 1.6.1.1.1 | 0. Locação |  | 2d | 2023-08-29 | 2023-08-30 | 110 | 1d | 0d | carpinteiro; aux. Carpinteiro | 35.2h | 456.99 | 1. Casa 1 | 0. Térreo | 0. Locação 1 | Própria |  |  |  |
| 118 | 1.6.1.1.2 | 1. Fundação |  | 9d | 2023-09-25 | 2023-10-05 | 493 | 1d | 0d | servente estrutura [300%]; aux. Carpinteiro; aux. ferreiro; ferreiro; carpinteiro [200%] | 633.6h | 19,882.86 | 1. Casa 1 | 0. Térreo | 1. Fundação 1 | Própria |  |  |  |
| 119 | 1.6.1.1.3 | 2. Estrutura |  | 7d | 2023-10-06 | 2023-10-17 | 118 | 1d | 0d | servente estrutura [300%]; aux. Carpinteiro [200%]; aux. ferreiro [200%]; ferreiro [500%]; carpinteiro [200%] | 862.4h | 46,439.03 | 1. Casa 1 | 0. Térreo | 2. Estrutura 1 | Própria |  |  |  |
| 120 | 1.6.1.1.4 | 3. Alvenarias |  | 5d | 2023-11-16 | 2023-11-22 | 119FS+28ed | 0d |  | pedreiro [400%]; servente [400%] | 352h | 8,388.41 | 1. Casa 1 | 0. Térreo | 3. Alvenarias 1 | Própria |  |  |  |
| 121 | 1.6.1.1.5 | 5. Ref. Inter. Arg (Parede) |  | 3d | 2024-05-15 | 2024-05-17 | 537 | 0d |  | pedreiro [600%]; servente [600%] | 316.8h | 5,776 | 1. Casa 1 | 0. Térreo | 5. Ref. Inter. Arg (Parede) 1 | Própria |  |  |  |
| 122 | 1.6.1.1.6 | 6. Revest. Gesso (Parede + Teto) |  | 3d | 2024-06-03 | 2024-06-06 | 142SF | 389d |  | gesseiro [400%]; aux. gesseiro [200%] | 158.4h | 2,119.41 | 1. Casa 1 | 0. Térreo | 6. Revest. Gesso (Parede + Teto) 1 | Própria |  |  |  |
| 123 | 1.6.1.1.7 | 7. Impermeabilização |  | 2d | 2024-06-27 | 2024-07-01 | 143SF | 372d | 0d | aplicador de manta | 17.6h | 3,288.15 | 1. Casa 1 | 0. Térreo | 7. Impermeabilização 1 | Própria |  |  |  |
| 124 | 1.6.1.1.8 | 8. Contrapiso |  | 2d | 2024-07-09 | 2024-07-11 | 191SF | 296d | 0d | pedreiro [200%]; servente | 52.8h | 3,735.07 | 1. Casa 1 | 0. Térreo | 8. Contrapiso 1 | Própria |  |  |  |
| 125 | 1.6.1.1.9 | 9.1. Chapisco |  | 0.5d | 2024-10-01 | 2024-10-01 | 849 | 148.5d | 0d | pedreiro [600%]; servente [400%] | 44h | 5,131.51 | 1. Casa 1 | 0. Térreo | 9. Fachada 1 | Própria |  |  |  |
| 126 | 1.6.1.1.10 | 9.2. Emboço |  | 1.5d | 2024-10-24 | 2024-10-25 | 146 | 148.5d | 0d | pedreiro [600%]; servente [400%] | 132h | 7,697.26 | 1. Casa 1 | 0. Térreo | 9. Fachada 1 | Própria |  |  |  |
| 127 | 1.6.1.1.11 | 9.3. Pint. 1 Demão |  | 1d | 2024-12-31 | 2025-01-02 | 147 | 148.5d | 0d | pintor [400%]; aux.pintor [200%] | 52.8h | 1,135.92 | 1. Casa 1 | 0. Térreo | 9. Fachada 1 | Própria |  |  |  |
| 128 | 1.6.1.1.12 | 9.4. Pint. 2 Demão |  | 2d | 2025-02-14 | 2025-02-18 | 148 | 148.5d | 0d | pintor [400%]; aux.pintor [200%] | 105.6h | 757.28 | 1. Casa 1 | 0. Térreo | 9. Fachada 1 | Própria |  |  |  |
| 129 | 1.6.1.1.13 | 10. Cer. Piso |  | 4d | 2024-09-13 | 2024-09-18 | 473FS+28ed | 0d |  | pedreiro [400%]; servente [200%] | 211.2h | 25,485.98 | 1. Casa 1 | 0. Térreo | 10. Cer. Piso 1 | Própria | 10 | 10 | 10 |
| 130 | 1.6.1.1.14 | 11. Cer. Parede |  | 3d | 2024-12-13 | 2024-12-17 | 478 | 0d |  | pedreiro [400%]; servente [200%] | 158.4h | 4,238.82 | 1. Casa 1 | 0. Térreo | 11. Cer. Parede 1 | Própria | 11 | 11 | 11 |
| 131 | 1.6.1.1.15 | 12. Forro (WC's e cozinha) |  | 1d | 2025-01-20 | 2025-01-21 | 151SF | 229d | 0d | gesseiro; aux. gesseiro | 17.6h | 635.82 | 1. Casa 1 | 0. Térreo | 12. Forro (WC's e cozinha) 1 | Própria | 12 | 12 | 12 |
| 132 | 1.6.1.1.16 | 13. Esq. Alumínio |  | 2d | 2025-01-22 | 2025-01-23 | 151 | 0d |  | montador esquadrias | 17.6h | 11,307.22 | 1. Casa 1 | 0. Térreo | 13. Esq. Alumínio 1 | Própria | 13 | 13 | 13 |
| 133 | 1.6.1.1.17 | 14. Portas |  | 2d | 2025-01-24 | 2025-01-27 | 132 | 0d |  | marceneiro [200%] | 35.2h | 2,827.85 | 1. Casa 1 | 0. Térreo | 14. Portas 1 | Própria | 14 | 14 | 14 |
| 134 | 1.6.1.1.18 | 15. Pintura (1ª Demão) |  | 4d | 2025-03-14 | 2025-03-20 | 482 | 0d |  | pintor [600%]; aux.pintor [300%] | 316.8h | 3,764.82 | 1. Casa 1 | 0. Térreo | 15. Pintura (1ª Demão) 1 | Própria | 15 | 15 | 15 |
| 135 | 1.6.1.1.19 | 16. Bancadas |  | 1d | 2025-05-29 | 2025-05-30 | 155SF | 80d | 0d | pedreiro [200%]; servente | 26.4h | 10,458.12 | 1. Casa 1 | 0. Térreo | 16. Bancadas 1 | Própria | 16 | 16 | 16 |
| 136 | 1.6.1.1.20 | 17. Pintura (2ª Demão) |  | 3d | 2025-06-23 | 2025-06-25 | 483 | 0d |  | pintor [600%]; aux.pintor [300%] | 237.6h | 1,563.98 | 1. Casa 1 | 0. Térreo | 17. Pintura (2ª Demão) 1 | Própria | 17 | 17 | 17 |
| 137 | 1.6.1.1.21 | 18. Limp. Interna |  | 1d | 2025-08-08 | 2025-08-11 | 157SF | 95d |  | Diarista [200%] | 17.6h | 418.75 | 1. Casa 1 | 0. Térreo | 18. Limp. Interna 1 | Própria | 18 | 18 | 18 |

| ID | WBS | Task | Duration | Start | Finish | Predecessors | Total slack | Free slack | Resources | Work | Cost | Casa | Pav | Equipe | Empresa | Pacote | Cor | LB |
| --- | --- | --- | --- | --- | --- | --- | --- | --- | --- | --- | --- | --- | --- | --- | --- | --- | --- | --- |
| 138 | 1.6.1.2 | **1. Pav. Superior** | 444d | 2023-10-18 | 2025-08-12 |  | 24d |  |  | 3229.6h | 114,879.9 |  |  |  |  |  |  |  |
| 139 | 1.6.1.2.1 | 2. Estrutura | 7d | 2023-10-18 | 2023-10-26 | 119 | 433d | 0d | servente estrutura [300%]; aux. Carpinteiro [200%]; aux. ferreiro [200%]; ferreiro [500%]; carpinteiro [200%] | 862.4h | 30,006.55 | 1. Casa 1 | 1. Pav. Superior | 2. Estrutura 1 | Própria |  |  |  |
| 140 | 1.6.1.2.2 | 3. Alvenarias | 5d | 2023-11-23 | 2023-11-29 | 120 | 0d |  | servente [400%]; pedreiro [400%] | 352h | 10,101.74 | 1. Casa 1 | 1. Pav. Superior | 3. Alvenarias 1 | Própria |  |  |  |
| 141 | 1.6.1.2.3 | 5. Ref. Inter. Arg (Parede) | 4d | 2024-05-20 | 2024-05-23 | 121 | 0d |  | pedreiro [600%]; servente [600%] | 422.4h | 5,398.69 | 1. Casa 1 | 1. Pav. Superior | 5. Ref. Inter. Arg (Parede) 1 | Própria |  |  |  |
| 142 | 1.6.1.2.4 | 6. Revest. Gesso (Parede + Teto) | 4d | 2024-06-06 | 2024-06-12 | 169SF | 385d | 0d | aux. gesseiro [200%]; gesseiro [400%] | 211.2h | 2,119.41 | 1. Casa 1 | 1. Pav. Superior | 6. Revest. Gesso (Parede + Teto) 1 | Própria |  |  |  |
| 143 | 1.6.1.2.5 | 7. Impermeabilização | 1d | 2024-07-01 | 2024-07-02 | 160SF | 371d | 0d | aplicador de manta | 8.8h | 2,046.85 | 1. Casa 1 | 1. Pav. Superior | 7. Impermeabilização 1 | Própria |  |  |  |
| 144 | 1.6.1.2.6 | 8. Contrapiso | 2d | 2024-07-05 | 2024-07-09 | 124SF | 366d |  | pedreiro [200%]; servente | 52.8h | 2,476.11 | 1. Casa 1 | 1. Pav. Superior | 8. Contrapiso 1 | Própria |  |  |  |
| 145 | 1.6.1.2.7 | 9.1. Chapisco | 0.5d | 2024-10-01 | 2024-10-01 | 125 | 148.5d | 0d | pedreiro [600%]; servente [400%] | 44h | 5,131.51 | 1. Casa 1 | 1. Pav. Superior | 9. Fachada 1 | Própria |  |  |  |
| 146 | 1.6.1.2.8 | 9.2. Emboço | 1.5d | 2024-10-23 | 2024-10-24 | 850 | 148.5d | 0d | pedreiro [600%]; servente [400%] | 132h | 7,697.26 | 1. Casa 1 | 1. Pav. Superior | 9. Fachada 1 | Própria |  |  |  |
| 147 | 1.6.1.2.9 | 9.3. Pint. 1 Demão | 1d | 2024-12-30 | 2024-12-31 | 851 | 148.5d | 0d | pintor [400%]; aux.pintor [200%] | 52.8h | 1,135.92 | 1. Casa 1 | 1. Pav. Superior | 9. Fachada 1 | Própria |  |  |  |
| 148 | 1.6.1.2.10 | 9.4. Pint. 2 Demão | 2d | 2025-02-12 | 2025-02-14 | 852 | 148.5d | 0d | pintor [400%]; aux.pintor [200%] | 105.6h | 757.28 | 1. Casa 1 | 1. Pav. Superior | 9. Fachada 1 | Própria |  |  |  |
| 149 | 1.6.1.2.11 | 10. Cer. Piso | 4d | 2024-09-19 | 2024-09-24 | 129 | 0d |  | servente [200%]; pedreiro [400%] | 211.2h | 19,807.17 | 1. Casa 1 | 1. Pav. Superior | 10. Cer. Piso 1 | Própria | 10 | 10 | 10 |
| 150 | 1.6.1.2.12 | 11. Cer. Parede | 2d | 2024-12-18 | 2024-12-19 | 130 | 0d |  | pedreiro [400%]; servente [200%] | 105.6h | 4,238.82 | 1. Casa 1 | 1. Pav. Superior | 11. Cer. Parede 1 | Própria | 11 | 11 | 11 |
| 151 | 1.6.1.2.13 | 12. Forro (WC's e cozinha) | 1d | 2025-01-21 | 2025-01-22 | 178SF | 0d |  | aux. gesseiro; gesseiro | 17.6h | 895 | 1. Casa 1 | 1. Pav. Superior | 12. Forro (WC's e cozinha) 1 | Própria | 12 | 12 | 12 |
| 152 | 1.6.1.2.14 | 13. Esq. Alumínio | 2d | 2025-01-24 | 2025-01-27 | 132 | 164d | 0d | montador esquadrias | 17.6h | 8,489.61 | 1. Casa 1 | 1. Pav. Superior | 13. Esq. Alumínio 1 | Própria | 13 | 13 | 13 |
| 153 | 1.6.1.2.15 | 14. Portas | 2d | 2025-01-28 | 2025-01-29 | 133 | 0d |  | marceneiro [200%] | 35.2h | 1,858.35 | 1. Casa 1 | 1. Pav. Superior | 14. Portas 1 | Própria | 14 | 14 | 14 |
| 154 | 1.6.1.2.16 | 15. Pintura (1ª Demão) | 4d | 2025-03-21 | 2025-03-27 | 134 | 0d |  | pintor [600%]; aux.pintor [300%] | 316.8h | 3,764.82 | 1. Casa 1 | 1. Pav. Superior | 15. Pintura (1ª Demão) 1 | Própria | 15 | 15 | 15 |
| 155 | 1.6.1.2.17 | 16. Bancadas | 1d | 2025-05-30 | 2025-06-02 | 182SF | 80d | 0d | servente; pedreiro [200%] | 26.4h | 6,972.08 | 1. Casa 1 | 1. Pav. Superior | 16. Bancadas 1 | Própria | 16 | 16 | 16 |
| 156 | 1.6.1.2.18 | 17. Pintura (2ª Demão) | 3d | 2025-06-26 | 2025-06-30 | 136 | 0d |  | aux.pintor [300%]; pintor [600%] | 237.6h | 1,563.98 | 1. Casa 1 | 1. Pav. Superior | 17. Pintura (2ª Demão) 1 | Própria | 17 | 17 | 17 |
| 157 | 1.6.1.2.19 | 18. Limp. Interna | 1d | 2025-08-11 | 2025-08-12 | 184SF | 94d | 0d | Diarista [200%] | 17.6h | 418.75 | 1. Casa 1 | 1. Pav. Superior | 18. Limp. Interna 1 | Própria | 18 | 18 | 18 |
| 158 | 1.6.1.3 | **2. Coberta** | 139d | 2023-11-30 | 2024-07-03 |  | 0d |  |  | 536.8h | 58,163.18 |  |  |  |  |  |  |  |
| 159 | 1.6.1.3.1 | 1. Alvenarias | 3d | 2023-11-30 | 2023-12-04 | 140 | 0d |  | pedreiro [400%]; servente [400%] | 211.2h | 9,834.12 | 1. Casa 1 | 2. Coberta | 3. Alvenarias 1 | Própria |  |  |  |
| 160 | 1.6.1.3.2 | 2. Impermeabilização | 1d | 2024-07-02 | 2024-07-03 | 170SF | 370d | 0d | aplicador de manta | 8.8h | 24,164.53 | 1. Casa 1 | 2. Coberta | 7. Impermeabilização 1 | Própria |  |  |  |
| 161 | 1.6.1.3.3 | 3. Coberta | 6d | 2024-02-23 | 2024-03-04 | 208SF | 451d |  | carpinteiro [400%]; aux. Carpinteiro [200%] | 316.8h | 24,164.53 | 1. Casa 1 | 2. Coberta | 4. Coberta 1 | Própria |  |  |  |

| ID | WBS | Task | Duration | Start | Finish | Predecessors | Total slack | Free slack | Resources | Work | Cost | Casa | Pav | Equipe | Empresa | Pacote | Cor | LB |
| --- | --- | --- | --- | --- | --- | --- | --- | --- | --- | --- | --- | --- | --- | --- | --- | --- | --- | --- |
| 162 | 1.6.2 | **2. Casa 2** | 478d | 2023-08-31 | 2025-08-14 |  | 1d |  |  | 7568h | 338,293.15 |  |  |  |  |  |  |  |
| 163 | 1.6.2.1 | **0. Térreo** | 477d | 2023-08-31 | 2025-08-13 |  | 1d |  |  | 3801.6h | 165,509.25 |  |  |  |  |  |  |  |
| 164 | 1.6.2.1.1 | 0. Locação | 2d | 2023-08-31 | 2023-09-01 | 117 | 1d | 0d | carpinteiro; aux. Carpinteiro | 35.2h | 456.99 | 2. Casa 2 | 0. Térreo | 0. Locação 1 | Própria |  |  |  |
| 165 | 1.6.2.1.2 | 1. Fundação | 9d | 2023-10-06 | 2023-10-19 | 118 | 482d | 0d | servente estrutura [300%]; aux. Carpinteiro; aux. ferreiro; ferreiro; carpinteiro [200%] | 633.6h | 19,882.86 | 2. Casa 2 | 0. Térreo | 1. Fundação 1 | Própria |  |  |  |
| 166 | 1.6.2.1.3 | 2. Estrutura | 7d | 2023-10-27 | 2023-11-07 | 139 | 433d | 0d | servente estrutura [300%]; aux. Carpinteiro [200%]; aux. ferreiro [200%]; ferreiro [500%]; carpinteiro [200%] | 862.4h | 46,439.03 | 2. Casa 2 | 0. Térreo | 2. Estrutura 1 | Própria |  |  |  |
| 167 | 1.6.2.1.4 | 3. Alvenarias | 5d | 2023-12-05 | 2023-12-11 | 159 | 0d |  | pedreiro [400%]; servente [400%] | 352h | 8,388.41 | 2. Casa 2 | 0. Térreo | 3. Alvenarias 1 | Própria |  |  |  |
| 168 | 1.6.2.1.5 | 5. Ref. Inter. Arg (Parede) | 3d | 2024-05-24 | 2024-05-28 | 141 | 0d |  | pedreiro [600%]; servente [600%] | 316.8h | 5,776 | 2. Casa 2 | 0. Térreo | 5. Ref. Inter. Arg (Parede) 1 | Própria |  |  |  |
| 169 | 1.6.2.1.6 | 6. Revest. Gesso (Parede + Teto) | 3d | 2024-06-12 | 2024-06-17 | 189SF | 382d | 0d | gesseiro [400%]; aux. gesseiro [200%] | 158.4h | 2,119.41 | 2. Casa 2 | 0. Térreo | 6. Revest. Gesso (Parede + Teto) 1 | Própria |  |  |  |
| 170 | 1.6.2.1.7 | 7. Impermeabilização | 2d | 2024-07-03 | 2024-07-05 | 190SF | 368d | 0d | aplicador de manta | 17.6h | 3,288.15 | 2. Casa 2 | 0. Térreo | 7. Impermeabilização 1 | Própria |  |  |  |
| 171 | 1.6.2.1.8 | 8. Contrapiso | 2d | 2024-07-15 | 2024-07-17 | 238SF | 296d | 0d | pedreiro [200%]; servente | 52.8h | 3,735.07 | 2. Casa 2 | 0. Térreo | 8. Contrapiso 1 | Própria |  |  |  |
| 172 | 1.6.2.1.9 | 9.1. Chapisco | 0.5d | 2024-10-02 | 2024-10-02 | 145 | 148.5d | 0d | pedreiro [600%]; servente [400%] | 44h | 5,131.51 | 2. Casa 2 | 0. Térreo | 9. Fachada 1 | Própria |  |  |  |
| 173 | 1.6.2.1.10 | 9.2. Emboço | 1.5d | 2024-10-29 | 2024-10-30 | 193 | 148.5d | 0d | pedreiro [600%]; servente [400%] | 132h | 7,697.26 | 2. Casa 2 | 0. Térreo | 9. Fachada 1 | Própria |  |  |  |
| 174 | 1.6.2.1.11 | 9.3. Pint. 1 Demão | 1d | 2025-01-03 | 2025-01-06 | 194 | 148.5d | 0d | pintor [400%]; aux.pintor [200%] | 52.8h | 1,135.92 | 2. Casa 2 | 0. Térreo | 9. Fachada 1 | Própria |  |  |  |
| 175 | 1.6.2.1.12 | 9.4. Pint. 2 Demão | 2d | 2025-02-20 | 2025-02-24 | 195 | 148.5d | 0d | pintor [400%]; aux.pintor [200%] | 105.6h | 757.28 | 2. Casa 2 | 0. Térreo | 9. Fachada 1 | Própria |  |  |  |
| 176 | 1.6.2.1.13 | 10. Cer. Piso | 4d | 2024-09-25 | 2024-09-30 | 149 | 0d |  | pedreiro [400%]; servente [200%] | 211.2h | 25,485.98 | 2. Casa 2 | 0. Térreo | 10. Cer. Piso 1 | Própria | 10 | 10 | 10 |
| 177 | 1.6.2.1.14 | 11. Cer. Parede | 3d | 2024-12-20 | 2024-12-24 | 150 | 0d |  | pedreiro [400%]; servente [200%] | 158.4h | 4,238.82 | 2. Casa 2 | 0. Térreo | 11. Cer. Parede 1 | Própria | 11 | 11 | 11 |
| 178 | 1.6.2.1.15 | 12. Forro (WC's e cozinha) | 1d | 2025-01-22 | 2025-01-23 | 198SF | 0d |  | gesseiro; aux. gesseiro | 17.6h | 635.82 | 2. Casa 2 | 0. Térreo | 12. Forro (WC's e cozinha) 1 | Própria | 12 | 12 | 12 |
| 179 | 1.6.2.1.16 | 13. Esq. Alumínio | 2d | 2025-01-28 | 2025-01-29 | 152 | 164d | 0d | montador esquadrias | 17.6h | 11,307.22 | 2. Casa 2 | 0. Térreo | 13. Esq. Alumínio 1 | Própria | 13 | 13 | 13 |
| 180 | 1.6.2.1.17 | 14. Portas | 2d | 2025-01-30 | 2025-01-31 | 153 | 0d |  | marceneiro [200%] | 35.2h | 2,827.85 | 2. Casa 2 | 0. Térreo | 14. Portas 1 | Própria | 14 | 14 | 14 |
| 181 | 1.6.2.1.18 | 15. Pintura (1ª Demão) | 4d | 2025-03-28 | 2025-04-02 | 154 | 0d |  | pintor [600%]; aux.pintor [300%] | 316.8h | 3,764.82 | 2. Casa 2 | 0. Térreo | 15. Pintura (1ª Demão) 1 | Própria | 15 | 15 | 15 |
| 182 | 1.6.2.1.19 | 16. Bancadas | 1d | 2025-06-02 | 2025-06-03 | 202SF | 80d | 0d | pedreiro [200%]; servente | 26.4h | 10,458.12 | 2. Casa 2 | 0. Térreo | 16. Bancadas 1 | Própria | 16 | 16 | 16 |
| 183 | 1.6.2.1.20 | 17. Pintura (2ª Demão) | 3d | 2025-07-01 | 2025-07-03 | 156 | 0d |  | pintor [600%]; aux.pintor [300%] | 237.6h | 1,563.98 | 2. Casa 2 | 0. Térreo | 17. Pintura (2ª Demão) 1 | Própria | 17 | 17 | 17 |
| 184 | 1.6.2.1.21 | 18. Limp. Interna | 1d | 2025-08-12 | 2025-08-13 | 204SF | 93d | 0d | Diarista [200%] | 17.6h | 418.75 | 2. Casa 2 | 0. Térreo | 18. Limp. Interna 1 | Própria | 18 | 18 | 18 |
| 185 | 1.6.2.2 | **1. Pav. Superior** | 432d | 2023-11-08 | 2025-08-14 |  | 23d |  |  | 3229.6h | 114,620.72 |  |  |  |  |  |  |  |
| 186 | 1.6.2.2.1 | 2. Estrutura | 7d | 2023-11-08 | 2023-11-17 | 166 | 433d | 0d | servente estrutura [300%]; aux. Carpinteiro [200%]; aux. ferreiro [200%]; ferreiro [500%]; carpinteiro [200%] | 862.4h | 30,006.55 | 2. Casa 2 | 1. Pav. Superior | 2. Estrutura 1 | Própria |  |  |  |
| 187 | 1.6.2.2.2 | 3. Alvenarias | 5d | 2023-12-12 | 2023-12-18 | 167 | 0d |  | servente [400%]; pedreiro [400%] | 352h | 10,101.74 | 2. Casa 2 | 1. Pav. Superior | 3. Alvenarias 1 | Própria |  |  |  |
| 188 | 1.6.2.2.3 | 5. Ref. Inter. Arg (Parede) | 4d | 2024-05-29 | 2024-06-05 | 168 | 0d |  | pedreiro [600%]; servente [600%] | 422.4h | 5,398.69 | 2. Casa 2 | 1. Pav. Superior | 5. Ref. Inter. Arg (Parede) 1 | Própria |  |  |  |
| 189 | 1.6.2.2.4 | 6. Revest. Gesso (Parede + Teto) | 4d | 2024-06-17 | 2024-06-21 | 216SF | 378d | 0d | aux. gesseiro [200%]; gesseiro [400%] | 211.2h | 2,119.41 | 2. Casa 2 | 1. Pav. Superior | 6. Revest. Gesso (Parede + Teto) 1 | Própria |  |  |  |
| 190 | 1.6.2.2.5 | 7. Impermeabilização | 1d | 2024-07-05 | 2024-07-08 | 207SF | 367d | 0d | aplicador de manta | 8.8h | 2,046.85 | 2. Casa 2 | 1. Pav. Superior | 7. Impermeabilização 1 | Própria |  |  |  |
| 191 | 1.6.2.2.6 | 8. Contrapiso | 2d | 2024-07-11 | 2024-07-15 | 171SF | 296d | 0d | pedreiro [200%]; servente | 52.8h | 2,476.11 | 2. Casa 2 | 1. Pav. Superior | 8. Contrapiso 1 | Própria |  |  |  |
| 192 | 1.6.2.2.7 | 9.1. Chapisco | 0.5d | 2024-10-02 | 2024-10-02 | 172 | 148.5d | 0d | pedreiro [600%]; servente [400%] | 44h | 5,131.51 | 2. Casa 2 | 1. Pav. Superior | 9. Fachada 1 | Própria |  |  |  |
| 193 | 1.6.2.2.8 | 9.2. Emboço | 1.5d | 2024-10-28 | 2024-10-29 | 126 | 148.5d | 0d | pedreiro [600%]; servente [400%] | 132h | 7,697.26 | 2. Casa 2 | 1. Pav. Superior | 9. Fachada 1 | Própria |  |  |  |
| 194 | 1.6.2.2.9 | 9.3. Pint. 1 Demão | 1d | 2025-01-02 | 2025-01-03 | 127 | 148.5d | 0d | pintor [400%]; aux.pintor [200%] | 52.8h | 1,135.92 | 2. Casa 2 | 1. Pav. Superior | 9. Fachada 1 | Própria |  |  |  |
| 195 | 1.6.2.2.10 | 9.4. Pint. 2 Demão | 2d | 2025-02-18 | 2025-02-20 | 128 | 148.5d | 0d | pintor [400%]; aux.pintor [200%] | 105.6h | 757.28 | 2. Casa 2 | 1. Pav. Superior | 9. Fachada 1 | Própria |  |  |  |
| 196 | 1.6.2.2.11 | 10. Cer. Piso | 4d | 2024-10-01 | 2024-10-04 | 176 | 0d |  | pedreiro [400%]; servente [200%] | 211.2h | 19,807.17 | 2. Casa 2 | 1. Pav. Superior | 10. Cer. Piso 1 | Própria | 10 | 10 | 10 |
| 197 | 1.6.2.2.12 | 11. Cer. Parede | 2d | 2024-12-26 | 2024-12-27 | 177 | 0d |  | pedreiro [400%]; servente [200%] | 105.6h | 4,238.82 | 2. Casa 2 | 1. Pav. Superior | 11. Cer. Parede 1 | Própria | 11 | 11 | 11 |
| 198 | 1.6.2.2.13 | 12. Forro (WC's e cozinha) | 1d | 2025-01-23 | 2025-01-24 | 225SF | 0d |  | gesseiro; aux. gesseiro | 17.6h | 635.82 | 2. Casa 2 | 1. Pav. Superior | 12. Forro (WC's e cozinha) 1 | Própria | 12 | 12 | 12 |
| 199 | 1.6.2.2.14 | 13. Esq. Alumínio | 2d | 2025-01-30 | 2025-01-31 | 179 | 164d | 0d | montador esquadrias | 17.6h | 8,489.61 | 2. Casa 2 | 1. Pav. Superior | 13. Esq. Alumínio 1 | Própria | 13 | 13 | 13 |
| 200 | 1.6.2.2.15 | 14. Portas | 2d | 2025-02-03 | 2025-02-04 | 180 | 0d |  | marceneiro [200%] | 35.2h | 1,858.35 | 2. Casa 2 | 1. Pav. Superior | 14. Portas 1 | Própria | 14 | 14 | 14 |
| 201 | 1.6.2.2.16 | 15. Pintura (1ª Demão) | 4d | 2025-04-03 | 2025-04-08 | 181 | 0d |  | pintor [600%]; aux.pintor [300%] | 316.8h | 3,764.82 | 2. Casa 2 | 1. Pav. Superior | 15. Pintura (1ª Demão) 1 | Própria | 15 | 15 | 15 |
| 202 | 1.6.2.2.17 | 16. Bancadas | 1d | 2025-06-03 | 2025-06-04 | 229SF | 80d | 0d | servente; pedreiro [200%] | 26.4h | 6,972.08 | 2. Casa 2 | 1. Pav. Superior | 16. Bancadas 1 | Própria | 16 | 16 | 16 |
| 203 | 1.6.2.2.18 | 17. Pintura (2ª Demão) | 3d | 2025-07-04 | 2025-07-08 | 183 | 0d |  | aux.pintor [300%]; pintor [600%] | 237.6h | 1,563.98 | 2. Casa 2 | 1. Pav. Superior | 17. Pintura (2ª Demão) 1 | Própria | 17 | 17 | 17 |
| 204 | 1.6.2.2.19 | 18. Limp. Interna | 1d | 2025-08-13 | 2025-08-14 | 231SF | 92d | 0d | Diarista [200%] | 17.6h | 418.75 | 2. Casa 2 | 1. Pav. Superior | 18. Limp. Interna 1 | Própria | 18 | 18 | 18 |

| ID | WBS | Task | Duration | Start | Finish | Predecessors | Total slack | Free slack | Resources | Work | Cost | Casa | Pav | Equipe | Empresa | Pacote | Cor | LB |
| --- | --- | --- | --- | --- | --- | --- | --- | --- | --- | --- | --- | --- | --- | --- | --- | --- | --- | --- |
| 205 | 1.6.2.3 | **2. Coberta** | 130d | 2023-12-19 | 2024-07-09 |  | 0d |  |  | 536.8h | 58,163.18 |  |  |  |  |  |  |  |
| 206 | 1.6.2.3.1 | 1. Alvenarias | 3d | 2023-12-19 | 2023-12-21 | 187 | 0d |  | pedreiro [400%]; servente [400%] | 211.2h | 9,834.12 | 2. Casa 2 | 2. Coberta | 3. Alvenarias 1 | Própria |  |  |  |
| 207 | 1.6.2.3.2 | 2. Impermeabilização | 1d | 2024-07-08 | 2024-07-09 | 217SF | 366d | 0d | aplicador de manta | 8.8h | 24,164.53 | 2. Casa 2 | 2. Coberta | 7. Impermeabilização 1 | Própria |  |  |  |
| 208 | 1.6.2.3.3 | 3. Coberta | 6d | 2024-03-04 | 2024-03-12 | 255SF | 445d | 0d | carpinteiro [400%]; aux. Carpinteiro [200%] | 316.8h | 24,164.53 | 2. Casa 2 | 2. Coberta | 4. Coberta 1 | Própria |  |  |  |
| 209 | 1.6.3 | **3. Casa 3** | 478d | 2023-09-04 | 2025-08-18 |  | 1d |  |  | 7568h | 338,552.33 |  |  |  |  |  |  |  |
| 210 | 1.6.3.1 | **0. Térreo** | 477d | 2023-09-04 | 2025-08-15 |  | 1d |  |  | 3801.6h | 165,768.43 |  |  |  |  |  |  |  |
| 211 | 1.6.3.1.1 | 0. Locação | 2d | 2023-09-04 | 2023-09-05 | 164 | 1d | 0d | carpinteiro; aux. Carpinteiro | 35.2h | 456.99 | 3. Casa 3 | 0. Térreo | 0. Locação 1 | Própria |  |  |  |
| 212 | 1.6.3.1.2 | 1. Fundação | 9d | 2023-10-20 | 2023-11-01 | 165 | 482d | 0d | servente estrutura [300%]; aux. Carpinteiro; aux. ferreiro; ferreiro; carpinteiro [200%] | 633.6h | 19,882.86 | 3. Casa 3 | 0. Térreo | 1. Fundação 1 | Própria |  |  |  |
| 213 | 1.6.3.1.3 | 2. Estrutura | 7d | 2023-11-20 | 2023-11-28 | 186 | 433d | 0d | servente estrutura [300%]; aux. Carpinteiro [200%]; aux. ferreiro [200%]; ferreiro [500%]; carpinteiro [200%] | 862.4h | 46,439.03 | 3. Casa 3 | 0. Térreo | 2. Estrutura 1 | Própria |  |  |  |
| 214 | 1.6.3.1.4 | 3. Alvenarias | 5d | 2023-12-22 | 2024-01-05 | 206 | 0d |  | pedreiro [400%]; servente [400%] | 352h | 8,388.41 | 3. Casa 3 | 0. Térreo | 3. Alvenarias 1 | Própria |  |  |  |
| 215 | 1.6.3.1.5 | 5. Ref. Inter. Arg (Parede) | 3d | 2024-06-06 | 2024-06-10 | 188 | 0d |  | pedreiro [600%]; servente [600%] | 316.8h | 5,776 | 3. Casa 3 | 0. Térreo | 5. Ref. Inter. Arg (Parede) 1 | Própria |  |  |  |
| 216 | 1.6.3.1.6 | 6. Revest. Gesso (Parede + Teto) | 3d | 2024-06-21 | 2024-06-26 | 236SF | 375d | 0d | gesseiro [400%]; aux. gesseiro [200%] | 158.4h | 2,119.41 | 3. Casa 3 | 0. Térreo | 6. Revest. Gesso (Parede + Teto) 1 | Própria |  |  |  |
| 217 | 1.6.3.1.7 | 7. Impermeabilização | 2d | 2024-07-09 | 2024-07-11 | 237SF | 364d | 0d | aplicador de manta | 17.6h | 3,288.15 | 3. Casa 3 | 0. Térreo | 7. Impermeabilização 1 | Própria |  |  |  |
| 218 | 1.6.3.1.8 | 8. Contrapiso | 2d | 2024-07-19 | 2024-07-23 | 285SF | 296d | 0d | pedreiro [200%]; servente | 52.8h | 3,735.07 | 3. Casa 3 | 0. Térreo | 8. Contrapiso 1 | Própria |  |  |  |
| 219 | 1.6.3.1.9 | 9.1. Chapisco | 0.5d | 2024-10-03 | 2024-10-03 | 192 | 148.5d | 0d | pedreiro [600%]; servente [400%] | 44h | 5,131.51 | 3. Casa 3 | 0. Térreo | 9. Fachada 1 | Própria |  |  |  |
| 220 | 1.6.3.1.10 | 9.2. Emboço | 1.5d | 2024-11-01 | 2024-11-04 | 240 | 148.5d | 0d | pedreiro [600%]; servente [400%] | 132h | 7,697.26 | 3. Casa 3 | 0. Térreo | 9. Fachada 1 | Própria |  |  |  |
| 221 | 1.6.3.1.11 | 9.3. Pint. 1 Demão | 1d | 2025-01-07 | 2025-01-08 | 241 | 148.5d | 0d | pintor [400%]; aux.pintor [200%] | 52.8h | 1,135.92 | 3. Casa 3 | 0. Térreo | 9. Fachada 1 | Própria |  |  |  |
| 222 | 1.6.3.1.12 | 9.4. Pint. 2 Demão | 2d | 2025-02-26 | 2025-02-28 | 242 | 148.5d | 0d | pintor [400%]; aux.pintor [200%] | 105.6h | 757.28 | 3. Casa 3 | 0. Térreo | 9. Fachada 1 | Própria |  |  |  |
| 223 | 1.6.3.1.13 | 10. Cer. Piso | 4d | 2024-10-07 | 2024-10-10 | 196 | 0d |  | pedreiro [400%]; servente [200%] | 211.2h | 25,485.98 | 3. Casa 3 | 0. Térreo | 10. Cer. Piso 1 | Própria | 10 | 10 | 10 |
| 224 | 1.6.3.1.14 | 11. Cer. Parede | 3d | 2024-12-30 | 2025-01-02 | 197 | 0d |  | pedreiro [400%]; servente [200%] | 158.4h | 4,238.82 | 3. Casa 3 | 0. Térreo | 11. Cer. Parede 1 | Própria | 11 | 11 | 11 |
| 225 | 1.6.3.1.15 | 12. Forro (WC's e cozinha) | 1d | 2025-01-24 | 2025-01-27 | 245SF | 0d |  | gesseiro; aux. gesseiro | 17.6h | 895 | 3. Casa 3 | 0. Térreo | 12. Forro (WC's e cozinha) 1 | Própria | 12 | 12 | 12 |
| 226 | 1.6.3.1.16 | 13. Esq. Alumínio | 2d | 2025-02-03 | 2025-02-04 | 199 | 164d | 0d | montador esquadrias | 17.6h | 11,307.22 | 3. Casa 3 | 0. Térreo | 13. Esq. Alumínio 1 | Própria | 13 | 13 | 13 |
| 227 | 1.6.3.1.17 | 14. Portas | 2d | 2025-02-05 | 2025-02-06 | 200 | 0d |  | marceneiro [200%] | 35.2h | 2,827.85 | 3. Casa 3 | 0. Térreo | 14. Portas 1 | Própria | 14 | 14 | 14 |
| 228 | 1.6.3.1.18 | 15. Pintura (1ª Demão) | 4d | 2025-04-09 | 2025-04-14 | 201 | 0d |  | pintor [600%]; aux.pintor [300%] | 316.8h | 3,764.82 | 3. Casa 3 | 0. Térreo | 15. Pintura (1ª Demão) 1 | Própria | 15 | 15 | 15 |
| 229 | 1.6.3.1.19 | 16. Bancadas | 1d | 2025-06-04 | 2025-06-05 | 249SF | 80d | 0d | pedreiro [200%]; servente | 26.4h | 10,458.12 | 3. Casa 3 | 0. Térreo | 16. Bancadas 1 | Própria | 16 | 16 | 16 |
| 230 | 1.6.3.1.20 | 17. Pintura (2ª Demão) | 3d | 2025-07-09 | 2025-07-11 | 203 | 0d |  | pintor [600%]; aux.pintor [300%] | 237.6h | 1,563.98 | 3. Casa 3 | 0. Térreo | 17. Pintura (2ª Demão) 1 | Própria | 17 | 17 | 17 |
| 231 | 1.6.3.1.21 | 18. Limp. Interna | 1d | 2025-08-14 | 2025-08-15 | 251SF | 91d | 0d | Diarista [200%] | 17.6h | 418.75 | 3. Casa 3 | 0. Térreo | 18. Limp. Interna 1 | Própria | 18 | 18 | 18 |

| ID | WBS | Task | Duration | Start | Finish | Predecessors | Total slack | Free slack | Resources | Work | Cost | Casa | Pav | Equipe | Empresa | Pacote | Cor | LB |
| --- | --- | --- | --- | --- | --- | --- | --- | --- | --- | --- | --- | --- | --- | --- | --- | --- | --- | --- |
| 232 | 1.6.3.2 | **1. Pav. Superior** | 420d | 2023-11-29 | 2025-08-18 |  | 22d |  |  | 3229.6h | 114,620.72 |  |  |  |  |  |  |  |
| 233 | 1.6.3.2.1 | 2. Estrutura | 7d | 2023-11-29 | 2023-12-07 | 213 | 433d | 0d | servente estrutura [300%]; aux. Carpinteiro [200%]; aux. ferreiro [200%]; ferreiro [500%]; carpinteiro [200%] | 862.4h | 30,006.55 | 3. Casa 3 | 1. Pav. Superior | 2. Estrutura 1 | Própria |  |  |  |
| 234 | 1.6.3.2.2 | 3. Alvenarias | 5d | 2024-01-08 | 2024-01-12 | 214 | 0d |  | servente [400%]; pedreiro [400%] | 352h | 10,101.74 | 3. Casa 3 | 1. Pav. Superior | 3. Alvenarias 1 | Própria |  |  |  |
| 235 | 1.6.3.2.3 | 5. Ref. Inter. Arg (Parede) | 4d | 2024-06-11 | 2024-06-14 | 215 | 0d |  | pedreiro [600%]; servente [600%] | 422.4h | 5,398.69 | 3. Casa 3 | 1. Pav. Superior | 5. Ref. Inter. Arg (Parede) 1 | Própria |  |  |  |
| 236 | 1.6.3.2.4 | 6. Revest. Gesso (Parede + Teto) | 4d | 2024-06-26 | 2024-07-02 | 263SF | 371d | 0d | aux. gesseiro [200%]; gesseiro [400%] | 211.2h | 2,119.41 | 3. Casa 3 | 1. Pav. Superior | 6. Revest. Gesso (Parede + Teto) 1 | Própria |  |  |  |
| 237 | 1.6.3.2.5 | 7. Impermeabilização | 1d | 2024-07-11 | 2024-07-12 | 254SF | 363d | 0d | aplicador de manta | 8.8h | 2,046.85 | 3. Casa 3 | 1. Pav. Superior | 7. Impermeabilização 1 | Própria |  |  |  |
| 238 | 1.6.3.2.6 | 8. Contrapiso | 2d | 2024-07-17 | 2024-07-19 | 218SF | 296d | 0d | pedreiro [200%]; servente | 52.8h | 2,476.11 | 3. Casa 3 | 1. Pav. Superior | 8. Contrapiso 1 | Própria |  |  |  |
| 239 | 1.6.3.2.7 | 9.1. Chapisco | 0.5d | 2024-10-03 | 2024-10-03 | 219 | 148.5d | 0d | pedreiro [600%]; servente [400%] | 44h | 5,131.51 | 3. Casa 3 | 1. Pav. Superior | 9. Fachada 1 | Própria |  |  |  |
| 240 | 1.6.3.2.8 | 9.2. Emboço | 1.5d | 2024-10-31 | 2024-11-01 | 173 | 148.5d | 0d | pedreiro [600%]; servente [400%] | 132h | 7,697.26 | 3. Casa 3 | 1. Pav. Superior | 9. Fachada 1 | Própria |  |  |  |
| 241 | 1.6.3.2.9 | 9.3. Pint. 1 Demão | 1d | 2025-01-06 | 2025-01-07 | 174 | 148.5d | 0d | pintor [400%]; aux.pintor [200%] | 52.8h | 1,135.92 | 3. Casa 3 | 1. Pav. Superior | 9. Fachada 1 | Própria |  |  |  |
| 242 | 1.6.3.2.10 | 9.4. Pint. 2 Demão | 2d | 2025-02-24 | 2025-02-26 | 175 | 148.5d | 0d | pintor [400%]; aux.pintor [200%] | 105.6h | 757.28 | 3. Casa 3 | 1. Pav. Superior | 9. Fachada 1 | Própria |  |  |  |
| 243 | 1.6.3.2.11 | 10. Cer. Piso | 4d | 2024-10-11 | 2024-10-16 | 223 | 0d |  | servente [200%]; pedreiro [400%] | 211.2h | 19,807.17 | 3. Casa 3 | 1. Pav. Superior | 10. Cer. Piso 1 | Própria | 10 | 10 | 10 |
| 244 | 1.6.3.2.12 | 11. Cer. Parede | 2d | 2025-01-03 | 2025-01-06 | 224 | 0d |  | pedreiro [400%]; servente [200%] | 105.6h | 4,238.82 | 3. Casa 3 | 1. Pav. Superior | 11. Cer. Parede 1 | Própria | 11 | 11 | 11 |
| 245 | 1.6.3.2.13 | 12. Forro (WC's e cozinha) | 1d | 2025-01-27 | 2025-01-28 | 272SF | 0d |  | aux. gesseiro; gesseiro | 17.6h | 635.82 | 3. Casa 3 | 1. Pav. Superior | 12. Forro (WC's e cozinha) 1 | Própria | 12 | 12 | 12 |
| 246 | 1.6.3.2.14 | 13. Esq. Alumínio | 2d | 2025-02-05 | 2025-02-06 | 226 | 164d | 0d | montador esquadrias | 17.6h | 8,489.61 | 3. Casa 3 | 1. Pav. Superior | 13. Esq. Alumínio 1 | Própria | 13 | 13 | 13 |
| 247 | 1.6.3.2.15 | 14. Portas | 2d | 2025-02-07 | 2025-02-10 | 227 | 0d |  | marceneiro [200%] | 35.2h | 1,858.35 | 3. Casa 3 | 1. Pav. Superior | 14. Portas 1 | Própria | 14 | 14 | 14 |
| 248 | 1.6.3.2.16 | 15. Pintura (1ª Demão) | 4d | 2025-04-15 | 2025-04-22 | 228 | 0d |  | pintor [600%]; aux.pintor [300%] | 316.8h | 3,764.82 | 3. Casa 3 | 1. Pav. Superior | 15. Pintura (1ª Demão) 1 | Própria | 15 | 15 | 15 |
| 249 | 1.6.3.2.17 | 16. Bancadas | 1d | 2025-06-05 | 2025-06-06 | 276SF | 80d | 0d | servente; pedreiro [200%] | 26.4h | 6,972.08 | 3. Casa 3 | 1. Pav. Superior | 16. Bancadas 1 | Própria | 16 | 16 | 16 |
| 250 | 1.6.3.2.18 | 17. Pintura (2ª Demão) | 3d | 2025-07-14 | 2025-07-16 | 230 | 0d |  | aux.pintor [300%]; pintor [600%] | 237.6h | 1,563.98 | 3. Casa 3 | 1. Pav. Superior | 17. Pintura (2ª Demão) 1 | Própria | 17 | 17 | 17 |
| 251 | 1.6.3.2.19 | 18. Limp. Interna | 1d | 2025-08-15 | 2025-08-18 | 278SF | 90d | 0d | Diarista [200%] | 17.6h | 418.75 | 3. Casa 3 | 1. Pav. Superior | 18. Limp. Interna 1 | Própria | 18 | 18 | 18 |
| 252 | 1.6.3.3 | **2. Coberta** | 121d | 2024-01-15 | 2024-07-15 |  | 0d |  |  | 536.8h | 58,163.18 |  |  |  |  |  |  |  |
| 253 | 1.6.3.3.1 | 1. Alvenarias | 3d | 2024-01-15 | 2024-01-17 | 234 | 0d |  | pedreiro [400%]; servente [400%] | 211.2h | 9,834.12 | 3. Casa 3 | 2. Coberta | 3. Alvenarias 1 | Própria |  |  |  |
| 254 | 1.6.3.3.2 | 2. Impermeabilização | 1d | 2024-07-12 | 2024-07-15 | 264SF | 362d | 0d | aplicador de manta | 8.8h | 24,164.53 | 3. Casa 3 | 2. Coberta | 7. Impermeabilização 1 | Própria |  |  |  |
| 255 | 1.6.3.3.3 | 3. Coberta | 6d | 2024-03-12 | 2024-03-21 | 302SF | 439d | 0d | carpinteiro [400%]; aux. Carpinteiro [200%] | 316.8h | 24,164.53 | 3. Casa 3 | 2. Coberta | 4. Coberta 1 | Própria |  |  |  |

| ID | WBS | Task | Duration | Start | Finish | Predecessors | Total slack | Free slack | Resources | Work | Cost | Casa | Pav | Equipe | Empresa | Pacote | Cor | LB |
| --- | --- | --- | --- | --- | --- | --- | --- | --- | --- | --- | --- | --- | --- | --- | --- | --- | --- | --- |
| 256 | 1.6.4 | **4. Casa 4** | 478d | 2023-09-06 | 2025-08-20 |  | 1d |  |  | 7568h | 338,552.33 |  |  |  |  |  |  |  |
| 257 | 1.6.4.1 | **0. Térreo** | 477d | 2023-09-06 | 2025-08-19 |  | 1d |  |  | 3801.6h | 165,768.43 |  |  |  |  |  |  |  |
| 258 | 1.6.4.1.1 | 0. Locação | 2d | 2023-09-06 | 2023-09-08 | 211 | 1d | 0d | carpinteiro; aux. Carpinteiro | 35.2h | 456.99 | 4. Casa 4 | 0. Térreo | 0. Locação 1 | Própria |  |  |  |
| 259 | 1.6.4.1.2 | 1. Fundação | 9d | 2023-11-03 | 2023-11-16 | 212 | 482d | 0d | servente estrutura [300%]; aux. Carpinteiro; aux. ferreiro; ferreiro; carpinteiro [200%] | 633.6h | 19,882.86 | 4. Casa 4 | 0. Térreo | 1. Fundação 1 | Própria |  |  |  |
| 260 | 1.6.4.1.3 | 2. Estrutura | 7d | 2023-12-08 | 2023-12-18 | 233 | 433d | 0d | servente estrutura [300%]; aux. Carpinteiro [200%]; aux. ferreiro [200%]; ferreiro [500%]; carpinteiro [200%] | 862.4h | 46,439.03 | 4. Casa 4 | 0. Térreo | 2. Estrutura 1 | Própria |  |  |  |
| 261 | 1.6.4.1.4 | 3. Alvenarias | 5d | 2024-01-18 | 2024-01-24 | 253 | 0d |  | pedreiro [400%]; servente [400%] | 352h | 8,388.41 | 4. Casa 4 | 0. Térreo | 3. Alvenarias 1 | Própria |  |  |  |
| 262 | 1.6.4.1.5 | 5. Ref. Inter. Arg (Parede) | 3d | 2024-06-17 | 2024-06-19 | 235 | 0d |  | pedreiro [600%]; servente [600%] | 316.8h | 5,776 | 4. Casa 4 | 0. Térreo | 5. Ref. Inter. Arg (Parede) 1 | Própria |  |  |  |
| 263 | 1.6.4.1.6 | 6. Revest. Gesso (Parede + Teto) | 3d | 2024-07-02 | 2024-07-05 | 283SF | 368d | 0d | gesseiro [400%]; aux. gesseiro [200%] | 158.4h | 2,119.41 | 4. Casa 4 | 0. Térreo | 6. Revest. Gesso (Parede + Teto) 1 | Própria |  |  |  |
| 264 | 1.6.4.1.7 | 7. Impermeabilização | 2d | 2024-07-15 | 2024-07-17 | 284SF | 360d | 0d | aplicador de manta | 17.6h | 3,288.15 | 4. Casa 4 | 0. Térreo | 7. Impermeabilização 1 | Própria |  |  |  |
| 265 | 1.6.4.1.8 | 8. Contrapiso | 2d | 2024-07-25 | 2024-07-29 | 332SF | 296d | 0d | pedreiro [200%]; servente | 52.8h | 3,735.07 | 4. Casa 4 | 0. Térreo | 8. Contrapiso 1 | Própria |  |  |  |
| 266 | 1.6.4.1.9 | 9.1. Chapisco | 0.5d | 2024-10-04 | 2024-10-04 | 239 | 148.5d | 0d | pedreiro [600%]; servente [400%] | 44h | 5,131.51 | 4. Casa 4 | 0. Térreo | 9. Fachada 1 | Própria |  |  |  |
| 267 | 1.6.4.1.10 | 9.2. Emboço | 1.5d | 2024-11-06 | 2024-11-07 | 287 | 148.5d | 0d | pedreiro [600%]; servente [400%] | 132h | 7,697.26 | 4. Casa 4 | 0. Térreo | 9. Fachada 1 | Própria |  |  |  |
| 268 | 1.6.4.1.11 | 9.3. Pint. 1 Demão | 1d | 2025-01-09 | 2025-01-10 | 288 | 148.5d | 0d | pintor [400%]; aux.pintor [200%] | 52.8h | 1,135.92 | 4. Casa 4 | 0. Térreo | 9. Fachada 1 | Própria |  |  |  |
| 269 | 1.6.4.1.12 | 9.4. Pint. 2 Demão | 2d | 2025-03-07 | 2025-03-11 | 289 | 148.5d | 0d | pintor [400%]; aux.pintor [200%] | 105.6h | 757.28 | 4. Casa 4 | 0. Térreo | 9. Fachada 1 | Própria |  |  |  |
| 270 | 1.6.4.1.13 | 10. Cer. Piso | 4d | 2024-10-17 | 2024-10-22 | 243 | 0d |  | pedreiro [400%]; servente [200%] | 211.2h | 25,485.98 | 4. Casa 4 | 0. Térreo | 10. Cer. Piso 1 | Própria | 10 | 10 | 10 |
| 271 | 1.6.4.1.14 | 11. Cer. Parede | 3d | 2025-01-07 | 2025-01-09 | 244 | 0d |  | pedreiro [400%]; servente [200%] | 158.4h | 4,238.82 | 4. Casa 4 | 0. Térreo | 11. Cer. Parede 1 | Própria | 11 | 11 | 11 |
| 272 | 1.6.4.1.15 | 12. Forro (WC's e cozinha) | 1d | 2025-01-28 | 2025-01-29 | 292SF | 0d |  | gesseiro; aux. gesseiro | 17.6h | 895 | 4. Casa 4 | 0. Térreo | 12. Forro (WC's e cozinha) 1 | Própria | 12 | 12 | 12 |
| 273 | 1.6.4.1.16 | 13. Esq. Alumínio | 2d | 2025-02-07 | 2025-02-10 | 246 | 164d | 0d | montador esquadrias | 17.6h | 11,307.22 | 4. Casa 4 | 0. Térreo | 13. Esq. Alumínio 1 | Própria | 13 | 13 | 13 |
| 274 | 1.6.4.1.17 | 14. Portas | 2d | 2025-02-11 | 2025-02-12 | 247 | 0d |  | marceneiro [200%] | 35.2h | 2,827.85 | 4. Casa 4 | 0. Térreo | 14. Portas 1 | Própria | 14 | 14 | 14 |
| 275 | 1.6.4.1.18 | 15. Pintura (1ª Demão) | 4d | 2025-04-23 | 2025-04-28 | 248 | 0d |  | pintor [600%]; aux.pintor [300%] | 316.8h | 3,764.82 | 4. Casa 4 | 0. Térreo | 15. Pintura (1ª Demão) 1 | Própria | 15 | 15 | 15 |
| 276 | 1.6.4.1.19 | 16. Bancadas | 1d | 2025-06-06 | 2025-06-09 | 296SF | 80d | 0d | pedreiro [200%]; servente | 26.4h | 10,458.12 | 4. Casa 4 | 0. Térreo | 16. Bancadas 1 | Própria | 16 | 16 | 16 |
| 277 | 1.6.4.1.20 | 17. Pintura (2ª Demão) | 3d | 2025-07-17 | 2025-07-21 | 250 | 0d |  | pintor [600%]; aux.pintor [300%] | 237.6h | 1,563.98 | 4. Casa 4 | 0. Térreo | 17. Pintura (2ª Demão) 1 | Própria | 17 | 17 | 17 |
| 278 | 1.6.4.1.21 | 18. Limp. Interna | 1d | 2025-08-18 | 2025-08-19 | 298SF | 89d | 0d | Diarista [200%] | 17.6h | 418.75 | 4. Casa 4 | 0. Térreo | 18. Limp. Interna 1 | Própria | 18 | 18 | 18 |
| 279 | 1.6.4.2 | **1. Pav. Superior** | 408d | 2023-12-19 | 2025-08-20 |  | 21d |  |  | 3229.6h | 114,620.72 |  |  |  |  |  |  |  |
| 280 | 1.6.4.2.1 | 2. Estrutura | 7d | 2023-12-19 | 2024-01-04 | 260 | 433d | 0d | servente estrutura [300%]; aux. Carpinteiro [200%]; aux. ferreiro [200%]; ferreiro [500%]; carpinteiro [200%] | 862.4h | 30,006.55 | 4. Casa 4 | 1. Pav. Superior | 2. Estrutura 1 | Própria |  |  |  |
| 281 | 1.6.4.2.2 | 3. Alvenarias | 5d | 2024-01-25 | 2024-01-31 | 261 | 0d |  | servente [400%]; pedreiro [400%] | 352h | 10,101.74 | 4. Casa 4 | 1. Pav. Superior | 3. Alvenarias 1 | Própria |  |  |  |
| 282 | 1.6.4.2.3 | 5. Ref. Inter. Arg (Parede) | 4d | 2024-06-20 | 2024-06-25 | 262 | 0d |  | pedreiro [600%]; servente [600%] | 422.4h | 5,398.69 | 4. Casa 4 | 1. Pav. Superior | 5. Ref. Inter. Arg (Parede) 1 | Própria |  |  |  |
| 283 | 1.6.4.2.4 | 6. Revest. Gesso (Parede + Teto) | 4d | 2024-07-05 | 2024-07-11 | 310SF | 364d | 0d | aux. gesseiro [200%]; gesseiro [400%] | 211.2h | 2,119.41 | 4. Casa 4 | 1. Pav. Superior | 6. Revest. Gesso (Parede + Teto) 1 | Própria |  |  |  |
| 284 | 1.6.4.2.5 | 7. Impermeabilização | 1d | 2024-07-17 | 2024-07-18 | 301SF | 359d | 0d | aplicador de manta | 8.8h | 2,046.85 | 4. Casa 4 | 1. Pav. Superior | 7. Impermeabilização 1 | Própria |  |  |  |
| 285 | 1.6.4.2.6 | 8. Contrapiso | 2d | 2024-07-23 | 2024-07-25 | 265SF | 296d | 0d | pedreiro [200%]; servente | 52.8h | 2,476.11 | 4. Casa 4 | 1. Pav. Superior | 8. Contrapiso 1 | Própria |  |  |  |
| 286 | 1.6.4.2.7 | 9.1. Chapisco | 0.5d | 2024-10-04 | 2024-10-04 | 266 | 148.5d | 0d | pedreiro [600%]; servente [400%] | 44h | 5,131.51 | 4. Casa 4 | 1. Pav. Superior | 9. Fachada 1 | Própria |  |  |  |
| 287 | 1.6.4.2.8 | 9.2. Emboço | 1.5d | 2024-11-05 | 2024-11-06 | 220 | 148.5d | 0d | pedreiro [600%]; servente [400%] | 132h | 7,697.26 | 4. Casa 4 | 1. Pav. Superior | 9. Fachada 1 | Própria |  |  |  |
| 288 | 1.6.4.2.9 | 9.3. Pint. 1 Demão | 1d | 2025-01-08 | 2025-01-09 | 221 | 148.5d | 0d | pintor [400%]; aux.pintor [200%] | 52.8h | 1,135.92 | 4. Casa 4 | 1. Pav. Superior | 9. Fachada 1 | Própria |  |  |  |
| 289 | 1.6.4.2.10 | 9.4. Pint. 2 Demão | 2d | 2025-02-28 | 2025-03-07 | 222 | 148.5d | 0d | pintor [400%]; aux.pintor [200%] | 105.6h | 757.28 | 4. Casa 4 | 1. Pav. Superior | 9. Fachada 1 | Própria |  |  |  |
| 290 | 1.6.4.2.11 | 10. Cer. Piso | 4d | 2024-10-23 | 2024-10-28 | 270 | 0d |  | pedreiro [400%]; servente [200%] | 211.2h | 19,807.17 | 4. Casa 4 | 1. Pav. Superior | 10. Cer. Piso 1 | Própria | 10 | 10 | 10 |
| 291 | 1.6.4.2.12 | 11. Cer. Parede | 2d | 2025-01-10 | 2025-01-13 | 271 | 0d |  | pedreiro [400%]; servente [200%] | 105.6h | 4,238.82 | 4. Casa 4 | 1. Pav. Superior | 11. Cer. Parede 1 | Própria | 11 | 11 | 11 |
| 292 | 1.6.4.2.13 | 12. Forro (WC's e cozinha) | 1d | 2025-01-29 | 2025-01-30 | 319SF | 0d |  | aux. gesseiro; gesseiro | 17.6h | 635.82 | 4. Casa 4 | 1. Pav. Superior | 12. Forro (WC's e cozinha) 1 | Própria | 12 | 12 | 12 |
| 293 | 1.6.4.2.14 | 13. Esq. Alumínio | 2d | 2025-02-11 | 2025-02-12 | 273 | 164d | 0d | montador esquadrias | 17.6h | 8,489.61 | 4. Casa 4 | 1. Pav. Superior | 13. Esq. Alumínio 1 | Própria | 13 | 13 | 13 |
| 294 | 1.6.4.2.15 | 14. Portas | 2d | 2025-02-13 | 2025-02-14 | 274 | 0d |  | marceneiro [200%] | 35.2h | 1,858.35 | 4. Casa 4 | 1. Pav. Superior | 14. Portas 1 | Própria | 14 | 14 | 14 |
| 295 | 1.6.4.2.16 | 15. Pintura (1ª Demão) | 4d | 2025-04-29 | 2025-05-05 | 275 | 0d |  | pintor [600%]; aux.pintor [300%] | 316.8h | 3,764.82 | 4. Casa 4 | 1. Pav. Superior | 15. Pintura (1ª Demão) 1 | Própria | 15 | 15 | 15 |
| 296 | 1.6.4.2.17 | 16. Bancadas | 1d | 2025-06-09 | 2025-06-10 | 323SF | 80d | 0d | servente; pedreiro [200%] | 26.4h | 6,972.08 | 4. Casa 4 | 1. Pav. Superior | 16. Bancadas 1 | Própria | 16 | 16 | 16 |
| 297 | 1.6.4.2.18 | 17. Pintura (2ª Demão) | 3d | 2025-07-22 | 2025-07-24 | 277 | 0d |  | aux.pintor [300%]; pintor [600%] | 237.6h | 1,563.98 | 4. Casa 4 | 1. Pav. Superior | 17. Pintura (2ª Demão) 1 | Própria | 17 | 17 | 17 |
| 298 | 1.6.4.2.19 | 18. Limp. Interna | 1d | 2025-08-19 | 2025-08-20 | 325SF | 88d | 0d | Diarista [200%] | 17.6h | 418.75 | 4. Casa 4 | 1. Pav. Superior | 18. Limp. Interna 1 | Própria | 18 | 18 | 18 |

| ID | WBS | Task | Duration | Start | Finish | Predecessors | Total slack | Free slack | Resources | Work | Cost | Casa | Pav | Equipe | Empresa | Pacote | Cor | LB |
| --- | --- | --- | --- | --- | --- | --- | --- | --- | --- | --- | --- | --- | --- | --- | --- | --- | --- | --- |
| 299 | 1.6.4.3 | **2. Coberta** | 112d | 2024-02-01 | 2024-07-19 |  | 0d |  |  | 536.8h | 58,163.18 |  |  |  |  |  |  |  |
| 300 | 1.6.4.3.1 | 1. Alvenarias | 3d | 2024-02-01 | 2024-02-05 | 281 | 0d |  | pedreiro [400%]; servente [400%] | 211.2h | 9,834.12 | 4. Casa 4 | 2. Coberta | 3. Alvenarias 1 | Própria |  |  |  |
| 301 | 1.6.4.3.2 | 2. Impermeabilização | 1d | 2024-07-18 | 2024-07-19 | 311SF | 358d | 0d | aplicador de manta | 8.8h | 24,164.53 | 4. Casa 4 | 2. Coberta | 7. Impermeabilização 1 | Própria |  |  |  |
| 302 | 1.6.4.3.3 | 3. Coberta | 6d | 2024-03-21 | 2024-04-02 | 349SF | 433d | 0d | carpinteiro [400%]; aux. Carpinteiro [200%] | 316.8h | 24,164.53 | 4. Casa 4 | 2. Coberta | 4. Coberta 1 | Própria |  |  |  |
| 303 | 1.6.5 | **5. Casa 5** | 478d | 2023-09-11 | 2025-08-22 |  | 1d |  |  | 7568h | 338,552.33 |  |  |  |  |  |  |  |
| 304 | 1.6.5.1 | **0. Térreo** | 477d | 2023-09-11 | 2025-08-21 |  | 1d |  |  | 3801.6h | 165,768.43 |  |  |  |  |  |  |  |
| 305 | 1.6.5.1.1 | 0. Locação | 2d | 2023-09-11 | 2023-09-12 | 258 | 1d | 0d | carpinteiro; aux. Carpinteiro | 35.2h | 456.99 | 5. Casa 5 | 0. Térreo | 0. Locação 1 | Própria |  |  |  |
| 306 | 1.6.5.1.2 | 1. Fundação | 9d | 2023-11-17 | 2023-11-29 | 259 | 482d | 0d | servente estrutura [300%]; aux. Carpinteiro; aux. ferreiro; ferreiro; carpinteiro [200%] | 633.6h | 19,882.86 | 5. Casa 5 | 0. Térreo | 1. Fundação 1 | Própria |  |  |  |
| 307 | 1.6.5.1.3 | 2. Estrutura | 7d | 2024-01-05 | 2024-01-15 | 280 | 433d | 0d | servente estrutura [300%]; aux. Carpinteiro [200%]; aux. ferreiro [200%]; ferreiro [500%]; carpinteiro [200%] | 862.4h | 46,439.03 | 5. Casa 5 | 0. Térreo | 2. Estrutura 1 | Própria |  |  |  |
| 308 | 1.6.5.1.4 | 3. Alvenarias | 5d | 2024-02-06 | 2024-02-15 | 300 | 0d |  | pedreiro [400%]; servente [400%] | 352h | 8,388.41 | 5. Casa 5 | 0. Térreo | 3. Alvenarias 1 | Própria |  |  |  |
| 309 | 1.6.5.1.5 | 5. Ref. Inter. Arg (Parede) | 3d | 2024-06-26 | 2024-06-28 | 282 | 0d |  | pedreiro [600%]; servente [600%] | 316.8h | 5,776 | 5. Casa 5 | 0. Térreo | 5. Ref. Inter. Arg (Parede) 1 | Própria |  |  |  |
| 310 | 1.6.5.1.6 | 6. Revest. Gesso (Parede + Teto) | 3d | 2024-07-11 | 2024-07-16 | 330SF | 361d | 0d | gesseiro [400%]; aux. gesseiro [200%] | 158.4h | 2,119.41 | 5. Casa 5 | 0. Térreo | 6. Revest. Gesso (Parede + Teto) 1 | Própria |  |  |  |
| 311 | 1.6.5.1.7 | 7. Impermeabilização | 2d | 2024-07-19 | 2024-07-23 | 331SF | 356d | 0d | aplicador de manta | 17.6h | 3,288.15 | 5. Casa 5 | 0. Térreo | 7. Impermeabilização 1 | Própria |  |  |  |
| 312 | 1.6.5.1.8 | 8. Contrapiso | 2d | 2024-07-31 | 2024-08-02 | 379SF | 296d | 0d | pedreiro [200%]; servente | 52.8h | 3,735.07 | 5. Casa 5 | 0. Térreo | 8. Contrapiso 1 | Própria |  |  |  |
| 313 | 1.6.5.1.9 | 9.1. Chapisco | 0.5d | 2024-10-07 | 2024-10-07 | 286 | 148.5d | 0d | pedreiro [600%]; servente [400%] | 44h | 5,131.51 | 5. Casa 5 | 0. Térreo | 9. Fachada 1 | Própria |  |  |  |
| 314 | 1.6.5.1.10 | 9.2. Emboço | 1.5d | 2024-11-11 | 2024-11-12 | 334 | 148.5d | 0d | pedreiro [600%]; servente [400%] | 132h | 7,697.26 | 5. Casa 5 | 0. Térreo | 9. Fachada 1 | Própria |  |  |  |
| 315 | 1.6.5.1.11 | 9.3. Pint. 1 Demão | 1d | 2025-01-13 | 2025-01-14 | 335 | 148.5d | 0d | pintor [400%]; aux.pintor [200%] | 52.8h | 1,135.92 | 5. Casa 5 | 0. Térreo | 9. Fachada 1 | Própria |  |  |  |
| 316 | 1.6.5.1.12 | 9.4. Pint. 2 Demão | 2d | 2025-03-13 | 2025-03-17 | 336 | 148.5d | 0d | pintor [400%]; aux.pintor [200%] | 105.6h | 757.28 | 5. Casa 5 | 0. Térreo | 9. Fachada 1 | Própria |  |  |  |
| 317 | 1.6.5.1.13 | 10. Cer. Piso | 4d | 2024-10-29 | 2024-11-01 | 290 | 0d |  | pedreiro [400%]; servente [200%] | 211.2h | 25,485.98 | 5. Casa 5 | 0. Térreo | 10. Cer. Piso 1 | Própria | 10 | 10 | 10 |
| 318 | 1.6.5.1.14 | 11. Cer. Parede | 3d | 2025-01-14 | 2025-01-16 | 291 | 0d |  | pedreiro [400%]; servente [200%] | 158.4h | 4,238.82 | 5. Casa 5 | 0. Térreo | 11. Cer. Parede 1 | Própria | 11 | 11 | 11 |
| 319 | 1.6.5.1.15 | 12. Forro (WC's e cozinha) | 1d | 2025-01-30 | 2025-01-31 | 339SF | 0d |  | gesseiro; aux. gesseiro | 17.6h | 895 | 5. Casa 5 | 0. Térreo | 12. Forro (WC's e cozinha) 1 | Própria | 12 | 12 | 12 |
| 320 | 1.6.5.1.16 | 13. Esq. Alumínio | 2d | 2025-02-13 | 2025-02-14 | 293 | 164d | 0d | montador esquadrias | 17.6h | 11,307.22 | 5. Casa 5 | 0. Térreo | 13. Esq. Alumínio 1 | Própria | 13 | 13 | 13 |
| 321 | 1.6.5.1.17 | 14. Portas | 2d | 2025-02-17 | 2025-02-18 | 294 | 0d |  | marceneiro [200%] | 35.2h | 2,827.85 | 5. Casa 5 | 0. Térreo | 14. Portas 1 | Própria | 14 | 14 | 14 |
| 322 | 1.6.5.1.18 | 15. Pintura (1ª Demão) | 4d | 2025-05-06 | 2025-05-09 | 295 | 0d |  | pintor [600%]; aux.pintor [300%] | 316.8h | 3,764.82 | 5. Casa 5 | 0. Térreo | 15. Pintura (1ª Demão) 1 | Própria | 15 | 15 | 15 |
| 323 | 1.6.5.1.19 | 16. Bancadas | 1d | 2025-06-10 | 2025-06-11 | 343SF | 80d | 0d | pedreiro [200%]; servente | 26.4h | 10,458.12 | 5. Casa 5 | 0. Térreo | 16. Bancadas 1 | Própria | 16 | 16 | 16 |
| 324 | 1.6.5.1.20 | 17. Pintura (2ª Demão) | 3d | 2025-07-25 | 2025-07-29 | 297 | 0d |  | pintor [600%]; aux.pintor [300%] | 237.6h | 1,563.98 | 5. Casa 5 | 0. Térreo | 17. Pintura (2ª Demão) 1 | Própria | 17 | 17 | 17 |
| 325 | 1.6.5.1.21 | 18. Limp. Interna | 1d | 2025-08-20 | 2025-08-21 | 345SF | 87d | 0d | Diarista [200%] | 17.6h | 418.75 | 5. Casa 5 | 0. Térreo | 18. Limp. Interna 1 | Própria | 18 | 18 | 18 |

| ID | WBS | Task | Duration | Start | Finish | Predecessors | Total slack | Free slack | Resources | Work | Cost | Casa | Pav | Equipe | Empresa | Pacote | Cor | LB |
| --- | --- | --- | --- | --- | --- | --- | --- | --- | --- | --- | --- | --- | --- | --- | --- | --- | --- | --- |
| 326 | 1.6.5.2 | **1. Pav. Superior** | 396d | 2024-01-16 | 2025-08-22 |  | 20d |  |  | 3229.6h | 114,620.72 |  |  |  |  |  |  |  |
| 327 | 1.6.5.2.1 | 2. Estrutura | 7d | 2024-01-16 | 2024-01-24 | 307 | 433d | 0d | servente estrutura [300%]; aux. Carpinteiro [200%]; aux. ferreiro [200%]; ferreiro [500%]; carpinteiro [200%] | 862.4h | 30,006.55 | 5. Casa 5 | 1. Pav. Superior | 2. Estrutura 1 | Própria |  |  |  |
| 328 | 1.6.5.2.2 | 3. Alvenarias | 5d | 2024-02-16 | 2024-02-22 | 308 | 0d |  | servente [400%]; pedreiro [400%] | 352h | 10,101.74 | 5. Casa 5 | 1. Pav. Superior | 3. Alvenarias 1 | Própria |  |  |  |
| 329 | 1.6.5.2.3 | 5. Ref. Inter. Arg (Parede) | 4d | 2024-07-01 | 2024-07-04 | 309 | 0d |  | pedreiro [600%]; servente [600%] | 422.4h | 5,398.69 | 5. Casa 5 | 1. Pav. Superior | 5. Ref. Inter. Arg (Parede) 1 | Própria |  |  |  |
| 330 | 1.6.5.2.4 | 6. Revest. Gesso (Parede + Teto) | 4d | 2024-07-16 | 2024-07-22 | 357SF | 357d | 0d | aux. gesseiro [200%]; gesseiro [400%] | 211.2h | 2,119.41 | 5. Casa 5 | 1. Pav. Superior | 6. Revest. Gesso (Parede + Teto) 1 | Própria |  |  |  |
| 331 | 1.6.5.2.5 | 7. Impermeabilização | 1d | 2024-07-23 | 2024-07-24 | 348SF | 355d | 0d | aplicador de manta | 8.8h | 2,046.85 | 5. Casa 5 | 1. Pav. Superior | 7. Impermeabilização 1 | Própria |  |  |  |
| 332 | 1.6.5.2.6 | 8. Contrapiso | 2d | 2024-07-29 | 2024-07-31 | 312SF | 296d | 0d | pedreiro [200%]; servente | 52.8h | 2,476.11 | 5. Casa 5 | 1. Pav. Superior | 8. Contrapiso 1 | Própria |  |  |  |
| 333 | 1.6.5.2.7 | 9.1. Chapisco | 0.5d | 2024-10-07 | 2024-10-07 | 313 | 148.5d | 0d | pedreiro [600%]; servente [400%] | 44h | 5,131.51 | 5. Casa 5 | 1. Pav. Superior | 9. Fachada 1 | Própria |  |  |  |
| 334 | 1.6.5.2.8 | 9.2. Emboço | 1.5d | 2024-11-08 | 2024-11-11 | 267 | 148.5d | 0d | pedreiro [600%]; servente [400%] | 132h | 7,697.26 | 5. Casa 5 | 1. Pav. Superior | 9. Fachada 1 | Própria |  |  |  |
| 335 | 1.6.5.2.9 | 9.3. Pint. 1 Demão | 1d | 2025-01-10 | 2025-01-13 | 268 | 148.5d | 0d | pintor [400%]; aux.pintor [200%] | 52.8h | 1,135.92 | 5. Casa 5 | 1. Pav. Superior | 9. Fachada 1 | Própria |  |  |  |
| 336 | 1.6.5.2.10 | 9.4. Pint. 2 Demão | 2d | 2025-03-11 | 2025-03-13 | 269 | 148.5d | 0d | pintor [400%]; aux.pintor [200%] | 105.6h | 757.28 | 5. Casa 5 | 1. Pav. Superior | 9. Fachada 1 | Própria |  |  |  |
| 337 | 1.6.5.2.11 | 10. Cer. Piso | 4d | 2024-11-04 | 2024-11-07 | 317 | 0d |  | servente [200%]; pedreiro [400%] | 211.2h | 19,807.17 | 5. Casa 5 | 1. Pav. Superior | 10. Cer. Piso 1 | Própria | 10 | 10 | 10 |
| 338 | 1.6.5.2.12 | 11. Cer. Parede | 2d | 2025-01-17 | 2025-01-20 | 318 | 0d |  | pedreiro [400%]; servente [200%] | 105.6h | 4,238.82 | 5. Casa 5 | 1. Pav. Superior | 11. Cer. Parede 1 | Própria | 11 | 11 | 11 |
| 339 | 1.6.5.2.13 | 12. Forro (WC's e cozinha) | 1d | 2025-01-31 | 2025-02-03 | 366SF | 0d |  | aux. gesseiro; gesseiro | 17.6h | 635.82 | 5. Casa 5 | 1. Pav. Superior | 12. Forro (WC's e cozinha) 1 | Própria | 12 | 12 | 12 |
| 340 | 1.6.5.2.14 | 13. Esq. Alumínio | 2d | 2025-02-17 | 2025-02-18 | 320 | 164d | 0d | montador esquadrias | 17.6h | 8,489.61 | 5. Casa 5 | 1. Pav. Superior | 13. Esq. Alumínio 1 | Própria | 13 | 13 | 13 |
| 341 | 1.6.5.2.15 | 14. Portas | 2d | 2025-02-19 | 2025-02-20 | 321 | 0d |  | marceneiro [200%] | 35.2h | 1,858.35 | 5. Casa 5 | 1. Pav. Superior | 14. Portas 1 | Própria | 14 | 14 | 14 |
| 342 | 1.6.5.2.16 | 15. Pintura (1ª Demão) | 4d | 2025-05-12 | 2025-05-15 | 322 | 0d |  | pintor [600%]; aux.pintor [300%] | 316.8h | 3,764.82 | 5. Casa 5 | 1. Pav. Superior | 15. Pintura (1ª Demão) 1 | Própria | 15 | 15 | 15 |
| 343 | 1.6.5.2.17 | 16. Bancadas | 1d | 2025-06-11 | 2025-06-12 | 370SF | 80d | 0d | servente; pedreiro [200%] | 26.4h | 6,972.08 | 5. Casa 5 | 1. Pav. Superior | 16. Bancadas 1 | Própria | 16 | 16 | 16 |
| 344 | 1.6.5.2.18 | 17. Pintura (2ª Demão) | 3d | 2025-07-30 | 2025-08-01 | 324 | 0d |  | aux.pintor [300%]; pintor [600%] | 237.6h | 1,563.98 | 5. Casa 5 | 1. Pav. Superior | 17. Pintura (2ª Demão) 1 | Própria | 17 | 17 | 17 |
| 345 | 1.6.5.2.19 | 18. Limp. Interna | 1d | 2025-08-21 | 2025-08-22 | 372SF | 86d | 0d | Diarista [200%] | 17.6h | 418.75 | 5. Casa 5 | 1. Pav. Superior | 18. Limp. Interna 1 | Própria | 18 | 18 | 18 |
| 346 | 1.6.5.3 | **2. Coberta** | 103d | 2024-02-23 | 2024-07-25 |  | 0d |  |  | 536.8h | 58,163.18 |  |  |  |  |  |  |  |
| 347 | 1.6.5.3.1 | 1. Alvenarias | 3d | 2024-02-23 | 2024-02-27 | 328 | 0d |  | pedreiro [400%]; servente [400%] | 211.2h | 9,834.12 | 5. Casa 5 | 2. Coberta | 3. Alvenarias 1 | Própria |  |  |  |
| 348 | 1.6.5.3.2 | 2. Impermeabilização | 1d | 2024-07-24 | 2024-07-25 | 358SF | 354d | 0d | aplicador de manta | 8.8h | 24,164.53 | 5. Casa 5 | 2. Coberta | 7. Impermeabilização 1 | Própria |  |  |  |
| 349 | 1.6.5.3.3 | 3. Coberta | 6d | 2024-04-02 | 2024-04-10 | 396SF | 427d | 0d | carpinteiro [400%]; aux. Carpinteiro [200%] | 316.8h | 24,164.53 | 5. Casa 5 | 2. Coberta | 4. Coberta 1 | Própria |  |  |  |

| ID | WBS | Task | Duration | Start | Finish | Predecessors | Total slack | Free slack | Resources | Work | Cost | Casa | Pav | Equipe | Empresa | Pacote | Cor | LB |
| --- | --- | --- | --- | --- | --- | --- | --- | --- | --- | --- | --- | --- | --- | --- | --- | --- | --- | --- |
| 350 | 1.6.6 | **6. Casa 6** | 478d | 2023-09-13 | 2025-08-26 |  | 1d |  |  | 7568h | 338,552.33 |  |  |  |  |  |  |  |
| 351 | 1.6.6.1 | **0. Térreo** | 477d | 2023-09-13 | 2025-08-25 |  | 1d |  |  | 3801.6h | 165,509.25 |  |  |  |  |  |  |  |
| 352 | 1.6.6.1.1 | 0. Locação | 2d | 2023-09-13 | 2023-09-14 | 305 | 1d | 0d | carpinteiro; aux. Carpinteiro | 35.2h | 456.99 | 6. Casa 6 | 0. Térreo | 0. Locação 1 | Própria |  |  |  |
| 353 | 1.6.6.1.2 | 1. Fundação | 9d | 2023-11-30 | 2023-12-12 | 306 | 482d | 0d | servente estrutura [300%]; aux. Carpinteiro; aux. ferreiro; ferreiro; carpinteiro [200%] | 633.6h | 19,882.86 | 6. Casa 6 | 0. Térreo | 1. Fundação 1 | Própria |  |  |  |
| 354 | 1.6.6.1.3 | 2. Estrutura | 7d | 2024-01-25 | 2024-02-02 | 327 | 433d | 0d | servente estrutura [300%]; aux. Carpinteiro [200%]; aux. ferreiro [200%]; ferreiro [500%]; carpinteiro [200%] | 862.4h | 46,439.03 | 6. Casa 6 | 0. Térreo | 2. Estrutura 1 | Própria |  |  |  |
| 355 | 1.6.6.1.4 | 3. Alvenarias | 5d | 2024-02-28 | 2024-03-05 | 347 | 0d |  | pedreiro [400%]; servente [400%] | 352h | 8,388.41 | 6. Casa 6 | 0. Térreo | 3. Alvenarias 1 | Própria |  |  |  |
| 356 | 1.6.6.1.5 | 5. Ref. Inter. Arg (Parede) | 3d | 2024-07-05 | 2024-07-09 | 329 | 0d |  | pedreiro [600%]; servente [600%] | 316.8h | 5,776 | 6. Casa 6 | 0. Térreo | 5. Ref. Inter. Arg (Parede) 1 | Própria |  |  |  |
| 357 | 1.6.6.1.6 | 6. Revest. Gesso (Parede + Teto) | 3d | 2024-07-22 | 2024-07-25 | 377SF | 354d | 0d | gesseiro [400%]; aux. gesseiro [200%] | 158.4h | 2,119.41 | 6. Casa 6 | 0. Térreo | 6. Revest. Gesso (Parede + Teto) 1 | Própria |  |  |  |
| 358 | 1.6.6.1.7 | 7. Impermeabilização | 2d | 2024-07-25 | 2024-07-29 | 378SF | 352d | 0d | aplicador de manta | 17.6h | 3,288.15 | 6. Casa 6 | 0. Térreo | 7. Impermeabilização 1 | Própria |  |  |  |
| 359 | 1.6.6.1.8 | 8. Contrapiso | 2d | 2024-08-06 | 2024-08-08 | 426SF | 296d | 0d | pedreiro [200%]; servente | 52.8h | 3,735.07 | 6. Casa 6 | 0. Térreo | 8. Contrapiso 1 | Própria |  |  |  |
| 360 | 1.6.6.1.9 | 9.1. Chapisco | 0.5d | 2024-10-08 | 2024-10-08 | 333 | 148.5d | 0d | pedreiro [600%]; servente [400%] | 44h | 5,131.51 | 6. Casa 6 | 0. Térreo | 9. Fachada 1 | Própria |  |  |  |
| 361 | 1.6.6.1.10 | 9.2. Emboço | 1.5d | 2024-11-14 | 2024-11-18 | 381 | 148.5d | 0d | pedreiro [600%]; servente [400%] | 132h | 7,697.26 | 6. Casa 6 | 0. Térreo | 9. Fachada 1 | Própria |  |  |  |
| 362 | 1.6.6.1.11 | 9.3. Pint. 1 Demão | 1d | 2025-01-15 | 2025-01-16 | 382 | 148.5d | 0d | pintor [400%]; aux.pintor [200%] | 52.8h | 1,135.92 | 6. Casa 6 | 0. Térreo | 9. Fachada 1 | Própria |  |  |  |
| 363 | 1.6.6.1.12 | 9.4. Pint. 2 Demão | 2d | 2025-03-20 | 2025-03-24 | 383 | 148.5d | 0d | pintor [400%]; aux.pintor [200%] | 105.6h | 757.28 | 6. Casa 6 | 0. Térreo | 9. Fachada 1 | Própria |  |  |  |
| 364 | 1.6.6.1.13 | 10. Cer. Piso | 4d | 2024-11-08 | 2024-11-13 | 337 | 0d |  | pedreiro [400%]; servente [200%] | 211.2h | 25,485.98 | 6. Casa 6 | 0. Térreo | 10. Cer. Piso 1 | Própria | 10 | 10 | 10 |
| 365 | 1.6.6.1.14 | 11. Cer. Parede | 3d | 2025-01-21 | 2025-01-23 | 338 | 0d |  | pedreiro [400%]; servente [200%] | 158.4h | 4,238.82 | 6. Casa 6 | 0. Térreo | 11. Cer. Parede 1 | Própria | 11 | 11 | 11 |
| 366 | 1.6.6.1.15 | 12. Forro (WC's e cozinha) | 1d | 2025-02-03 | 2025-02-04 | 386SF | 0d |  | gesseiro; aux. gesseiro | 17.6h | 635.82 | 6. Casa 6 | 0. Térreo | 12. Forro (WC's e cozinha) 1 | Própria | 12 | 12 | 12 |
| 367 | 1.6.6.1.16 | 13. Esq. Alumínio | 2d | 2025-02-19 | 2025-02-20 | 340 | 164d | 0d | montador esquadrias | 17.6h | 11,307.22 | 6. Casa 6 | 0. Térreo | 13. Esq. Alumínio 1 | Própria | 13 | 13 | 13 |
| 368 | 1.6.6.1.17 | 14. Portas | 2d | 2025-02-21 | 2025-02-24 | 341 | 0d |  | marceneiro [200%] | 35.2h | 2,827.85 | 6. Casa 6 | 0. Térreo | 14. Portas 1 | Própria | 14 | 14 | 14 |
| 369 | 1.6.6.1.18 | 15. Pintura (1ª Demão) | 4d | 2025-05-16 | 2025-05-21 | 342 | 0d |  | pintor [600%]; aux.pintor [300%] | 316.8h | 3,764.82 | 6. Casa 6 | 0. Térreo | 15. Pintura (1ª Demão) 1 | Própria | 15 | 15 | 15 |
| 370 | 1.6.6.1.19 | 16. Bancadas | 1d | 2025-06-12 | 2025-06-13 | 390SF | 80d | 0d | pedreiro [200%]; servente | 26.4h | 10,458.12 | 6. Casa 6 | 0. Térreo | 16. Bancadas 1 | Própria | 16 | 16 | 16 |
| 371 | 1.6.6.1.20 | 17. Pintura (2ª Demão) | 3d | 2025-08-04 | 2025-08-06 | 344 | 0d |  | pintor [600%]; aux.pintor [300%] | 237.6h | 1,563.98 | 6. Casa 6 | 0. Térreo | 17. Pintura (2ª Demão) 1 | Própria | 17 | 17 | 17 |
| 372 | 1.6.6.1.21 | 18. Limp. Interna | 1d | 2025-08-22 | 2025-08-25 | 392SF | 85d | 0d | Diarista [200%] | 17.6h | 418.75 | 6. Casa 6 | 0. Térreo | 18. Limp. Interna 1 | Própria | 18 | 18 | 18 |
| 373 | 1.6.6.2 | **1. Pav. Superior** | 384d | 2024-02-05 | 2025-08-26 |  | 19d |  |  | 3229.6h | 114,879.9 |  |  |  |  |  |  |  |
| 374 | 1.6.6.2.1 | 2. Estrutura | 7d | 2024-02-05 | 2024-02-16 | 354 | 433d | 0d | servente estrutura [300%]; aux. Carpinteiro [200%]; aux. ferreiro [200%]; ferreiro [500%]; carpinteiro [200%] | 862.4h | 30,006.55 | 6. Casa 6 | 1. Pav. Superior | 2. Estrutura 1 | Própria |  |  |  |
| 375 | 1.6.6.2.2 | 3. Alvenarias | 5d | 2024-03-06 | 2024-03-12 | 355 | 0d |  | servente [400%]; pedreiro [400%] | 352h | 10,101.74 | 6. Casa 6 | 1. Pav. Superior | 3. Alvenarias 1 | Própria |  |  |  |
| 376 | 1.6.6.2.3 | 5. Ref. Inter. Arg (Parede) | 4d | 2024-07-10 | 2024-07-15 | 356 | 0d |  | pedreiro [600%]; servente [600%] | 422.4h | 5,398.69 | 6. Casa 6 | 1. Pav. Superior | 5. Ref. Inter. Arg (Parede) 1 | Própria |  |  |  |
| 377 | 1.6.6.2.4 | 6. Revest. Gesso (Parede + Teto) | 4d | 2024-07-25 | 2024-07-31 | 404SF | 350d | 0d | aux. gesseiro [200%]; gesseiro [400%] | 211.2h | 2,119.41 | 6. Casa 6 | 1. Pav. Superior | 6. Revest. Gesso (Parede + Teto) 1 | Própria |  |  |  |
| 378 | 1.6.6.2.5 | 7. Impermeabilização | 1d | 2024-07-29 | 2024-07-30 | 395SF | 351d | 0d | aplicador de manta | 8.8h | 2,046.85 | 6. Casa 6 | 1. Pav. Superior | 7. Impermeabilização 1 | Própria |  |  |  |
| 379 | 1.6.6.2.6 | 8. Contrapiso | 2d | 2024-08-02 | 2024-08-06 | 359SF | 296d | 0d | pedreiro [200%]; servente | 52.8h | 2,476.11 | 6. Casa 6 | 1. Pav. Superior | 8. Contrapiso 1 | Própria |  |  |  |
| 380 | 1.6.6.2.7 | 9.1. Chapisco | 0.5d | 2024-10-08 | 2024-10-08 | 360 | 148.5d | 0d | pedreiro [600%]; servente [400%] | 44h | 5,131.51 | 6. Casa 6 | 1. Pav. Superior | 9. Fachada 1 | Própria |  |  |  |
| 381 | 1.6.6.2.8 | 9.2. Emboço | 1.5d | 2024-11-13 | 2024-11-14 | 314 | 148.5d | 0d | pedreiro [600%]; servente [400%] | 132h | 7,697.26 | 6. Casa 6 | 1. Pav. Superior | 9. Fachada 1 | Própria |  |  |  |
| 382 | 1.6.6.2.9 | 9.3. Pint. 1 Demão | 1d | 2025-01-14 | 2025-01-15 | 315 | 148.5d | 0d | pintor [400%]; aux.pintor [200%] | 52.8h | 1,135.92 | 6. Casa 6 | 1. Pav. Superior | 9. Fachada 1 | Própria |  |  |  |
| 383 | 1.6.6.2.10 | 9.4. Pint. 2 Demão | 2d | 2025-03-17 | 2025-03-20 | 316 | 148.5d | 0d | pintor [400%]; aux.pintor [200%] | 105.6h | 757.28 | 6. Casa 6 | 1. Pav. Superior | 9. Fachada 1 | Própria |  |  |  |
| 384 | 1.6.6.2.11 | 10. Cer. Piso | 4d | 2024-11-14 | 2024-11-20 | 364 | 0d |  | pedreiro [400%]; servente [200%] | 211.2h | 19,807.17 | 6. Casa 6 | 1. Pav. Superior | 10. Cer. Piso 1 | Própria | 10 | 10 | 10 |
| 385 | 1.6.6.2.12 | 11. Cer. Parede | 2d | 2025-01-24 | 2025-01-27 | 365 | 0d |  | pedreiro [400%]; servente [200%] | 105.6h | 4,238.82 | 6. Casa 6 | 1. Pav. Superior | 11. Cer. Parede 1 | Própria | 11 | 11 | 11 |
| 386 | 1.6.6.2.13 | 12. Forro (WC's e cozinha) | 1d | 2025-02-04 | 2025-02-05 | 413SF | 0d |  | aux. gesseiro; gesseiro | 17.6h | 895 | 6. Casa 6 | 1. Pav. Superior | 12. Forro (WC's e cozinha) 1 | Própria | 12 | 12 | 12 |
| 387 | 1.6.6.2.14 | 13. Esq. Alumínio | 2d | 2025-02-21 | 2025-02-24 | 367 | 164d | 0d | montador esquadrias | 17.6h | 8,489.61 | 6. Casa 6 | 1. Pav. Superior | 13. Esq. Alumínio 1 | Própria | 13 | 13 | 13 |
| 388 | 1.6.6.2.15 | 14. Portas | 2d | 2025-02-25 | 2025-02-26 | 368 | 0d |  | marceneiro [200%] | 35.2h | 1,858.35 | 6. Casa 6 | 1. Pav. Superior | 14. Portas 1 | Própria | 14 | 14 | 14 |
| 389 | 1.6.6.2.16 | 15. Pintura (1ª Demão) | 4d | 2025-05-22 | 2025-05-27 | 369 | 0d |  | pintor [600%]; aux.pintor [300%] | 316.8h | 3,764.82 | 6. Casa 6 | 1. Pav. Superior | 15. Pintura (1ª Demão) 1 | Própria | 15 | 15 | 15 |
| 390 | 1.6.6.2.17 | 16. Bancadas | 1d | 2025-06-13 | 2025-06-16 | 417SF | 80d | 0d | servente; pedreiro [200%] | 26.4h | 6,972.08 | 6. Casa 6 | 1. Pav. Superior | 16. Bancadas 1 | Própria | 16 | 16 | 16 |
| 391 | 1.6.6.2.18 | 17. Pintura (2ª Demão) | 3d | 2025-08-07 | 2025-08-11 | 371 | 0d |  | aux.pintor [300%]; pintor [600%] | 237.6h | 1,563.98 | 6. Casa 6 | 1. Pav. Superior | 17. Pintura (2ª Demão) 1 | Própria | 17 | 17 | 17 |
| 392 | 1.6.6.2.19 | 18. Limp. Interna | 1d | 2025-08-25 | 2025-08-26 | 419SF | 84d | 0d | Diarista [200%] | 17.6h | 418.75 | 6. Casa 6 | 1. Pav. Superior | 18. Limp. Interna 1 | Própria | 18 | 18 | 18 |

| ID | WBS | Task | Duration | Start | Finish | Predecessors | Total slack | Free slack | Resources | Work | Cost | Casa | Pav | Equipe | Empresa | Pacote | Cor | LB |
| --- | --- | --- | --- | --- | --- | --- | --- | --- | --- | --- | --- | --- | --- | --- | --- | --- | --- | --- |
| 393 | 1.6.6.3 | **2. Coberta** | 94d | 2024-03-13 | 2024-07-31 |  | 0d |  |  | 536.8h | 58,163.18 |  |  |  |  |  |  |  |
| 394 | 1.6.6.3.1 | 1. Alvenarias | 3d | 2024-03-13 | 2024-03-15 | 375 | 0d |  | pedreiro [400%]; servente [400%] | 211.2h | 9,834.12 | 6. Casa 6 | 2. Coberta | 3. Alvenarias 1 | Própria |  |  |  |
| 395 | 1.6.6.3.2 | 2. Impermeabilização | 1d | 2024-07-30 | 2024-07-31 | 405SF | 350d | 0d | aplicador de manta | 8.8h | 24,164.53 | 6. Casa 6 | 2. Coberta | 7. Impermeabilização 1 | Própria |  |  |  |
| 396 | 1.6.6.3.3 | 3. Coberta | 6d | 2024-04-10 | 2024-04-18 | 443SF | 421d | 0d | carpinteiro [400%]; aux. Carpinteiro [200%] | 316.8h | 24,164.53 | 6. Casa 6 | 2. Coberta | 4. Coberta 1 | Própria |  |  |  |
| 397 | 1.6.7 | **7. Casa 7** | 478d | 2023-09-15 | 2025-08-28 |  | 1d |  |  | 7568h | 338,552.33 |  |  |  |  |  |  |  |
| 398 | 1.6.7.1 | **0. Térreo** | 477d | 2023-09-15 | 2025-08-27 |  | 1d |  |  | 3801.6h | 165,509.25 |  |  |  |  |  |  |  |
| 399 | 1.6.7.1.1 | 0. Locação | 2d | 2023-09-15 | 2023-09-18 | 352 | 1d | 0d | carpinteiro; aux. Carpinteiro | 35.2h | 456.99 | 7. Casa 7 | 0. Térreo | 0. Locação 1 | Própria |  |  |  |
| 400 | 1.6.7.1.2 | 1. Fundação | 9d | 2023-12-13 | 2024-01-02 | 353 | 482d | 0d | servente estrutura [300%]; aux. Carpinteiro; aux. ferreiro; ferreiro; carpinteiro [200%] | 633.6h | 19,882.86 | 7. Casa 7 | 0. Térreo | 1. Fundação 1 | Própria |  |  |  |
| 401 | 1.6.7.1.3 | 2. Estrutura | 7d | 2024-02-19 | 2024-02-27 | 374 | 433d | 0d | servente estrutura [300%]; aux. Carpinteiro [200%]; aux. ferreiro [200%]; ferreiro [500%]; carpinteiro [200%] | 862.4h | 46,439.03 | 7. Casa 7 | 0. Térreo | 2. Estrutura 1 | Própria |  |  |  |
| 402 | 1.6.7.1.4 | 3. Alvenarias | 5d | 2024-03-18 | 2024-03-26 | 394 | 0d |  | pedreiro [400%]; servente [400%] | 352h | 8,388.41 | 7. Casa 7 | 0. Térreo | 3. Alvenarias 1 | Própria |  |  |  |
| 403 | 1.6.7.1.5 | 5. Ref. Inter. Arg (Parede) | 3d | 2024-07-16 | 2024-07-18 | 376 | 0d |  | pedreiro [600%]; servente [600%] | 316.8h | 5,776 | 7. Casa 7 | 0. Térreo | 5. Ref. Inter. Arg (Parede) 1 | Própria |  |  |  |
| 404 | 1.6.7.1.6 | 6. Revest. Gesso (Parede + Teto) | 3d | 2024-07-31 | 2024-08-05 | 424SF | 347d | 0d | gesseiro [400%]; aux. gesseiro [200%] | 158.4h | 2,119.41 | 7. Casa 7 | 0. Térreo | 6. Revest. Gesso (Parede + Teto) 1 | Própria |  |  |  |
| 405 | 1.6.7.1.7 | 7. Impermeabilização | 2d | 2024-07-31 | 2024-08-02 | 425SF | 348d | 0d | aplicador de manta | 17.6h | 3,288.15 | 7. Casa 7 | 0. Térreo | 7. Impermeabilização 1 | Própria |  |  |  |
| 406 | 1.6.7.1.8 | 8. Contrapiso | 2d | 2024-08-12 | 2024-08-14 | 473SF | 296d | 0d | pedreiro [200%]; servente | 52.8h | 3,735.07 | 7. Casa 7 | 0. Térreo | 8. Contrapiso 1 | Própria |  |  |  |
| 407 | 1.6.7.1.9 | 9.1. Chapisco | 0.5d | 2024-10-09 | 2024-10-09 | 380 | 148.5d | 0d | pedreiro [600%]; servente [400%] | 44h | 5,131.51 | 7. Casa 7 | 0. Térreo | 9. Fachada 1 | Própria |  |  |  |
| 408 | 1.6.7.1.10 | 9.2. Emboço | 1.5d | 2024-11-20 | 2024-11-21 | 428 | 148.5d | 0d | pedreiro [600%]; servente [400%] | 132h | 7,697.26 | 7. Casa 7 | 0. Térreo | 9. Fachada 1 | Própria |  |  |  |
| 409 | 1.6.7.1.11 | 9.3. Pint. 1 Demão | 1d | 2025-01-17 | 2025-01-20 | 429 | 148.5d | 0d | pintor [400%]; aux.pintor [200%] | 52.8h | 1,135.92 | 7. Casa 7 | 0. Térreo | 9. Fachada 1 | Própria |  |  |  |
| 410 | 1.6.7.1.12 | 9.4. Pint. 2 Demão | 2d | 2025-03-27 | 2025-03-31 | 430 | 148.5d | 0d | pintor [400%]; aux.pintor [200%] | 105.6h | 757.28 | 7. Casa 7 | 0. Térreo | 9. Fachada 1 | Própria |  |  |  |
| 411 | 1.6.7.1.13 | 10. Cer. Piso | 4d | 2024-11-21 | 2024-11-26 | 384 | 0d |  | pedreiro [400%]; servente [200%] | 211.2h | 25,485.98 | 7. Casa 7 | 0. Térreo | 10. Cer. Piso 1 | Própria | 10 | 10 | 10 |
| 412 | 1.6.7.1.14 | 11. Cer. Parede | 3d | 2025-01-28 | 2025-01-30 | 385 | 0d |  | pedreiro [400%]; servente [200%] | 158.4h | 4,238.82 | 7. Casa 7 | 0. Térreo | 11. Cer. Parede 1 | Própria | 11 | 11 | 11 |
| 413 | 1.6.7.1.15 | 12. Forro (WC's e cozinha) | 1d | 2025-02-05 | 2025-02-06 | 433SF | 0d |  | gesseiro; aux. gesseiro | 17.6h | 635.82 | 7. Casa 7 | 0. Térreo | 12. Forro (WC's e cozinha) 1 | Própria | 12 | 12 | 12 |
| 414 | 1.6.7.1.16 | 13. Esq. Alumínio | 2d | 2025-02-25 | 2025-02-26 | 387 | 164d | 0d | montador esquadrias | 17.6h | 11,307.22 | 7. Casa 7 | 0. Térreo | 13. Esq. Alumínio 1 | Própria | 13 | 13 | 13 |
| 415 | 1.6.7.1.17 | 14. Portas | 2d | 2025-02-27 | 2025-02-28 | 388 | 0d |  | marceneiro [200%] | 35.2h | 2,827.85 | 7. Casa 7 | 0. Térreo | 14. Portas 1 | Própria | 14 | 14 | 14 |
| 416 | 1.6.7.1.18 | 15. Pintura (1ª Demão) | 4d | 2025-05-28 | 2025-06-02 | 389 | 0d |  | pintor [600%]; aux.pintor [300%] | 316.8h | 3,764.82 | 7. Casa 7 | 0. Térreo | 15. Pintura (1ª Demão) 1 | Própria | 15 | 15 | 15 |
| 417 | 1.6.7.1.19 | 16. Bancadas | 1d | 2025-06-16 | 2025-06-17 | 437SF | 80d | 0d | pedreiro [200%]; servente | 26.4h | 10,458.12 | 7. Casa 7 | 0. Térreo | 16. Bancadas 1 | Própria | 16 | 16 | 16 |
| 418 | 1.6.7.1.20 | 17. Pintura (2ª Demão) | 3d | 2025-08-12 | 2025-08-14 | 391 | 0d |  | pintor [600%]; aux.pintor [300%] | 237.6h | 1,563.98 | 7. Casa 7 | 0. Térreo | 17. Pintura (2ª Demão) 1 | Própria | 17 | 17 | 17 |
| 419 | 1.6.7.1.21 | 18. Limp. Interna | 1d | 2025-08-26 | 2025-08-27 | 439SF | 83d | 0d | Diarista [200%] | 17.6h | 418.75 | 7. Casa 7 | 0. Térreo | 18. Limp. Interna 1 | Própria | 18 | 18 | 18 |

| ID | WBS | Task | Duration | Start | Finish | Predecessors | Total slack | Free slack | Resources | Work | Cost | Casa | Pav | Equipe | Empresa | Pacote | Cor | LB |
| --- | --- | --- | --- | --- | --- | --- | --- | --- | --- | --- | --- | --- | --- | --- | --- | --- | --- | --- |
| 420 | 1.6.7.2 | **1. Pav. Superior** | 372d | 2024-02-28 | 2025-08-28 |  | 18d |  |  | 3229.6h | 114,879.9 |  |  |  |  |  |  |  |
| 421 | 1.6.7.2.1 | 2. Estrutura | 7d | 2024-02-28 | 2024-03-07 | 401 | 433d | 0d | servente estrutura [300%]; aux. Carpinteiro [200%]; aux. ferreiro [200%]; ferreiro [500%]; carpinteiro [200%] | 862.4h | 30,006.55 | 7. Casa 7 | 1. Pav. Superior | 2. Estrutura 1 | Própria |  |  |  |
| 422 | 1.6.7.2.2 | 3. Alvenarias | 5d | 2024-03-27 | 2024-04-03 | 402 | 0d |  | servente [400%]; pedreiro [400%] | 352h | 10,101.74 | 7. Casa 7 | 1. Pav. Superior | 3. Alvenarias 1 | Própria |  |  |  |
| 423 | 1.6.7.2.3 | 5. Ref. Inter. Arg (Parede) | 4d | 2024-07-19 | 2024-07-24 | 403 | 0d |  | pedreiro [600%]; servente [600%] | 422.4h | 5,398.69 | 7. Casa 7 | 1. Pav. Superior | 5. Ref. Inter. Arg (Parede) 1 | Própria |  |  |  |
| 424 | 1.6.7.2.4 | 6. Revest. Gesso (Parede + Teto) | 4d | 2024-08-05 | 2024-08-09 | 451SF | 343d | 0d | aux. gesseiro [200%]; gesseiro [400%] | 211.2h | 2,119.41 | 7. Casa 7 | 1. Pav. Superior | 6. Revest. Gesso (Parede + Teto) 1 | Própria |  |  |  |
| 425 | 1.6.7.2.5 | 7. Impermeabilização | 1d | 2024-08-02 | 2024-08-05 | 442SF | 347d | 0d | aplicador de manta | 8.8h | 2,046.85 | 7. Casa 7 | 1. Pav. Superior | 7. Impermeabilização 1 | Própria |  |  |  |
| 426 | 1.6.7.2.6 | 8. Contrapiso | 2d | 2024-08-08 | 2024-08-12 | 406SF | 296d | 0d | pedreiro [200%]; servente | 52.8h | 2,476.11 | 7. Casa 7 | 1. Pav. Superior | 8. Contrapiso 1 | Própria |  |  |  |
| 427 | 1.6.7.2.7 | 9.1. Chapisco | 0.5d | 2024-10-09 | 2024-10-09 | 407 | 148.5d | 0d | pedreiro [600%]; servente [400%] | 44h | 5,131.51 | 7. Casa 7 | 1. Pav. Superior | 9. Fachada 1 | Própria |  |  |  |
| 428 | 1.6.7.2.8 | 9.2. Emboço | 1.5d | 2024-11-19 | 2024-11-20 | 361 | 148.5d | 0d | pedreiro [600%]; servente [400%] | 132h | 7,697.26 | 7. Casa 7 | 1. Pav. Superior | 9. Fachada 1 | Própria |  |  |  |
| 429 | 1.6.7.2.9 | 9.3. Pint. 1 Demão | 1d | 2025-01-16 | 2025-01-17 | 362 | 148.5d | 0d | pintor [400%]; aux.pintor [200%] | 52.8h | 1,135.92 | 7. Casa 7 | 1. Pav. Superior | 9. Fachada 1 | Própria |  |  |  |
| 430 | 1.6.7.2.10 | 9.4. Pint. 2 Demão | 2d | 2025-03-24 | 2025-03-27 | 363 | 148.5d | 0d | pintor [400%]; aux.pintor [200%] | 105.6h | 757.28 | 7. Casa 7 | 1. Pav. Superior | 9. Fachada 1 | Própria |  |  |  |
| 431 | 1.6.7.2.11 | 10. Cer. Piso | 4d | 2024-11-27 | 2024-12-02 | 411 | 0d |  | servente [200%]; pedreiro [400%] | 211.2h | 19,807.17 | 7. Casa 7 | 1. Pav. Superior | 10. Cer. Piso 1 | Própria | 10 | 10 | 10 |
| 432 | 1.6.7.2.12 | 11. Cer. Parede | 2d | 2025-01-31 | 2025-02-03 | 412 | 0d |  | pedreiro [400%]; servente [200%] | 105.6h | 4,238.82 | 7. Casa 7 | 1. Pav. Superior | 11. Cer. Parede 1 | Própria | 11 | 11 | 11 |
| 433 | 1.6.7.2.13 | 12. Forro (WC's e cozinha) | 1d | 2025-02-06 | 2025-02-07 | 460SF | 0d |  | aux. gesseiro; gesseiro | 17.6h | 895 | 7. Casa 7 | 1. Pav. Superior | 12. Forro (WC's e cozinha) 1 | Própria | 12 | 12 | 12 |
| 434 | 1.6.7.2.14 | 13. Esq. Alumínio | 2d | 2025-02-27 | 2025-02-28 | 414 | 164d | 0d | montador esquadrias | 17.6h | 8,489.61 | 7. Casa 7 | 1. Pav. Superior | 13. Esq. Alumínio 1 | Própria | 13 | 13 | 13 |
| 435 | 1.6.7.2.15 | 14. Portas | 2d | 2025-03-06 | 2025-03-07 | 415 | 0d |  | marceneiro [200%] | 35.2h | 1,858.35 | 7. Casa 7 | 1. Pav. Superior | 14. Portas 1 | Própria | 14 | 14 | 14 |
| 436 | 1.6.7.2.16 | 15. Pintura (1ª Demão) | 4d | 2025-06-03 | 2025-06-06 | 416 | 0d |  | pintor [600%]; aux.pintor [300%] | 316.8h | 3,764.82 | 7. Casa 7 | 1. Pav. Superior | 15. Pintura (1ª Demão) 1 | Própria | 15 | 15 | 15 |
| 437 | 1.6.7.2.17 | 16. Bancadas | 1d | 2025-06-17 | 2025-06-18 | 464SF | 80d | 0d | servente; pedreiro [200%] | 26.4h | 6,972.08 | 7. Casa 7 | 1. Pav. Superior | 16. Bancadas 1 | Própria | 16 | 16 | 16 |
| 438 | 1.6.7.2.18 | 17. Pintura (2ª Demão) | 3d | 2025-08-15 | 2025-08-19 | 418 | 0d |  | aux.pintor [300%]; pintor [600%] | 237.6h | 1,563.98 | 7. Casa 7 | 1. Pav. Superior | 17. Pintura (2ª Demão) 1 | Própria | 17 | 17 | 17 |
| 439 | 1.6.7.2.19 | 18. Limp. Interna | 1d | 2025-08-27 | 2025-08-28 | 466SF | 82d | 0d | Diarista [200%] | 17.6h | 418.75 | 7. Casa 7 | 1. Pav. Superior | 18. Limp. Interna 1 | Própria | 18 | 18 | 18 |
| 440 | 1.6.7.3 | **2. Coberta** | 85d | 2024-04-04 | 2024-08-06 |  | 0d |  |  | 536.8h | 58,163.18 |  |  |  |  |  |  |  |
| 441 | 1.6.7.3.1 | 1. Alvenarias | 3d | 2024-04-04 | 2024-04-08 | 422 | 0d |  | pedreiro [400%]; servente [400%] | 211.2h | 9,834.12 | 7. Casa 7 | 2. Coberta | 3. Alvenarias 1 | Própria |  |  |  |
| 442 | 1.6.7.3.2 | 2. Impermeabilização | 1d | 2024-08-05 | 2024-08-06 | 452SF | 346d | 0d | aplicador de manta | 8.8h | 24,164.53 | 7. Casa 7 | 2. Coberta | 7. Impermeabilização 1 | Própria |  |  |  |
| 443 | 1.6.7.3.3 | 3. Coberta | 6d | 2024-04-18 | 2024-04-26 | 490SF | 415d | 0d | carpinteiro [400%]; aux. Carpinteiro [200%] | 316.8h | 24,164.53 | 7. Casa 7 | 2. Coberta | 4. Coberta 1 | Própria |  |  |  |

| ID | WBS | Task | Duration | Start | Finish | Predecessors | Total slack | Free slack | Resources | Work | Cost | Casa | Pav | Equipe | Empresa | Pacote | Cor | LB |
| --- | --- | --- | --- | --- | --- | --- | --- | --- | --- | --- | --- | --- | --- | --- | --- | --- | --- | --- |
| 444 | 1.6.8 | **8. Casa 8** | 478d | 2023-09-19 | 2025-08-29 |  | 1d |  |  | 7568h | 338,552.33 |  |  |  |  |  |  |  |
| 445 | 1.6.8.1 | **0. Térreo** | 477d | 2023-09-19 | 2025-08-28 |  | 1d |  |  | 3801.6h | 165,509.25 |  |  |  |  |  |  |  |
| 446 | 1.6.8.1.1 | 0. Locação | 2d | 2023-09-19 | 2023-09-20 | 399 | 1d | 0d | carpinteiro; aux. Carpinteiro | 35.2h | 456.99 | 8. Casa 8 | 0. Térreo | 0. Locação 1 | Própria |  |  |  |
| 447 | 1.6.8.1.2 | 1. Fundação | 9d | 2024-01-03 | 2024-01-15 | 400 | 482d | 0d | servente estrutura [300%]; aux. Carpinteiro; aux. ferreiro; ferreiro; carpinteiro [200%] | 633.6h | 19,882.86 | 8. Casa 8 | 0. Térreo | 1. Fundação 1 | Própria |  |  |  |
| 448 | 1.6.8.1.3 | 2. Estrutura | 7d | 2024-03-08 | 2024-03-18 | 421 | 433d | 0d | servente estrutura [300%]; aux. Carpinteiro [200%]; aux. ferreiro [200%]; ferreiro [500%]; carpinteiro [200%] | 862.4h | 46,439.03 | 8. Casa 8 | 0. Térreo | 2. Estrutura 1 | Própria |  |  |  |
| 449 | 1.6.8.1.4 | 3. Alvenarias | 5d | 2024-04-09 | 2024-04-15 | 441 | 0d |  | pedreiro [400%]; servente [400%] | 352h | 8,388.41 | 8. Casa 8 | 0. Térreo | 3. Alvenarias 1 | Própria |  |  |  |
| 450 | 1.6.8.1.5 | 5. Ref. Inter. Arg (Parede) | 3d | 2024-07-25 | 2024-07-29 | 423 | 0d |  | pedreiro [600%]; servente [600%] | 316.8h | 5,776 | 8. Casa 8 | 0. Térreo | 5. Ref. Inter. Arg (Parede) 1 | Própria |  |  |  |
| 451 | 1.6.8.1.6 | 6. Revest. Gesso (Parede + Teto) | 3d | 2024-08-09 | 2024-08-13 | 471 | 340d | 0d | gesseiro [400%]; aux. gesseiro [200%] | 158.4h | 2,119.41 | 8. Casa 8 | 0. Térreo | 6. Revest. Gesso (Parede + Teto) 1 | Própria |  |  |  |
| 452 | 1.6.8.1.7 | 7. Impermeabilização | 2d | 2024-08-06 | 2024-08-08 | 472SF | 344d | 0d | aplicador de manta | 17.6h | 3,288.15 | 8. Casa 8 | 0. Térreo | 7. Impermeabilização 1 | Própria |  |  |  |
| 453 | 1.6.8.1.8 | 8. Contrapiso | 2d | 2024-08-16 | 2024-08-20 | 520SF | 0d |  | pedreiro [200%]; servente | 52.8h | 3,735.07 | 8. Casa 8 | 0. Térreo | 8. Contrapiso 1 | Própria |  |  |  |
| 454 | 1.6.8.1.9 | 9.1. Chapisco | 0.5d | 2024-10-10 | 2024-10-10 | 427 | 148.5d | 0d | pedreiro [600%]; servente [400%] | 44h | 5,131.51 | 8. Casa 8 | 0. Térreo | 9. Fachada 1 | Própria |  |  |  |
| 455 | 1.6.8.1.10 | 9.2. Emboço | 1.5d | 2024-11-25 | 2024-11-26 | 475 | 148.5d | 0d | pedreiro [600%]; servente [400%] | 132h | 7,697.26 | 8. Casa 8 | 0. Térreo | 9. Fachada 1 | Própria |  |  |  |
| 456 | 1.6.8.1.11 | 9.3. Pint. 1 Demão | 1d | 2025-01-21 | 2025-01-22 | 476 | 148.5d | 0d | pintor [400%]; aux.pintor [200%] | 52.8h | 1,135.92 | 8. Casa 8 | 0. Térreo | 9. Fachada 1 | Própria |  |  |  |
| 457 | 1.6.8.1.12 | 9.4. Pint. 2 Demão | 2d | 2025-04-02 | 2025-04-04 | 477 | 148.5d | 0d | pintor [400%]; aux.pintor [200%] | 105.6h | 757.28 | 8. Casa 8 | 0. Térreo | 9. Fachada 1 | Própria |  |  |  |
| 458 | 1.6.8.1.13 | 10. Cer. Piso | 4d | 2024-12-03 | 2024-12-06 | 431 | 0d |  | pedreiro [400%]; servente [200%] | 211.2h | 25,485.98 | 8. Casa 8 | 0. Térreo | 10. Cer. Piso 1 | Própria | 10 | 10 | 10 |
| 459 | 1.6.8.1.14 | 11. Cer. Parede | 3d | 2025-02-04 | 2025-02-06 | 432 | 0d |  | pedreiro [400%]; servente [200%] | 158.4h | 4,238.82 | 8. Casa 8 | 0. Térreo | 11. Cer. Parede 1 | Própria | 11 | 11 | 11 |
| 460 | 1.6.8.1.15 | 12. Forro (WC's e cozinha) | 1d | 2025-02-07 | 2025-02-10 | 480SF | 0d |  | gesseiro; aux. gesseiro | 17.6h | 635.82 | 8. Casa 8 | 0. Térreo | 12. Forro (WC's e cozinha) 1 | Própria | 12 | 12 | 12 |
| 461 | 1.6.8.1.16 | 13. Esq. Alumínio | 2d | 2025-03-06 | 2025-03-07 | 434 | 164d | 0d | montador esquadrias | 17.6h | 11,307.22 | 8. Casa 8 | 0. Térreo | 13. Esq. Alumínio 1 | Própria | 13 | 13 | 13 |
| 462 | 1.6.8.1.17 | 14. Portas | 2d | 2025-03-10 | 2025-03-11 | 435 | 0d |  | marceneiro [200%] | 35.2h | 2,827.85 | 8. Casa 8 | 0. Térreo | 14. Portas 1 | Própria | 14 | 14 | 14 |
| 463 | 1.6.8.1.18 | 15. Pintura (1ª Demão) | 4d | 2025-06-09 | 2025-06-12 | 436 | 0d |  | pintor [600%]; aux.pintor [300%] | 316.8h | 3,764.82 | 8. Casa 8 | 0. Térreo | 15. Pintura (1ª Demão) 1 | Própria | 15 | 15 | 15 |
| 464 | 1.6.8.1.19 | 16. Bancadas | 1d | 2025-06-18 | 2025-06-23 | 484SF | 80d | 0d | pedreiro [200%]; servente | 26.4h | 10,458.12 | 8. Casa 8 | 0. Térreo | 16. Bancadas 1 | Própria | 16 | 16 | 16 |
| 465 | 1.6.8.1.20 | 17. Pintura (2ª Demão) | 3d | 2025-08-20 | 2025-08-22 | 438 | 0d |  | pintor [600%]; aux.pintor [300%] | 237.6h | 1,563.98 | 8. Casa 8 | 0. Térreo | 17. Pintura (2ª Demão) 1 | Própria | 17 | 17 | 17 |
| 466 | 1.6.8.1.21 | 18. Limp. Interna | 1d | 2025-08-28 | 2025-08-28 | 485 | 0d |  | Diarista [200%] | 17.6h | 418.75 | 8. Casa 8 | 0. Térreo | 18. Limp. Interna 1 | Própria | 18 | 18 | 18 |
| 467 | 1.6.8.2 | **1. Pav. Superior** | 360d | 2024-03-20 | 2025-08-29 |  | 17d |  |  | 3229.6h | 114,879.9 |  |  |  |  |  |  |  |
| 468 | 1.6.8.2.1 | 2. Estrutura | 7d | 2024-03-20 | 2024-04-01 | 448 | 433d | 0d | servente estrutura [300%]; aux. Carpinteiro [200%]; aux. ferreiro [200%]; ferreiro [500%]; carpinteiro [200%] | 862.4h | 30,006.55 | 8. Casa 8 | 1. Pav. Superior | 2. Estrutura 1 | Própria |  |  |  |
| 469 | 1.6.8.2.2 | 3. Alvenarias | 5d | 2024-04-16 | 2024-04-22 | 449 | 0d |  | servente [400%]; pedreiro [400%] | 352h | 10,101.74 | 8. Casa 8 | 1. Pav. Superior | 3. Alvenarias 1 | Própria |  |  |  |
| 470 | 1.6.8.2.3 | 5. Ref. Inter. Arg (Parede) | 4d | 2024-07-30 | 2024-08-02 | 450 | 0d |  | pedreiro [600%]; servente [600%] | 422.4h | 5,398.69 | 8. Casa 8 | 1. Pav. Superior | 5. Ref. Inter. Arg (Parede) 1 | Própria |  |  |  |
| 471 | 1.6.8.2.4 | 6. Revest. Gesso (Parede + Teto) | 4d | 2024-08-05 | 2024-08-08 | 470 | 0d |  | aux. gesseiro [200%]; gesseiro [400%] | 211.2h | 2,119.41 | 8. Casa 8 | 1. Pav. Superior | 6. Revest. Gesso (Parede + Teto) 1 | Própria |  |  |  |
| 472 | 1.6.8.2.5 | 7. Impermeabilização | 1d | 2024-08-08 | 2024-08-09 | 489SF | 343d | 0d | aplicador de manta | 8.8h | 2,046.85 | 8. Casa 8 | 1. Pav. Superior | 7. Impermeabilização 1 | Própria |  |  |  |
| 473 | 1.6.8.2.6 | 8. Contrapiso | 2d | 2024-08-14 | 2024-08-16 | 453SF | 0d |  | pedreiro [200%]; servente | 52.8h | 2,476.11 | 8. Casa 8 | 1. Pav. Superior | 8. Contrapiso 1 | Própria |  |  |  |
| 474 | 1.6.8.2.7 | 9.1. Chapisco | 0.5d | 2024-10-10 | 2024-10-10 | 454 | 148.5d | 0d | pedreiro [600%]; servente [400%] | 44h | 5,131.51 | 8. Casa 8 | 1. Pav. Superior | 9. Fachada 1 | Própria |  |  |  |
| 475 | 1.6.8.2.8 | 9.2. Emboço | 1.5d | 2024-11-22 | 2024-11-25 | 408 | 148.5d | 0d | pedreiro [600%]; servente [400%] | 132h | 7,697.26 | 8. Casa 8 | 1. Pav. Superior | 9. Fachada 1 | Própria |  |  |  |
| 476 | 1.6.8.2.9 | 9.3. Pint. 1 Demão | 1d | 2025-01-20 | 2025-01-21 | 409 | 148.5d | 0d | pintor [400%]; aux.pintor [200%] | 52.8h | 1,135.92 | 8. Casa 8 | 1. Pav. Superior | 9. Fachada 1 | Própria |  |  |  |
| 477 | 1.6.8.2.10 | 9.4. Pint. 2 Demão | 2d | 2025-03-31 | 2025-04-02 | 410 | 148.5d | 0d | pintor [400%]; aux.pintor [200%] | 105.6h | 757.28 | 8. Casa 8 | 1. Pav. Superior | 9. Fachada 1 | Própria |  |  |  |
| 478 | 1.6.8.2.11 | 10. Cer. Piso | 4d | 2024-12-09 | 2024-12-12 | 458 | 0d |  | pedreiro [400%]; servente [200%] | 211.2h | 19,807.17 | 8. Casa 8 | 1. Pav. Superior | 10. Cer. Piso 1 | Própria | 10 | 10 | 10 |
| 479 | 1.6.8.2.12 | 11. Cer. Parede | 2d | 2025-02-07 | 2025-02-10 | 459 | 0d |  | pedreiro [400%]; servente [200%] | 105.6h | 4,238.82 | 8. Casa 8 | 1. Pav. Superior | 11. Cer. Parede 1 | Própria | 11 | 11 | 11 |
| 480 | 1.6.8.2.13 | 12. Forro (WC's e cozinha) | 1d | 2025-02-10 | 2025-02-11 | 507SF | 0d |  | gesseiro; aux. gesseiro | 17.6h | 895 | 8. Casa 8 | 1. Pav. Superior | 12. Forro (WC's e cozinha) 1 | Própria | 12 | 12 | 12 |
| 481 | 1.6.8.2.14 | 13. Esq. Alumínio | 2d | 2025-03-10 | 2025-03-11 | 461 | 164d | 0d | montador esquadrias | 17.6h | 8,489.61 | 8. Casa 8 | 1. Pav. Superior | 13. Esq. Alumínio 1 | Própria | 13 | 13 | 13 |
| 482 | 1.6.8.2.15 | 14. Portas | 2d | 2025-03-12 | 2025-03-13 | 462 | 0d |  | marceneiro [200%] | 35.2h | 1,858.35 | 8. Casa 8 | 1. Pav. Superior | 14. Portas 1 | Própria | 14 | 14 | 14 |
| 483 | 1.6.8.2.16 | 15. Pintura (1ª Demão) | 4d | 2025-06-13 | 2025-06-18 | 463 | 0d |  | pintor [600%]; aux.pintor [300%] | 316.8h | 3,764.82 | 8. Casa 8 | 1. Pav. Superior | 15. Pintura (1ª Demão) 1 | Própria | 15 | 15 | 15 |
| 484 | 1.6.8.2.17 | 16. Bancadas | 1d | 2025-06-23 | 2025-06-23 | 483 | 80d | 0d | servente; pedreiro [200%] | 26.4h | 6,972.08 | 8. Casa 8 | 1. Pav. Superior | 16. Bancadas 1 | Própria | 16 | 16 | 16 |
| 485 | 1.6.8.2.18 | 17. Pintura (2ª Demão) | 3d | 2025-08-25 | 2025-08-27 | 465 | 0d |  | aux.pintor [300%]; pintor [600%] | 237.6h | 1,563.98 | 8. Casa 8 | 1. Pav. Superior | 17. Pintura (2ª Demão) 1 | Própria | 17 | 17 | 17 |
| 486 | 1.6.8.2.19 | 18. Limp. Interna | 1d | 2025-08-29 | 2025-08-29 | 466 | 0d |  | Diarista [200%] | 17.6h | 418.75 | 8. Casa 8 | 1. Pav. Superior | 18. Limp. Interna 1 | Própria | 18 | 18 | 18 |

| ID | WBS | Task | Duration | Start | Finish | Predecessors | Total slack | Free slack | Resources | Work | Cost | Casa | Pav | Equipe | Empresa | Pacote | Cor | LB |
| --- | --- | --- | --- | --- | --- | --- | --- | --- | --- | --- | --- | --- | --- | --- | --- | --- | --- | --- |
| 487 | 1.6.8.3 | **2. Coberta** | 76d | 2024-04-23 | 2024-08-09 |  | 0d |  |  | 536.8h | 58,163.18 |  |  |  |  |  |  |  |
| 488 | 1.6.8.3.1 | 1. Alvenarias | 3d | 2024-04-23 | 2024-04-25 | 469 | 0d |  | pedreiro [400%]; servente [400%] | 211.2h | 9,834.12 | 8. Casa 8 | 2. Coberta | 3. Alvenarias 1 | Própria |  |  |  |
| 489 | 1.6.8.3.2 | 2. Impermeabilização | 1d | 2024-08-09 | 2024-08-09 | 471 | 0d |  | aplicador de manta | 8.8h | 24,164.53 | 8. Casa 8 | 2. Coberta | 7. Impermeabilização 1 | Própria |  |  |  |
| 490 | 1.6.8.3.3 | 3. Coberta | 6d | 2024-04-26 | 2024-05-06 | 488 | 0d |  | carpinteiro [400%]; aux. Carpinteiro [200%] | 316.8h | 24,164.53 | 8. Casa 8 | 2. Coberta | 4. Coberta 1 | Própria |  |  |  |
| 491 | 1.6.9 | **9. Casa 9** | 478d | 2023-09-21 | 2025-09-02 |  | 1d |  |  | 7568h | 338,293.15 |  |  |  |  |  |  |  |
| 492 | 1.6.9.1 | **0. Térreo** | 477d | 2023-09-21 | 2025-09-01 |  | 1d |  |  | 3801.6h | 165,509.25 |  |  |  |  |  |  |  |
| 493 | 1.6.9.1.1 | 0. Locação | 2d | 2023-09-21 | 2023-09-22 | 446 | 1d | 0d | carpinteiro; aux. Carpinteiro | 35.2h | 456.99 | 9. Casa 9 | 0. Térreo | 0. Locação 1 | Própria |  |  |  |
| 494 | 1.6.9.1.2 | 1. Fundação | 9d | 2023-09-25 | 2023-10-05 | 493 | 394d | 0d | servente estrutura [300%]; aux. Carpinteiro; aux. ferreiro; ferreiro; carpinteiro [200%] | 633.6h | 19,882.86 | 9. Casa 9 | 0. Térreo | 1. Fundação 1 | Própria |  |  |  |
| 495 | 1.6.9.1.3 | 2. Estrutura | 7d | 2023-11-03 | 2023-11-13 | 494FS+28ed | 396d | 0d | servente estrutura [300%]; aux. Carpinteiro [200%]; aux. ferreiro [200%]; ferreiro [500%]; carpinteiro [200%] | 862.4h | 46,439.03 | 9. Casa 9 | 0. Térreo | 2. Estrutura 1 | Própria |  |  |  |
| 496 | 1.6.9.1.4 | 3. Alvenarias | 5d | 2023-12-12 | 2023-12-18 | 495FS+28ed | 397d | 0d | pedreiro [400%]; servente [400%] | 352h | 8,388.41 | 9. Casa 9 | 0. Térreo | 3. Alvenarias 1 | Própria |  |  |  |
| 497 | 1.6.9.1.5 | 5. Ref. Inter. Arg (Parede) | 3d | 2024-05-15 | 2024-05-17 | 537 | 340d | 0d | pedreiro [600%]; servente [600%] | 316.8h | 5,776 | 9. Casa 9 | 0. Térreo | 5. Ref. Inter. Arg (Parede) 1 | Própria |  |  |  |
| 498 | 1.6.9.1.6 | 6. Revest. Gesso (Parede + Teto) | 3d | 2024-05-24 | 2024-05-29 | 518SF | 393d |  | gesseiro [400%]; aux. gesseiro [200%] | 158.4h | 2,119.41 | 9. Casa 9 | 0. Térreo | 6. Revest. Gesso (Parede + Teto) 1 | Própria |  |  |  |
| 499 | 1.6.9.1.7 | 7. Impermeabilização | 2d | 2024-08-12 | 2024-08-13 | 489 | 0d |  | aplicador de manta | 17.6h | 3,288.15 | 9. Casa 9 | 0. Térreo | 7. Impermeabilização 1 | Própria |  |  |  |
| 500 | 1.6.9.1.8 | 8. Contrapiso | 2d | 2024-08-22 | 2024-08-26 | 567SF | 0d |  | pedreiro [200%]; servente | 52.8h | 3,735.07 | 9. Casa 9 | 0. Térreo | 8. Contrapiso 1 | Própria |  |  |  |
| 501 | 1.6.9.1.9 | 9.1. Chapisco | 0.5d | 2024-10-11 | 2024-10-11 | 474 | 148.5d | 0d | pedreiro [600%]; servente [400%] | 44h | 5,131.51 | 9. Casa 9 | 0. Térreo | 9. Fachada 1 | Própria |  |  |  |
| 502 | 1.6.9.1.10 | 9.2. Emboço | 1.5d | 2024-11-28 | 2024-11-29 | 522 | 148.5d | 0d | pedreiro [600%]; servente [400%] | 132h | 7,697.26 | 9. Casa 9 | 0. Térreo | 9. Fachada 1 | Própria |  |  |  |
| 503 | 1.6.9.1.11 | 9.3. Pint. 1 Demão | 1d | 2025-01-23 | 2025-01-24 | 523 | 148.5d | 0d | pintor [400%]; aux.pintor [200%] | 52.8h | 1,135.92 | 9. Casa 9 | 0. Térreo | 9. Fachada 1 | Própria |  |  |  |
| 504 | 1.6.9.1.12 | 9.4. Pint. 2 Demão | 2d | 2025-04-08 | 2025-04-10 | 524 | 148.5d | 0d | pintor [400%]; aux.pintor [200%] | 105.6h | 757.28 | 9. Casa 9 | 0. Térreo | 9. Fachada 1 | Própria |  |  |  |
| 505 | 1.6.9.1.13 | 10. Cer. Piso | 4d | 2024-09-13 | 2024-09-18 | 473FS+28ed | 214d | 0d | pedreiro [400%]; servente [200%] | 211.2h | 25,485.98 | 9. Casa 9 | 0. Térreo | 10. Cer. Piso 1 | Própria | 10 | 10 | 10 |
| 506 | 1.6.9.1.14 | 11. Cer. Parede | 3d | 2024-12-13 | 2024-12-17 | 854 | 214d | 0d | pedreiro [400%]; servente [200%] | 158.4h | 4,238.82 | 9. Casa 9 | 0. Térreo | 11. Cer. Parede 1 | Própria | 11 | 11 | 11 |
| 507 | 1.6.9.1.15 | 12. Forro (WC's e cozinha) | 1d | 2025-02-11 | 2025-02-11 | 479 | 0d |  | gesseiro; aux. gesseiro | 17.6h | 635.82 | 9. Casa 9 | 0. Térreo | 12. Forro (WC's e cozinha) 1 | Própria | 12 | 12 | 12 |
| 508 | 1.6.9.1.16 | 13. Esq. Alumínio | 2d | 2025-03-12 | 2025-03-13 | 481 | 164d | 0d | montador esquadrias | 17.6h | 11,307.22 | 9. Casa 9 | 0. Térreo | 13. Esq. Alumínio 1 | Própria | 13 | 13 | 13 |
| 509 | 1.6.9.1.17 | 14. Portas | 2d | 2025-03-14 | 2025-03-17 | 482 | 162d | 0d | marceneiro [200%] | 35.2h | 2,827.85 | 9. Casa 9 | 0. Térreo | 14. Portas 1 | Própria | 14 | 14 | 14 |
| 510 | 1.6.9.1.18 | 15. Pintura (1ª Demão) | 4d | 2025-03-14 | 2025-03-20 | 482 | 82d | 0d | pintor [600%]; aux.pintor [300%] | 316.8h | 3,764.82 | 9. Casa 9 | 0. Térreo | 15. Pintura (1ª Demão) 1 | Própria | 15 | 15 | 15 |
| 511 | 1.6.9.1.19 | 16. Bancadas | 1d | 2025-06-24 | 2025-06-24 | 484 | 113d | 0d | pedreiro [200%]; servente | 26.4h | 10,458.12 | 9. Casa 9 | 0. Térreo | 16. Bancadas 1 | Própria | 16 | 16 | 16 |
| 512 | 1.6.9.1.20 | 17. Pintura (2ª Demão) | 3d | 2025-06-23 | 2025-06-25 | 859 | 82d | 0d | aux.pintor [300%]; pintor [600%] | 237.6h | 1,563.98 | 9. Casa 9 | 0. Térreo | 17. Pintura (2ª Demão) 1 | Própria | 17 | 17 | 17 |
| 513 | 1.6.9.1.21 | 18. Limp. Interna | 1d | 2025-09-01 | 2025-09-01 | 486 | 0d |  | Diarista [200%] | 17.6h | 418.75 | 9. Casa 9 | 0. Térreo | 18. Limp. Interna 1 | Própria | 18 | 18 | 18 |

| ID | WBS | Task | Duration | Start | Finish | Predecessors | Total slack | Free slack | Resources | Work | Cost | Casa | Pav | Equipe | Empresa | Pacote | Cor | LB |
| --- | --- | --- | --- | --- | --- | --- | --- | --- | --- | --- | --- | --- | --- | --- | --- | --- | --- | --- |
| 514 | 1.6.9.2 | **1. Pav. Superior** | 442d | 2023-11-14 | 2025-09-02 |  | 78d |  |  | 3229.6h | 114,620.72 |  |  |  |  |  |  |  |
| 515 | 1.6.9.2.1 | 2. Estrutura | 7d | 2023-11-14 | 2023-11-23 | 495 | 415d | 0d | servente estrutura [300%]; aux. Carpinteiro [200%]; aux. ferreiro [200%]; ferreiro [500%]; carpinteiro [200%] | 862.4h | 30,006.55 | 9. Casa 9 | 1. Pav. Superior | 2. Estrutura 1 | Própria |  |  |  |
| 516 | 1.6.9.2.2 | 3. Alvenarias | 5d | 2023-12-19 | 2024-01-02 | 496 | 397d | 0d | servente [400%]; pedreiro [400%] | 352h | 10,101.74 | 9. Casa 9 | 1. Pav. Superior | 3. Alvenarias 1 | Própria |  |  |  |
| 517 | 1.6.9.2.3 | 5. Ref. Inter. Arg (Parede) | 4d | 2024-05-20 | 2024-05-23 | 497 | 340d | 0d | pedreiro [600%]; servente [600%] | 422.4h | 5,398.69 | 9. Casa 9 | 1. Pav. Superior | 5. Ref. Inter. Arg (Parede) 1 | Própria |  |  |  |
| 518 | 1.6.9.2.4 | 6. Revest. Gesso (Parede + Teto) | 4d | 2024-05-29 | 2024-06-06 | 545SF | 389d | 0d | aux. gesseiro [200%]; gesseiro [400%] | 211.2h | 2,119.41 | 9. Casa 9 | 1. Pav. Superior | 6. Revest. Gesso (Parede + Teto) 1 | Própria |  |  |  |
| 519 | 1.6.9.2.5 | 7. Impermeabilização | 1d | 2024-08-14 | 2024-08-14 | 499 | 0d |  | aplicador de manta | 8.8h | 2,046.85 | 9. Casa 9 | 1. Pav. Superior | 7. Impermeabilização 1 | Própria |  |  |  |
| 520 | 1.6.9.2.6 | 8. Contrapiso | 2d | 2024-08-20 | 2024-08-22 | 500SF | 0d |  | pedreiro [200%]; servente | 52.8h | 2,476.11 | 9. Casa 9 | 1. Pav. Superior | 8. Contrapiso 1 | Própria |  |  |  |
| 521 | 1.6.9.2.7 | 9.1. Chapisco | 0.5d | 2024-10-11 | 2024-10-11 | 501 | 148.5d | 0d | pedreiro [600%]; servente [400%] | 44h | 5,131.51 | 9. Casa 9 | 1. Pav. Superior | 9. Fachada 1 | Própria |  |  |  |
| 522 | 1.6.9.2.8 | 9.2. Emboço | 1.5d | 2024-11-27 | 2024-11-28 | 455 | 148.5d | 0d | pedreiro [600%]; servente [400%] | 132h | 7,697.26 | 9. Casa 9 | 1. Pav. Superior | 9. Fachada 1 | Própria |  |  |  |
| 523 | 1.6.9.2.9 | 9.3. Pint. 1 Demão | 1d | 2025-01-22 | 2025-01-23 | 456 | 148.5d | 0d | pintor [400%]; aux.pintor [200%] | 52.8h | 1,135.92 | 9. Casa 9 | 1. Pav. Superior | 9. Fachada 1 | Própria |  |  |  |
| 524 | 1.6.9.2.10 | 9.4. Pint. 2 Demão | 2d | 2025-04-04 | 2025-04-08 | 457 | 148.5d | 0d | pintor [400%]; aux.pintor [200%] | 105.6h | 757.28 | 9. Casa 9 | 1. Pav. Superior | 9. Fachada 1 | Própria |  |  |  |
| 525 | 1.6.9.2.11 | 10. Cer. Piso | 4d | 2024-09-19 | 2024-09-24 | 505 | 214d | 0d | servente [200%]; pedreiro [400%] | 211.2h | 19,807.17 | 9. Casa 9 | 1. Pav. Superior | 10. Cer. Piso 1 | Própria | 10 | 10 | 10 |
| 526 | 1.6.9.2.12 | 11. Cer. Parede | 2d | 2024-12-18 | 2024-12-19 | 506 | 214d | 0d | pedreiro [400%]; servente [200%] | 105.6h | 4,238.82 | 9. Casa 9 | 1. Pav. Superior | 11. Cer. Parede 1 | Própria | 11 | 11 | 11 |
| 527 | 1.6.9.2.13 | 12. Forro (WC's e cozinha) | 1d | 2025-02-12 | 2025-02-12 | 507 | 198d | 0d | aux. gesseiro; gesseiro | 17.6h | 635.82 | 9. Casa 9 | 1. Pav. Superior | 12. Forro (WC's e cozinha) 1 | Própria | 12 | 12 | 12 |
| 528 | 1.6.9.2.14 | 13. Esq. Alumínio | 2d | 2025-03-14 | 2025-03-17 | 508 | 164d | 0d | montador esquadrias | 17.6h | 8,489.61 | 9. Casa 9 | 1. Pav. Superior | 13. Esq. Alumínio 1 | Própria | 13 | 13 | 13 |
| 529 | 1.6.9.2.15 | 14. Portas | 2d | 2025-03-18 | 2025-03-20 | 509 | 162d | 0d | marceneiro [200%] | 35.2h | 1,858.35 | 9. Casa 9 | 1. Pav. Superior | 14. Portas 1 | Própria | 14 | 14 | 14 |
| 530 | 1.6.9.2.16 | 15. Pintura (1ª Demão) | 4d | 2025-03-21 | 2025-03-27 | 510 | 82d | 0d | pintor [600%]; aux.pintor [300%] | 316.8h | 3,764.82 | 9. Casa 9 | 1. Pav. Superior | 15. Pintura (1ª Demão) 1 | Própria | 15 | 15 | 15 |
| 531 | 1.6.9.2.17 | 16. Bancadas | 1d | 2025-06-25 | 2025-06-25 | 511 | 113d | 0d | servente; pedreiro [200%] | 26.4h | 6,972.08 | 9. Casa 9 | 1. Pav. Superior | 16. Bancadas 1 | Própria | 16 | 16 | 16 |
| 532 | 1.6.9.2.18 | 17. Pintura (2ª Demão) | 3d | 2025-06-26 | 2025-06-30 | 512 | 82d | 0d | aux.pintor [300%]; pintor [600%] | 237.6h | 1,563.98 | 9. Casa 9 | 1. Pav. Superior | 17. Pintura (2ª Demão) 1 | Própria | 17 | 17 | 17 |
| 533 | 1.6.9.2.19 | 18. Limp. Interna | 1d | 2025-09-02 | 2025-09-02 | 513 | 0d |  | Diarista [200%] | 17.6h | 418.75 | 9. Casa 9 | 1. Pav. Superior | 18. Limp. Interna 1 | Própria | 18 | 18 | 18 |
| 534 | 1.6.9.3 | **2. Coberta** | 153d | 2024-01-03 | 2024-08-15 |  | 82d |  |  | 536.8h | 58,163.18 |  |  |  |  |  |  |  |
| 535 | 1.6.9.3.1 | 1. Alvenarias | 3d | 2024-01-03 | 2024-01-05 | 516 | 397d | 0d | pedreiro [400%]; servente [400%] | 211.2h | 9,834.12 | 9. Casa 9 | 2. Coberta | 3. Alvenarias 1 | Própria |  |  |  |
| 536 | 1.6.9.3.2 | 2. Impermeabilização | 1d | 2024-08-15 | 2024-08-15 | 519 | 0d |  | aplicador de manta | 8.8h | 24,164.53 | 9. Casa 9 | 2. Coberta | 7. Impermeabilização 1 | Própria |  |  |  |
| 537 | 1.6.9.3.3 | 3. Coberta | 6d | 2024-05-07 | 2024-05-14 | 490 | 0d |  | carpinteiro [400%]; aux. Carpinteiro [200%] | 316.8h | 24,164.53 | 9. Casa 9 | 2. Coberta | 4. Coberta 1 | Própria |  |  |  |

| ID | WBS | Task | Duration | Start | Finish | Predecessors | Total slack | Free slack | Resources | Work | Cost | Casa | Pav | Equipe | Empresa | Pacote | Cor | LB |
| --- | --- | --- | --- | --- | --- | --- | --- | --- | --- | --- | --- | --- | --- | --- | --- | --- | --- | --- |
| 538 | 1.6.10 | **10. Casa 10** | 478d | 2023-09-25 | 2025-09-04 |  | 76d |  |  | 7594.4h | 338,552.33 |  |  |  |  |  |  |  |
| 539 | 1.6.10.1 | **0. Térreo** | 477d | 2023-09-25 | 2025-09-03 |  | 77d |  |  | 3801.6h | 165,768.43 |  |  |  |  |  |  |  |
| 540 | 1.6.10.1.1 | 0. Locação | 2d | 2023-09-25 | 2023-09-26 | 493 | 540d | 0d | carpinteiro; aux. Carpinteiro | 35.2h | 456.99 | 10. Casa 10 | 0. Térreo | 0. Locação 1 | Própria |  |  |  |
| 541 | 1.6.10.1.2 | 1. Fundação | 9d | 2023-10-06 | 2023-10-19 | 494 | 482d | 0d | servente estrutura [300%]; aux. Carpinteiro; aux. ferreiro; ferreiro; carpinteiro [200%] | 633.6h | 19,882.86 | 10. Casa 10 | 0. Térreo | 1. Fundação 1 | Própria |  |  |  |
| 542 | 1.6.10.1.3 | 2. Estrutura | 7d | 2023-11-24 | 2023-12-04 | 515 | 415d | 0d | servente estrutura [300%]; aux. Carpinteiro [200%]; aux. ferreiro [200%]; ferreiro [500%]; carpinteiro [200%] | 862.4h | 46,439.03 | 10. Casa 10 | 0. Térreo | 2. Estrutura 1 | Própria |  |  |  |
| 543 | 1.6.10.1.4 | 3. Alvenarias | 5d | 2024-01-08 | 2024-01-12 | 535 | 397d | 0d | pedreiro [400%]; servente [400%] | 352h | 8,388.41 | 10. Casa 10 | 0. Térreo | 3. Alvenarias 1 | Própria |  |  |  |
| 544 | 1.6.10.1.5 | 5. Ref. Inter. Arg (Parede) | 3d | 2024-05-24 | 2024-05-28 | 517 | 340d | 0d | pedreiro [600%]; servente [600%] | 316.8h | 5,776 | 10. Casa 10 | 0. Térreo | 5. Ref. Inter. Arg (Parede) 1 | Própria |  |  |  |
| 545 | 1.6.10.1.6 | 6. Revest. Gesso (Parede + Teto) | 3d | 2024-06-06 | 2024-06-11 | 565SF | 386d | 0d | gesseiro [400%]; aux. gesseiro [200%] | 158.4h | 2,119.41 | 10. Casa 10 | 0. Térreo | 6. Revest. Gesso (Parede + Teto) 1 | Própria |  |  |  |
| 546 | 1.6.10.1.7 | 7. Impermeabilização | 2d | 2024-08-16 | 2024-08-19 | 536 | 0d |  | aplicador de manta | 17.6h | 3,288.15 | 10. Casa 10 | 0. Térreo | 7. Impermeabilização 1 | Própria |  |  |  |
| 547 | 1.6.10.1.8 | 8. Contrapiso | 2d | 2024-08-28 | 2024-08-30 | 614SF | 0d |  | pedreiro [200%]; servente | 52.8h | 3,735.07 | 10. Casa 10 | 0. Térreo | 8. Contrapiso 1 | Própria |  |  |  |
| 548 | 1.6.10.1.9 | 9.1. Chapisco | 0.5d | 2024-10-14 | 2024-10-14 | 521 | 148.5d | 0d | pedreiro [600%]; servente [400%] | 44h | 5,131.51 | 10. Casa 10 | 0. Térreo | 9. Fachada 1 | Própria |  |  |  |
| 549 | 1.6.10.1.10 | 9.2. Emboço | 1.5d | 2024-12-03 | 2024-12-04 | 569 | 148.5d | 0d | pedreiro [600%]; servente [400%] | 132h | 7,697.26 | 10. Casa 10 | 0. Térreo | 9. Fachada 1 | Própria |  |  |  |
| 550 | 1.6.10.1.11 | 9.3. Pint. 1 Demão | 1d | 2025-01-27 | 2025-01-28 | 570 | 148.5d | 0d | pintor [400%]; aux.pintor [200%] | 52.8h | 1,135.92 | 10. Casa 10 | 0. Térreo | 9. Fachada 1 | Própria |  |  |  |
| 551 | 1.6.10.1.12 | 9.4. Pint. 2 Demão | 2d | 2025-04-14 | 2025-04-16 | 571 | 148.5d | 0d | pintor [400%]; aux.pintor [200%] | 105.6h | 757.28 | 10. Casa 10 | 0. Térreo | 9. Fachada 1 | Própria |  |  |  |
| 552 | 1.6.10.1.13 | 10. Cer. Piso | 4d | 2024-09-25 | 2024-09-30 | 525 | 214d | 0d | pedreiro [400%]; servente [200%] | 211.2h | 25,485.98 | 10. Casa 10 | 0. Térreo | 10. Cer. Piso 1 | Própria | 10 | 10 | 10 |
| 553 | 1.6.10.1.14 | 11. Cer. Parede | 3d | 2024-12-20 | 2024-12-24 | 526 | 214d | 0d | pedreiro [400%]; servente [200%] | 158.4h | 4,238.82 | 10. Casa 10 | 0. Térreo | 11. Cer. Parede 1 | Própria | 11 | 11 | 11 |
| 554 | 1.6.10.1.15 | 12. Forro (WC's e cozinha) | 1d | 2025-02-13 | 2025-02-13 | 527 | 198d | 0d | gesseiro; aux. gesseiro | 17.6h | 895 | 10. Casa 10 | 0. Térreo | 12. Forro (WC's e cozinha) 1 | Própria | 12 | 12 | 12 |
| 555 | 1.6.10.1.16 | 13. Esq. Alumínio | 2d | 2025-03-18 | 2025-03-20 | 528 | 164d | 0d | montador esquadrias | 17.6h | 11,307.22 | 10. Casa 10 | 0. Térreo | 13. Esq. Alumínio 1 | Própria | 13 | 13 | 13 |
| 556 | 1.6.10.1.17 | 14. Portas | 2d | 2025-03-21 | 2025-03-24 | 529 | 162d | 0d | marceneiro [200%] | 35.2h | 2,827.85 | 10. Casa 10 | 0. Térreo | 14. Portas 1 | Própria | 14 | 14 | 14 |
| 557 | 1.6.10.1.18 | 15. Pintura (1ª Demão) | 4d | 2025-03-28 | 2025-04-02 | 530 | 82d | 0d | pintor [600%]; aux.pintor [300%] | 316.8h | 3,764.82 | 10. Casa 10 | 0. Térreo | 15. Pintura (1ª Demão) 1 | Própria | 15 | 15 | 15 |
| 558 | 1.6.10.1.19 | 16. Bancadas | 1d | 2025-06-26 | 2025-06-26 | 531 | 113d | 0d | pedreiro [200%]; servente | 26.4h | 10,458.12 | 10. Casa 10 | 0. Térreo | 16. Bancadas 1 | Própria | 16 | 16 | 16 |
| 559 | 1.6.10.1.20 | 17. Pintura (2ª Demão) | 3d | 2025-07-01 | 2025-07-03 | 532 | 82d | 0d | aux.pintor [300%]; pintor [600%] | 237.6h | 1,563.98 | 10. Casa 10 | 0. Térreo | 17. Pintura (2ª Demão) 1 | Própria | 17 | 17 | 17 |
| 560 | 1.6.10.1.21 | 18. Limp. Interna | 1d | 2025-09-03 | 2025-09-03 | 533 | 0d |  | Diarista [200%] | 17.6h | 418.75 | 10. Casa 10 | 0. Térreo | 18. Limp. Interna 1 | Própria | 18 | 18 | 18 |
| 561 | 1.6.10.2 | **1. Pav. Superior** | 430d | 2023-12-05 | 2025-09-04 |  | 76d |  |  | 3256h | 114,620.72 |  |  |  |  |  |  |  |
| 562 | 1.6.10.2.1 | 2. Estrutura | 7d | 2023-12-05 | 2023-12-13 | 542 | 415d | 0d | servente estrutura [300%]; aux. Carpinteiro [200%]; aux. ferreiro [200%]; ferreiro [500%]; carpinteiro [200%] | 862.4h | 30,006.55 | 10. Casa 10 | 1. Pav. Superior | 2. Estrutura 1 | Própria |  |  |  |
| 563 | 1.6.10.2.2 | 3. Alvenarias | 5d | 2024-01-15 | 2024-01-19 | 543 | 397d | 0d | servente [400%]; pedreiro [400%] | 352h | 10,101.74 | 10. Casa 10 | 1. Pav. Superior | 3. Alvenarias 1 | Própria |  |  |  |
| 564 | 1.6.10.2.3 | 5. Ref. Inter. Arg (Parede) | 4d | 2024-05-29 | 2024-06-05 | 544 | 340d | 0d | pedreiro [600%]; servente [600%] | 422.4h | 5,398.69 | 10. Casa 10 | 1. Pav. Superior | 5. Ref. Inter. Arg (Parede) 1 | Própria |  |  |  |
| 565 | 1.6.10.2.4 | 6. Revest. Gesso (Parede + Teto) | 4d | 2024-06-11 | 2024-06-17 | 592SF | 382d | 0d | aux. gesseiro [200%]; gesseiro [400%] | 211.2h | 2,119.41 | 10. Casa 10 | 1. Pav. Superior | 6. Revest. Gesso (Parede + Teto) 1 | Própria |  |  |  |
| 566 | 1.6.10.2.5 | 7. Impermeabilização | 1d | 2024-08-20 | 2024-08-20 | 546 | 0d |  | gesseiro [300%]; servente | 35.2h | 2,046.85 | 10. Casa 10 | 1. Pav. Superior | 7. Impermeabilização 1 | Própria |  |  |  |
| 567 | 1.6.10.2.6 | 8. Contrapiso | 2d | 2024-08-26 | 2024-08-28 | 547SF | 0d |  | pedreiro [200%]; servente | 52.8h | 2,476.11 | 10. Casa 10 | 1. Pav. Superior | 8. Contrapiso 1 | Própria |  |  |  |
| 568 | 1.6.10.2.7 | 9.1. Chapisco | 0.5d | 2024-10-14 | 2024-10-14 | 548 | 148.5d | 0d | pedreiro [600%]; servente [400%] | 44h | 5,131.51 | 10. Casa 10 | 1. Pav. Superior | 9. Fachada 1 | Própria |  |  |  |
| 569 | 1.6.10.2.8 | 9.2. Emboço | 1.5d | 2024-12-02 | 2024-12-03 | 502 | 148.5d | 0d | pedreiro [600%]; servente [400%] | 132h | 7,697.26 | 10. Casa 10 | 1. Pav. Superior | 9. Fachada 1 | Própria |  |  |  |
| 570 | 1.6.10.2.9 | 9.3. Pint. 1 Demão | 1d | 2025-01-24 | 2025-01-27 | 503 | 148.5d | 0d | pintor [400%]; aux.pintor [200%] | 52.8h | 1,135.92 | 10. Casa 10 | 1. Pav. Superior | 9. Fachada 1 | Própria |  |  |  |
| 571 | 1.6.10.2.10 | 9.4. Pint. 2 Demão | 2d | 2025-04-10 | 2025-04-14 | 504 | 148.5d | 0d | pintor [400%]; aux.pintor [200%] | 105.6h | 757.28 | 10. Casa 10 | 1. Pav. Superior | 9. Fachada 1 | Própria |  |  |  |
| 572 | 1.6.10.2.11 | 10. Cer. Piso | 4d | 2024-10-01 | 2024-10-04 | 552 | 214d | 0d | pedreiro [400%]; servente [200%] | 211.2h | 19,807.17 | 10. Casa 10 | 1. Pav. Superior | 10. Cer. Piso 1 | Própria | 10 | 10 | 10 |
| 573 | 1.6.10.2.12 | 11. Cer. Parede | 2d | 2024-12-26 | 2024-12-27 | 553 | 214d | 0d | pedreiro [400%]; servente [200%] | 105.6h | 4,238.82 | 10. Casa 10 | 1. Pav. Superior | 11. Cer. Parede 1 | Própria | 11 | 11 | 11 |
| 574 | 1.6.10.2.13 | 12. Forro (WC's e cozinha) | 1d | 2025-02-14 | 2025-02-14 | 554 | 198d | 0d | gesseiro; aux. gesseiro | 17.6h | 635.82 | 10. Casa 10 | 1. Pav. Superior | 12. Forro (WC's e cozinha) 1 | Própria | 12 | 12 | 12 |
| 575 | 1.6.10.2.14 | 13. Esq. Alumínio | 2d | 2025-03-21 | 2025-03-24 | 555 | 164d | 0d | montador esquadrias | 17.6h | 8,489.61 | 10. Casa 10 | 1. Pav. Superior | 13. Esq. Alumínio 1 | Própria | 13 | 13 | 13 |
| 576 | 1.6.10.2.15 | 14. Portas | 2d | 2025-03-26 | 2025-03-27 | 556 | 162d | 0d | marceneiro [200%] | 35.2h | 1,858.35 | 10. Casa 10 | 1. Pav. Superior | 14. Portas 1 | Própria | 14 | 14 | 14 |
| 577 | 1.6.10.2.16 | 15. Pintura (1ª Demão) | 4d | 2025-04-03 | 2025-04-08 | 557 | 82d | 0d | pintor [600%]; aux.pintor [300%] | 316.8h | 3,764.82 | 10. Casa 10 | 1. Pav. Superior | 15. Pintura (1ª Demão) 1 | Própria | 15 | 15 | 15 |
| 578 | 1.6.10.2.17 | 16. Bancadas | 1d | 2025-06-27 | 2025-06-27 | 558 | 113d | 0d | servente; pedreiro [200%] | 26.4h | 6,972.08 | 10. Casa 10 | 1. Pav. Superior | 16. Bancadas 1 | Própria | 16 | 16 | 16 |
| 579 | 1.6.10.2.18 | 17. Pintura (2ª Demão) | 3d | 2025-07-04 | 2025-07-08 | 559 | 82d | 0d | aux.pintor [300%]; pintor [600%] | 237.6h | 1,563.98 | 10. Casa 10 | 1. Pav. Superior | 17. Pintura (2ª Demão) 1 | Própria | 17 | 17 | 17 |
| 580 | 1.6.10.2.19 | 18. Limp. Interna | 1d | 2025-09-04 | 2025-09-04 | 560 | 0d |  | Diarista [200%] | 17.6h | 418.75 | 10. Casa 10 | 1. Pav. Superior | 18. Limp. Interna 1 | Própria | 18 | 18 | 18 |

| ID | WBS | Task | Duration | Start | Finish | Predecessors | Total slack | Free slack | Resources | Work | Cost | Casa | Pav | Equipe | Empresa | Pacote | Cor | LB |
| --- | --- | --- | --- | --- | --- | --- | --- | --- | --- | --- | --- | --- | --- | --- | --- | --- | --- | --- |
| 581 | 1.6.10.3 | **2. Coberta** | 144d | 2024-01-22 | 2024-08-21 |  | 143d |  |  | 536.8h | 58,163.18 |  |  |  |  |  |  |  |
| 582 | 1.6.10.3.1 | 1. Alvenarias | 3d | 2024-01-22 | 2024-01-24 | 563 | 397d | 0d | pedreiro [400%]; servente [400%] | 211.2h | 9,834.12 | 10. Casa 10 | 2. Coberta | 3. Alvenarias 1 | Própria |  |  |  |
| 583 | 1.6.10.3.2 | 2. Impermeabilização | 1d | 2024-08-21 | 2024-08-21 | 566 | 0d |  | aplicador de manta | 8.8h | 24,164.53 | 10. Casa 10 | 2. Coberta | 7. Impermeabilização 1 | Própria |  |  |  |
| 584 | 1.6.10.3.3 | 3. Coberta | 6d | 2024-05-15 | 2024-05-22 | 537 | 361d | 0d | carpinteiro [400%]; aux. Carpinteiro [200%] | 316.8h | 24,164.53 | 10. Casa 10 | 2. Coberta | 4. Coberta 1 | Própria |  |  |  |
| 585 | 1.6.11 | **11. Casa 11** | 478d | 2023-09-27 | 2025-09-08 |  | 74d |  |  | 7594.4h | 338,552.33 |  |  |  |  |  |  |  |
| 586 | 1.6.11.1 | **0. Térreo** | 477d | 2023-09-27 | 2025-09-05 |  | 75d |  |  | 3801.6h | 165,768.43 |  |  |  |  |  |  |  |
| 587 | 1.6.11.1.1 | 0. Locação | 2d | 2023-09-27 | 2023-09-28 | 540 | 540d | 0d | carpinteiro; aux. Carpinteiro | 35.2h | 456.99 | 11. Casa 11 | 0. Térreo | 0. Locação 1 | Própria |  |  |  |
| 588 | 1.6.11.1.2 | 1. Fundação | 9d | 2023-10-20 | 2023-11-01 | 541 | 482d | 0d | servente estrutura [300%]; aux. Carpinteiro; aux. ferreiro; ferreiro; carpinteiro [200%] | 633.6h | 19,882.86 | 11. Casa 11 | 0. Térreo | 1. Fundação 1 | Própria |  |  |  |
| 589 | 1.6.11.1.3 | 2. Estrutura | 7d | 2023-12-14 | 2023-12-22 | 562 | 415d | 0d | servente estrutura [300%]; aux. Carpinteiro [200%]; aux. ferreiro [200%]; ferreiro [500%]; carpinteiro [200%] | 862.4h | 46,439.03 | 11. Casa 11 | 0. Térreo | 2. Estrutura 1 | Própria |  |  |  |
| 590 | 1.6.11.1.4 | 3. Alvenarias | 5d | 2024-01-25 | 2024-01-31 | 582 | 397d | 0d | pedreiro [400%]; servente [400%] | 352h | 8,388.41 | 11. Casa 11 | 0. Térreo | 3. Alvenarias 1 | Própria |  |  |  |
| 591 | 1.6.11.1.5 | 5. Ref. Inter. Arg (Parede) | 3d | 2024-06-06 | 2024-06-10 | 564 | 340d | 0d | pedreiro [600%]; servente [600%] | 316.8h | 5,776 | 11. Casa 11 | 0. Térreo | 5. Ref. Inter. Arg (Parede) 1 | Própria |  |  |  |
| 592 | 1.6.11.1.6 | 6. Revest. Gesso (Parede + Teto) | 3d | 2024-06-17 | 2024-06-20 | 612SF | 379d | 0d | gesseiro [400%]; aux. gesseiro [200%] | 158.4h | 2,119.41 | 11. Casa 11 | 0. Térreo | 6. Revest. Gesso (Parede + Teto) 1 | Própria |  |  |  |
| 593 | 1.6.11.1.7 | 7. Impermeabilização | 2d | 2024-08-22 | 2024-08-23 | 583 | 0d |  | aplicador de manta | 17.6h | 3,288.15 | 11. Casa 11 | 0. Térreo | 7. Impermeabilização 1 | Própria |  |  |  |
| 594 | 1.6.11.1.8 | 8. Contrapiso | 2d | 2024-09-03 | 2024-09-05 | 661SF | 0d |  | pedreiro [200%]; servente | 52.8h | 3,735.07 | 11. Casa 11 | 0. Térreo | 8. Contrapiso 1 | Própria |  |  |  |
| 595 | 1.6.11.1.9 | 9.1. Chapisco | 0.5d | 2024-10-15 | 2024-10-15 | 568 | 148.5d | 0d | pedreiro [600%]; servente [400%] | 44h | 5,131.51 | 11. Casa 11 | 0. Térreo | 9. Fachada 1 | Própria |  |  |  |
| 596 | 1.6.11.1.10 | 9.2. Emboço | 1.5d | 2024-12-06 | 2024-12-09 | 616 | 148.5d | 0d | pedreiro [600%]; servente [400%] | 132h | 7,697.26 | 11. Casa 11 | 0. Térreo | 9. Fachada 1 | Própria |  |  |  |
| 597 | 1.6.11.1.11 | 9.3. Pint. 1 Demão | 1d | 2025-01-29 | 2025-01-30 | 617 | 148.5d | 0d | pintor [400%]; aux.pintor [200%] | 52.8h | 1,135.92 | 11. Casa 11 | 0. Térreo | 9. Fachada 1 | Própria |  |  |  |
| 598 | 1.6.11.1.12 | 9.4. Pint. 2 Demão | 2d | 2025-04-22 | 2025-04-24 | 618 | 148.5d | 0d | pintor [400%]; aux.pintor [200%] | 105.6h | 757.28 | 11. Casa 11 | 0. Térreo | 9. Fachada 1 | Própria |  |  |  |
| 599 | 1.6.11.1.13 | 10. Cer. Piso | 4d | 2024-10-07 | 2024-10-10 | 572 | 214d | 0d | pedreiro [400%]; servente [200%] | 211.2h | 25,485.98 | 11. Casa 11 | 0. Térreo | 10. Cer. Piso 1 | Própria | 10 | 10 | 10 |
| 600 | 1.6.11.1.14 | 11. Cer. Parede | 3d | 2024-12-30 | 2025-01-02 | 573 | 214d | 0d | pedreiro [400%]; servente [200%] | 158.4h | 4,238.82 | 11. Casa 11 | 0. Térreo | 11. Cer. Parede 1 | Própria | 11 | 11 | 11 |
| 601 | 1.6.11.1.15 | 12. Forro (WC's e cozinha) | 1d | 2025-02-17 | 2025-02-17 | 574 | 198d | 0d | gesseiro; aux. gesseiro | 17.6h | 895 | 11. Casa 11 | 0. Térreo | 12. Forro (WC's e cozinha) 1 | Própria | 12 | 12 | 12 |
| 602 | 1.6.11.1.16 | 13. Esq. Alumínio | 2d | 2025-03-26 | 2025-03-27 | 575 | 164d | 0d | montador esquadrias | 17.6h | 11,307.22 | 11. Casa 11 | 0. Térreo | 13. Esq. Alumínio 1 | Própria | 13 | 13 | 13 |
| 603 | 1.6.11.1.17 | 14. Portas | 2d | 2025-03-28 | 2025-03-31 | 576 | 162d | 0d | marceneiro [200%] | 35.2h | 2,827.85 | 11. Casa 11 | 0. Térreo | 14. Portas 1 | Própria | 14 | 14 | 14 |
| 604 | 1.6.11.1.18 | 15. Pintura (1ª Demão) | 4d | 2025-04-09 | 2025-04-14 | 577 | 82d | 0d | pintor [600%]; aux.pintor [300%] | 316.8h | 3,764.82 | 11. Casa 11 | 0. Térreo | 15. Pintura (1ª Demão) 1 | Própria | 15 | 15 | 15 |
| 605 | 1.6.11.1.19 | 16. Bancadas | 1d | 2025-06-30 | 2025-06-30 | 578 | 113d | 0d | pedreiro [200%]; servente | 26.4h | 10,458.12 | 11. Casa 11 | 0. Térreo | 16. Bancadas 1 | Própria | 16 | 16 | 16 |
| 606 | 1.6.11.1.20 | 17. Pintura (2ª Demão) | 3d | 2025-07-09 | 2025-07-11 | 579 | 82d | 0d | aux.pintor [300%]; pintor [600%] | 237.6h | 1,563.98 | 11. Casa 11 | 0. Térreo | 17. Pintura (2ª Demão) 1 | Própria | 17 | 17 | 17 |
| 607 | 1.6.11.1.21 | 18. Limp. Interna | 1d | 2025-09-05 | 2025-09-05 | 580 | 0d |  | Diarista [200%] | 17.6h | 418.75 | 11. Casa 11 | 0. Térreo | 18. Limp. Interna 1 | Própria | 18 | 18 | 18 |

| ID | WBS | Task | Duration | Start | Finish | Predecessors | Total slack | Free slack | Resources | Work | Cost | Casa | Pav | Equipe | Empresa | Pacote | Cor | LB |
| --- | --- | --- | --- | --- | --- | --- | --- | --- | --- | --- | --- | --- | --- | --- | --- | --- | --- | --- |
| 608 | 1.6.11.2 | **1. Pav. Superior** | 418d | 2024-01-02 | 2025-09-08 |  | 74d |  |  | 3256h | 114,620.72 |  |  |  |  |  |  |  |
| 609 | 1.6.11.2.1 | 2. Estrutura | 7d | 2024-01-02 | 2024-01-10 | 589 | 415d | 0d | servente estrutura [300%]; aux. Carpinteiro [200%]; aux. ferreiro [200%]; ferreiro [500%]; carpinteiro [200%] | 862.4h | 30,006.55 | 11. Casa 11 | 1. Pav. Superior | 2. Estrutura 1 | Própria |  |  |  |
| 610 | 1.6.11.2.2 | 3. Alvenarias | 5d | 2024-02-01 | 2024-02-07 | 590 | 397d | 0d | servente [400%]; pedreiro [400%] | 352h | 10,101.74 | 11. Casa 11 | 1. Pav. Superior | 3. Alvenarias 1 | Própria |  |  |  |
| 611 | 1.6.11.2.3 | 5. Ref. Inter. Arg (Parede) | 4d | 2024-06-11 | 2024-06-14 | 591 | 340d | 0d | pedreiro [600%]; servente [600%] | 422.4h | 5,398.69 | 11. Casa 11 | 1. Pav. Superior | 5. Ref. Inter. Arg (Parede) 1 | Própria |  |  |  |
| 612 | 1.6.11.2.4 | 6. Revest. Gesso (Parede + Teto) | 4d | 2024-06-20 | 2024-06-26 | 639SF | 375d | 0d | aux. gesseiro [200%]; gesseiro [400%] | 211.2h | 2,119.41 | 11. Casa 11 | 1. Pav. Superior | 6. Revest. Gesso (Parede + Teto) 1 | Própria |  |  |  |
| 613 | 1.6.11.2.5 | 7. Impermeabilização | 1d | 2024-08-26 | 2024-08-26 | 593 | 0d |  | gesseiro [300%]; servente | 35.2h | 2,046.85 | 11. Casa 11 | 1. Pav. Superior | 7. Impermeabilização 1 | Própria |  |  |  |
| 614 | 1.6.11.2.6 | 8. Contrapiso | 2d | 2024-08-30 | 2024-09-03 | 594SF | 0d |  | pedreiro [200%]; servente | 52.8h | 2,476.11 | 11. Casa 11 | 1. Pav. Superior | 8. Contrapiso 1 | Própria |  |  |  |
| 615 | 1.6.11.2.7 | 9.1. Chapisco | 0.5d | 2024-10-15 | 2024-10-15 | 595 | 148.5d | 0d | pedreiro [600%]; servente [400%] | 44h | 5,131.51 | 11. Casa 11 | 1. Pav. Superior | 9. Fachada 1 | Própria |  |  |  |
| 616 | 1.6.11.2.8 | 9.2. Emboço | 1.5d | 2024-12-05 | 2024-12-06 | 549 | 148.5d | 0d | pedreiro [600%]; servente [400%] | 132h | 7,697.26 | 11. Casa 11 | 1. Pav. Superior | 9. Fachada 1 | Própria |  |  |  |
| 617 | 1.6.11.2.9 | 9.3. Pint. 1 Demão | 1d | 2025-01-28 | 2025-01-29 | 550 | 148.5d | 0d | pintor [400%]; aux.pintor [200%] | 52.8h | 1,135.92 | 11. Casa 11 | 1. Pav. Superior | 9. Fachada 1 | Própria |  |  |  |
| 618 | 1.6.11.2.10 | 9.4. Pint. 2 Demão | 2d | 2025-04-16 | 2025-04-22 | 551 | 148.5d | 0d | pintor [400%]; aux.pintor [200%] | 105.6h | 757.28 | 11. Casa 11 | 1. Pav. Superior | 9. Fachada 1 | Própria |  |  |  |
| 619 | 1.6.11.2.11 | 10. Cer. Piso | 4d | 2024-10-11 | 2024-10-16 | 599 | 214d | 0d | servente [200%]; pedreiro [400%] | 211.2h | 19,807.17 | 11. Casa 11 | 1. Pav. Superior | 10. Cer. Piso 1 | Própria | 10 | 10 | 10 |
| 620 | 1.6.11.2.12 | 11. Cer. Parede | 2d | 2025-01-03 | 2025-01-06 | 600 | 214d | 0d | pedreiro [400%]; servente [200%] | 105.6h | 4,238.82 | 11. Casa 11 | 1. Pav. Superior | 11. Cer. Parede 1 | Própria | 11 | 11 | 11 |
| 621 | 1.6.11.2.13 | 12. Forro (WC's e cozinha) | 1d | 2025-02-18 | 2025-02-18 | 601 | 198d | 0d | aux. gesseiro; gesseiro | 17.6h | 635.82 | 11. Casa 11 | 1. Pav. Superior | 12. Forro (WC's e cozinha) 1 | Própria | 12 | 12 | 12 |
| 622 | 1.6.11.2.14 | 13. Esq. Alumínio | 2d | 2025-03-28 | 2025-03-31 | 602 | 164d | 0d | montador esquadrias | 17.6h | 8,489.61 | 11. Casa 11 | 1. Pav. Superior | 13. Esq. Alumínio 1 | Própria | 13 | 13 | 13 |
| 623 | 1.6.11.2.15 | 14. Portas | 2d | 2025-04-01 | 2025-04-02 | 603 | 162d | 0d | marceneiro [200%] | 35.2h | 1,858.35 | 11. Casa 11 | 1. Pav. Superior | 14. Portas 1 | Própria | 14 | 14 | 14 |
| 624 | 1.6.11.2.16 | 15. Pintura (1ª Demão) | 4d | 2025-04-15 | 2025-04-22 | 604 | 82d | 0d | pintor [600%]; aux.pintor [300%] | 316.8h | 3,764.82 | 11. Casa 11 | 1. Pav. Superior | 15. Pintura (1ª Demão) 1 | Própria | 15 | 15 | 15 |
| 625 | 1.6.11.2.17 | 16. Bancadas | 1d | 2025-07-01 | 2025-07-01 | 605 | 113d | 0d | servente; pedreiro [200%] | 26.4h | 6,972.08 | 11. Casa 11 | 1. Pav. Superior | 16. Bancadas 1 | Própria | 16 | 16 | 16 |
| 626 | 1.6.11.2.18 | 17. Pintura (2ª Demão) | 3d | 2025-07-14 | 2025-07-16 | 606 | 82d | 0d | aux.pintor [300%]; pintor [600%] | 237.6h | 1,563.98 | 11. Casa 11 | 1. Pav. Superior | 17. Pintura (2ª Demão) 1 | Própria | 17 | 17 | 17 |
| 627 | 1.6.11.2.19 | 18. Limp. Interna | 1d | 2025-09-08 | 2025-09-08 | 607 | 0d |  | Diarista [200%] | 17.6h | 418.75 | 11. Casa 11 | 1. Pav. Superior | 18. Limp. Interna 1 | Própria | 18 | 18 | 18 |
| 628 | 1.6.11.3 | **2. Coberta** | 135d | 2024-02-08 | 2024-08-27 |  | 134d |  |  | 536.8h | 58,163.18 |  |  |  |  |  |  |  |
| 629 | 1.6.11.3.1 | 1. Alvenarias | 3d | 2024-02-08 | 2024-02-15 | 610 | 397d | 0d | pedreiro [400%]; servente [400%] | 211.2h | 9,834.12 | 11. Casa 11 | 2. Coberta | 3. Alvenarias 1 | Própria |  |  |  |
| 630 | 1.6.11.3.2 | 2. Impermeabilização | 1d | 2024-08-27 | 2024-08-27 | 613 | 0d |  | aplicador de manta | 8.8h | 24,164.53 | 11. Casa 11 | 2. Coberta | 7. Impermeabilização 1 | Própria |  |  |  |
| 631 | 1.6.11.3.3 | 3. Coberta | 6d | 2024-05-23 | 2024-06-03 | 584 | 361d | 0d | carpinteiro [400%]; aux. Carpinteiro [200%] | 316.8h | 24,164.53 | 11. Casa 11 | 2. Coberta | 4. Coberta 1 | Própria |  |  |  |

| ID | WBS | Task | Duration | Start | Finish | Predecessors | Total slack | Free slack | Resources | Work | Cost | Casa | Pav | Equipe | Empresa | Pacote | Cor | LB |
| --- | --- | --- | --- | --- | --- | --- | --- | --- | --- | --- | --- | --- | --- | --- | --- | --- | --- | --- |
| 632 | 1.6.12 | **12. Casa 12** | 478d | 2023-09-29 | 2025-09-10 |  | 72d |  |  | 7594.4h | 338,552.33 |  |  |  |  |  |  |  |
| 633 | 1.6.12.1 | **0. Térreo** | 477d | 2023-09-29 | 2025-09-09 |  | 73d |  |  | 3801.6h | 165,768.43 |  |  |  |  |  |  |  |
| 634 | 1.6.12.1.1 | 0. Locação | 2d | 2023-09-29 | 2023-10-02 | 587 | 540d | 0d | carpinteiro; aux. Carpinteiro | 35.2h | 456.99 | 12. Casa 12 | 0. Térreo | 0. Locação 1 | Própria |  |  |  |
| 635 | 1.6.12.1.2 | 1. Fundação | 9d | 2023-11-03 | 2023-11-16 | 588 | 482d | 0d | servente estrutura [300%]; aux. Carpinteiro; aux. ferreiro; ferreiro; carpinteiro [200%] | 633.6h | 19,882.86 | 12. Casa 12 | 0. Térreo | 1. Fundação 1 | Própria |  |  |  |
| 636 | 1.6.12.1.3 | 2. Estrutura | 7d | 2024-01-11 | 2024-01-19 | 609 | 415d | 0d | servente estrutura [300%]; aux. Carpinteiro [200%]; aux. ferreiro [200%]; ferreiro [500%]; carpinteiro [200%] | 862.4h | 46,439.03 | 12. Casa 12 | 0. Térreo | 2. Estrutura 1 | Própria |  |  |  |
| 637 | 1.6.12.1.4 | 3. Alvenarias | 5d | 2024-02-16 | 2024-02-22 | 629 | 397d | 0d | pedreiro [400%]; servente [400%] | 352h | 8,388.41 | 12. Casa 12 | 0. Térreo | 3. Alvenarias 1 | Própria |  |  |  |
| 638 | 1.6.12.1.5 | 5. Ref. Inter. Arg (Parede) | 3d | 2024-06-17 | 2024-06-19 | 611 | 340d | 0d | pedreiro [600%]; servente [600%] | 316.8h | 5,776 | 12. Casa 12 | 0. Térreo | 5. Ref. Inter. Arg (Parede) 1 | Própria |  |  |  |
| 639 | 1.6.12.1.6 | 6. Revest. Gesso (Parede + Teto) | 3d | 2024-06-26 | 2024-07-01 | 659SF | 372d | 0d | gesseiro [400%]; aux. gesseiro [200%] | 158.4h | 2,119.41 | 12. Casa 12 | 0. Térreo | 6. Revest. Gesso (Parede + Teto) 1 | Própria |  |  |  |
| 640 | 1.6.12.1.7 | 7. Impermeabilização | 2d | 2024-08-28 | 2024-08-29 | 630 | 0d |  | aplicador de manta | 17.6h | 3,288.15 | 12. Casa 12 | 0. Térreo | 7. Impermeabilização 1 | Própria |  |  |  |
| 641 | 1.6.12.1.8 | 8. Contrapiso | 2d | 2024-09-09 | 2024-09-11 | 708SF | 0d |  | pedreiro [200%]; servente | 52.8h | 3,735.07 | 12. Casa 12 | 0. Térreo | 8. Contrapiso 1 | Própria |  |  |  |
| 642 | 1.6.12.1.9 | 9.1. Chapisco | 0.5d | 2024-10-16 | 2024-10-16 | 615 | 148.5d | 0d | pedreiro [600%]; servente [400%] | 44h | 5,131.51 | 12. Casa 12 | 0. Térreo | 9. Fachada 1 | Própria |  |  |  |
| 643 | 1.6.12.1.10 | 9.2. Emboço | 1.5d | 2024-12-11 | 2024-12-12 | 663 | 148.5d | 0d | pedreiro [600%]; servente [400%] | 132h | 7,697.26 | 12. Casa 12 | 0. Térreo | 9. Fachada 1 | Própria |  |  |  |
| 644 | 1.6.12.1.11 | 9.3. Pint. 1 Demão | 1d | 2025-01-31 | 2025-02-03 | 664 | 148.5d | 0d | pintor [400%]; aux.pintor [200%] | 52.8h | 1,135.92 | 12. Casa 12 | 0. Térreo | 9. Fachada 1 | Própria |  |  |  |
| 645 | 1.6.12.1.12 | 9.4. Pint. 2 Demão | 2d | 2025-04-28 | 2025-04-30 | 665 | 148.5d | 0d | pintor [400%]; aux.pintor [200%] | 105.6h | 757.28 | 12. Casa 12 | 0. Térreo | 9. Fachada 1 | Própria |  |  |  |
| 646 | 1.6.12.1.13 | 10. Cer. Piso | 4d | 2024-10-17 | 2024-10-22 | 619 | 214d | 0d | pedreiro [400%]; servente [200%] | 211.2h | 25,485.98 | 12. Casa 12 | 0. Térreo | 10. Cer. Piso 1 | Própria | 10 | 10 | 10 |
| 647 | 1.6.12.1.14 | 11. Cer. Parede | 3d | 2025-01-07 | 2025-01-09 | 620 | 214d | 0d | pedreiro [400%]; servente [200%] | 158.4h | 4,238.82 | 12. Casa 12 | 0. Térreo | 11. Cer. Parede 1 | Própria | 11 | 11 | 11 |
| 648 | 1.6.12.1.15 | 12. Forro (WC's e cozinha) | 1d | 2025-02-19 | 2025-02-19 | 621 | 198d | 0d | gesseiro; aux. gesseiro | 17.6h | 895 | 12. Casa 12 | 0. Térreo | 12. Forro (WC's e cozinha) 1 | Própria | 12 | 12 | 12 |
| 649 | 1.6.12.1.16 | 13. Esq. Alumínio | 2d | 2025-04-01 | 2025-04-02 | 622 | 164d | 0d | montador esquadrias | 17.6h | 11,307.22 | 12. Casa 12 | 0. Térreo | 13. Esq. Alumínio 1 | Própria | 13 | 13 | 13 |
| 650 | 1.6.12.1.17 | 14. Portas | 2d | 2025-04-03 | 2025-04-04 | 623 | 162d | 0d | marceneiro [200%] | 35.2h | 2,827.85 | 12. Casa 12 | 0. Térreo | 14. Portas 1 | Própria | 14 | 14 | 14 |
| 651 | 1.6.12.1.18 | 15. Pintura (1ª Demão) | 4d | 2025-04-23 | 2025-04-28 | 624 | 82d | 0d | pintor [600%]; aux.pintor [300%] | 316.8h | 3,764.82 | 12. Casa 12 | 0. Térreo | 15. Pintura (1ª Demão) 1 | Própria | 15 | 15 | 15 |
| 652 | 1.6.12.1.19 | 16. Bancadas | 1d | 2025-07-02 | 2025-07-02 | 625 | 113d | 0d | pedreiro [200%]; servente | 26.4h | 10,458.12 | 12. Casa 12 | 0. Térreo | 16. Bancadas 1 | Própria | 16 | 16 | 16 |
| 653 | 1.6.12.1.20 | 17. Pintura (2ª Demão) | 3d | 2025-07-17 | 2025-07-21 | 626 | 82d | 0d | aux.pintor [300%]; pintor [600%] | 237.6h | 1,563.98 | 12. Casa 12 | 0. Térreo | 17. Pintura (2ª Demão) 1 | Própria | 17 | 17 | 17 |
| 654 | 1.6.12.1.21 | 18. Limp. Interna | 1d | 2025-09-09 | 2025-09-09 | 627 | 0d |  | Diarista [200%] | 17.6h | 418.75 | 12. Casa 12 | 0. Térreo | 18. Limp. Interna 1 | Própria | 18 | 18 | 18 |
| 655 | 1.6.12.2 | **1. Pav. Superior** | 406d | 2024-01-22 | 2025-09-10 |  | 72d |  |  | 3256h | 114,620.72 |  |  |  |  |  |  |  |
| 656 | 1.6.12.2.1 | 2. Estrutura | 7d | 2024-01-22 | 2024-01-30 | 636 | 415d | 0d | servente estrutura [300%]; aux. Carpinteiro [200%]; aux. ferreiro [200%]; ferreiro [500%]; carpinteiro [200%] | 862.4h | 30,006.55 | 12. Casa 12 | 1. Pav. Superior | 2. Estrutura 1 | Própria |  |  |  |
| 657 | 1.6.12.2.2 | 3. Alvenarias | 5d | 2024-02-23 | 2024-02-29 | 637 | 397d | 0d | servente [400%]; pedreiro [400%] | 352h | 10,101.74 | 12. Casa 12 | 1. Pav. Superior | 3. Alvenarias 1 | Própria |  |  |  |
| 658 | 1.6.12.2.3 | 5. Ref. Inter. Arg (Parede) | 4d | 2024-06-20 | 2024-06-25 | 638 | 340d | 0d | pedreiro [600%]; servente [600%] | 422.4h | 5,398.69 | 12. Casa 12 | 1. Pav. Superior | 5. Ref. Inter. Arg (Parede) 1 | Própria |  |  |  |
| 659 | 1.6.12.2.4 | 6. Revest. Gesso (Parede + Teto) | 4d | 2024-07-01 | 2024-07-05 | 686SF | 368d | 0d | aux. gesseiro [200%]; gesseiro [400%] | 211.2h | 2,119.41 | 12. Casa 12 | 1. Pav. Superior | 6. Revest. Gesso (Parede + Teto) 1 | Própria |  |  |  |
| 660 | 1.6.12.2.5 | 7. Impermeabilização | 1d | 2024-08-30 | 2024-08-30 | 640 | 0d |  | gesseiro [300%]; servente | 35.2h | 2,046.85 | 12. Casa 12 | 1. Pav. Superior | 7. Impermeabilização 1 | Própria |  |  |  |
| 661 | 1.6.12.2.6 | 8. Contrapiso | 2d | 2024-09-05 | 2024-09-09 | 641SF | 0d |  | pedreiro [200%]; servente | 52.8h | 2,476.11 | 12. Casa 12 | 1. Pav. Superior | 8. Contrapiso 1 | Própria |  |  |  |
| 662 | 1.6.12.2.7 | 9.1. Chapisco | 0.5d | 2024-10-16 | 2024-10-16 | 642 | 148.5d | 0d | pedreiro [600%]; servente [400%] | 44h | 5,131.51 | 12. Casa 12 | 1. Pav. Superior | 9. Fachada 1 | Própria |  |  |  |
| 663 | 1.6.12.2.8 | 9.2. Emboço | 1.5d | 2024-12-10 | 2024-12-11 | 596 | 148.5d | 0d | pedreiro [600%]; servente [400%] | 132h | 7,697.26 | 12. Casa 12 | 1. Pav. Superior | 9. Fachada 1 | Própria |  |  |  |
| 664 | 1.6.12.2.9 | 9.3. Pint. 1 Demão | 1d | 2025-01-30 | 2025-01-31 | 597 | 148.5d | 0d | pintor [400%]; aux.pintor [200%] | 52.8h | 1,135.92 | 12. Casa 12 | 1. Pav. Superior | 9. Fachada 1 | Própria |  |  |  |
| 665 | 1.6.12.2.10 | 9.4. Pint. 2 Demão | 2d | 2025-04-24 | 2025-04-28 | 598 | 148.5d | 0d | pintor [400%]; aux.pintor [200%] | 105.6h | 757.28 | 12. Casa 12 | 1. Pav. Superior | 9. Fachada 1 | Própria |  |  |  |
| 666 | 1.6.12.2.11 | 10. Cer. Piso | 4d | 2024-10-23 | 2024-10-28 | 646 | 214d | 0d | pedreiro [400%]; servente [200%] | 211.2h | 19,807.17 | 12. Casa 12 | 1. Pav. Superior | 10. Cer. Piso 1 | Própria | 10 | 10 | 10 |
| 667 | 1.6.12.2.12 | 11. Cer. Parede | 2d | 2025-01-10 | 2025-01-13 | 647 | 214d | 0d | pedreiro [400%]; servente [200%] | 105.6h | 4,238.82 | 12. Casa 12 | 1. Pav. Superior | 11. Cer. Parede 1 | Própria | 11 | 11 | 11 |
| 668 | 1.6.12.2.13 | 12. Forro (WC's e cozinha) | 1d | 2025-02-20 | 2025-02-20 | 648 | 198d | 0d | aux. gesseiro; gesseiro | 17.6h | 635.82 | 12. Casa 12 | 1. Pav. Superior | 12. Forro (WC's e cozinha) 1 | Própria | 12 | 12 | 12 |
| 669 | 1.6.12.2.14 | 13. Esq. Alumínio | 2d | 2025-04-03 | 2025-04-04 | 649 | 164d | 0d | montador esquadrias | 17.6h | 8,489.61 | 12. Casa 12 | 1. Pav. Superior | 13. Esq. Alumínio 1 | Própria | 13 | 13 | 13 |
| 670 | 1.6.12.2.15 | 14. Portas | 2d | 2025-04-07 | 2025-04-08 | 650 | 162d | 0d | marceneiro [200%] | 35.2h | 1,858.35 | 12. Casa 12 | 1. Pav. Superior | 14. Portas 1 | Própria | 14 | 14 | 14 |
| 671 | 1.6.12.2.16 | 15. Pintura (1ª Demão) | 4d | 2025-04-29 | 2025-05-05 | 651 | 82d | 0d | pintor [600%]; aux.pintor [300%] | 316.8h | 3,764.82 | 12. Casa 12 | 1. Pav. Superior | 15. Pintura (1ª Demão) 1 | Própria | 15 | 15 | 15 |
| 672 | 1.6.12.2.17 | 16. Bancadas | 1d | 2025-07-03 | 2025-07-03 | 652 | 113d | 0d | servente; pedreiro [200%] | 26.4h | 6,972.08 | 12. Casa 12 | 1. Pav. Superior | 16. Bancadas 1 | Própria | 16 | 16 | 16 |
| 673 | 1.6.12.2.18 | 17. Pintura (2ª Demão) | 3d | 2025-07-22 | 2025-07-24 | 653 | 82d | 0d | aux.pintor [300%]; pintor [600%] | 237.6h | 1,563.98 | 12. Casa 12 | 1. Pav. Superior | 17. Pintura (2ª Demão) 1 | Própria | 17 | 17 | 17 |
| 674 | 1.6.12.2.19 | 18. Limp. Interna | 1d | 2025-09-10 | 2025-09-10 | 654 | 0d |  | Diarista [200%] | 17.6h | 418.75 | 12. Casa 12 | 1. Pav. Superior | 18. Limp. Interna 1 | Própria | 18 | 18 | 18 |

| ID | WBS | Task | Duration | Start | Finish | Predecessors | Total slack | Free slack | Resources | Work | Cost | Casa | Pav | Equipe | Empresa | Pacote | Cor | LB |
| --- | --- | --- | --- | --- | --- | --- | --- | --- | --- | --- | --- | --- | --- | --- | --- | --- | --- | --- |
| 675 | 1.6.12.3 | **2. Coberta** | 126d | 2024-03-01 | 2024-09-02 |  | 125d |  |  | 536.8h | 58,163.18 |  |  |  |  |  |  |  |
| 676 | 1.6.12.3.1 | 1. Alvenarias | 3d | 2024-03-01 | 2024-03-05 | 657 | 397d | 0d | pedreiro [400%]; servente [400%] | 211.2h | 9,834.12 | 12. Casa 12 | 2. Coberta | 3. Alvenarias 1 | Própria |  |  |  |
| 677 | 1.6.12.3.2 | 2. Impermeabilização | 1d | 2024-09-02 | 2024-09-02 | 660 | 0d |  | aplicador de manta | 8.8h | 24,164.53 | 12. Casa 12 | 2. Coberta | 7. Impermeabilização 1 | Própria |  |  |  |
| 678 | 1.6.12.3.3 | 3. Coberta | 6d | 2024-06-04 | 2024-06-11 | 631 | 361d | 0d | carpinteiro [400%]; aux. Carpinteiro [200%] | 316.8h | 24,164.53 | 12. Casa 12 | 2. Coberta | 4. Coberta 1 | Própria |  |  |  |
| 679 | 1.6.13 | **13. Casa 13** | 478d | 2023-10-03 | 2025-09-12 |  | 70d |  |  | 7594.4h | 338,552.33 |  |  |  |  |  |  |  |
| 680 | 1.6.13.1 | **0. Térreo** | 477d | 2023-10-03 | 2025-09-11 |  | 71d |  |  | 3801.6h | 165,509.25 |  |  |  |  |  |  |  |
| 681 | 1.6.13.1.1 | 0. Locação | 2d | 2023-10-03 | 2023-10-04 | 634 | 540d | 0d | carpinteiro; aux. Carpinteiro | 35.2h | 456.99 | 13. Casa 13 | 0. Térreo | 0. Locação 1 | Própria |  |  |  |
| 682 | 1.6.13.1.2 | 1. Fundação | 9d | 2023-11-17 | 2023-11-29 | 635 | 482d | 0d | servente estrutura [300%]; aux. Carpinteiro; aux. ferreiro; ferreiro; carpinteiro [200%] | 633.6h | 19,882.86 | 13. Casa 13 | 0. Térreo | 1. Fundação 1 | Própria |  |  |  |
| 683 | 1.6.13.1.3 | 2. Estrutura | 7d | 2024-01-31 | 2024-02-08 | 656 | 415d | 0d | servente estrutura [300%]; aux. Carpinteiro [200%]; aux. ferreiro [200%]; ferreiro [500%]; carpinteiro [200%] | 862.4h | 46,439.03 | 13. Casa 13 | 0. Térreo | 2. Estrutura 1 | Própria |  |  |  |
| 684 | 1.6.13.1.4 | 3. Alvenarias | 5d | 2024-03-06 | 2024-03-12 | 676 | 397d | 0d | pedreiro [400%]; servente [400%] | 352h | 8,388.41 | 13. Casa 13 | 0. Térreo | 3. Alvenarias 1 | Própria |  |  |  |
| 685 | 1.6.13.1.5 | 5. Ref. Inter. Arg (Parede) | 3d | 2024-06-26 | 2024-06-28 | 658 | 340d | 0d | pedreiro [600%]; servente [600%] | 316.8h | 5,776 | 13. Casa 13 | 0. Térreo | 5. Ref. Inter. Arg (Parede) 1 | Própria |  |  |  |
| 686 | 1.6.13.1.6 | 6. Revest. Gesso (Parede + Teto) | 3d | 2024-07-05 | 2024-07-10 | 706SF | 365d | 0d | gesseiro [400%]; aux. gesseiro [200%] | 158.4h | 2,119.41 | 13. Casa 13 | 0. Térreo | 6. Revest. Gesso (Parede + Teto) 1 | Própria |  |  |  |
| 687 | 1.6.13.1.7 | 7. Impermeabilização | 2d | 2024-09-03 | 2024-09-04 | 677 | 0d |  | aplicador de manta | 17.6h | 3,288.15 | 13. Casa 13 | 0. Térreo | 7. Impermeabilização 1 | Própria |  |  |  |
| 688 | 1.6.13.1.8 | 8. Contrapiso | 2d | 2024-09-13 | 2024-09-17 | 755SF | 0d |  | pedreiro [200%]; servente | 52.8h | 3,735.07 | 13. Casa 13 | 0. Térreo | 8. Contrapiso 1 | Própria |  |  |  |
| 689 | 1.6.13.1.9 | 9.1. Chapisco | 0.5d | 2024-10-17 | 2024-10-17 | 662 | 148.5d | 0d | pedreiro [600%]; servente [400%] | 44h | 5,131.51 | 13. Casa 13 | 0. Térreo | 9. Fachada 1 | Própria |  |  |  |
| 690 | 1.6.13.1.10 | 9.2. Emboço | 1.5d | 2024-12-16 | 2024-12-17 | 710 | 148.5d | 0d | pedreiro [600%]; servente [400%] | 132h | 7,697.26 | 13. Casa 13 | 0. Térreo | 9. Fachada 1 | Própria |  |  |  |
| 691 | 1.6.13.1.11 | 9.3. Pint. 1 Demão | 1d | 2025-02-04 | 2025-02-05 | 711 | 148.5d | 0d | pintor [400%]; aux.pintor [200%] | 52.8h | 1,135.92 | 13. Casa 13 | 0. Térreo | 9. Fachada 1 | Própria |  |  |  |
| 692 | 1.6.13.1.12 | 9.4. Pint. 2 Demão | 2d | 2025-05-05 | 2025-05-07 | 712 | 148.5d | 0d | pintor [400%]; aux.pintor [200%] | 105.6h | 757.28 | 13. Casa 13 | 0. Térreo | 9. Fachada 1 | Própria |  |  |  |
| 693 | 1.6.13.1.13 | 10. Cer. Piso | 4d | 2024-10-29 | 2024-11-01 | 666 | 214d | 0d | pedreiro [400%]; servente [200%] | 211.2h | 25,485.98 | 13. Casa 13 | 0. Térreo | 10. Cer. Piso 1 | Própria | 10 | 10 | 10 |
| 694 | 1.6.13.1.14 | 11. Cer. Parede | 3d | 2025-01-14 | 2025-01-16 | 667 | 214d | 0d | pedreiro [400%]; servente [200%] | 158.4h | 4,238.82 | 13. Casa 13 | 0. Térreo | 11. Cer. Parede 1 | Própria | 11 | 11 | 11 |
| 695 | 1.6.13.1.15 | 12. Forro (WC's e cozinha) | 1d | 2025-02-21 | 2025-02-21 | 668 | 198d | 0d | gesseiro; aux. gesseiro | 17.6h | 635.82 | 13. Casa 13 | 0. Térreo | 12. Forro (WC's e cozinha) 1 | Própria | 12 | 12 | 12 |
| 696 | 1.6.13.1.16 | 13. Esq. Alumínio | 2d | 2025-04-07 | 2025-04-08 | 669 | 164d | 0d | montador esquadrias | 17.6h | 11,307.22 | 13. Casa 13 | 0. Térreo | 13. Esq. Alumínio 1 | Própria | 13 | 13 | 13 |
| 697 | 1.6.13.1.17 | 14. Portas | 2d | 2025-04-09 | 2025-04-10 | 670 | 162d | 0d | marceneiro [200%] | 35.2h | 2,827.85 | 13. Casa 13 | 0. Térreo | 14. Portas 1 | Própria | 14 | 14 | 14 |
| 698 | 1.6.13.1.18 | 15. Pintura (1ª Demão) | 4d | 2025-05-06 | 2025-05-09 | 671 | 82d | 0d | pintor [600%]; aux.pintor [300%] | 316.8h | 3,764.82 | 13. Casa 13 | 0. Térreo | 15. Pintura (1ª Demão) 1 | Própria | 15 | 15 | 15 |
| 699 | 1.6.13.1.19 | 16. Bancadas | 1d | 2025-07-04 | 2025-07-04 | 672 | 113d | 0d | pedreiro [200%]; servente | 26.4h | 10,458.12 | 13. Casa 13 | 0. Térreo | 16. Bancadas 1 | Própria | 16 | 16 | 16 |
| 700 | 1.6.13.1.20 | 17. Pintura (2ª Demão) | 3d | 2025-07-25 | 2025-07-29 | 673 | 82d | 0d | aux.pintor [300%]; pintor [600%] | 237.6h | 1,563.98 | 13. Casa 13 | 0. Térreo | 17. Pintura (2ª Demão) 1 | Própria | 17 | 17 | 17 |
| 701 | 1.6.13.1.21 | 18. Limp. Interna | 1d | 2025-09-11 | 2025-09-11 | 674 | 0d |  | Diarista [200%] | 17.6h | 418.75 | 13. Casa 13 | 0. Térreo | 18. Limp. Interna 1 | Própria | 18 | 18 | 18 |

| ID | WBS | Task | Duration | Start | Finish | Predecessors | Total slack | Free slack | Resources | Work | Cost | Casa | Pav | Equipe | Empresa | Pacote | Cor | LB |
| --- | --- | --- | --- | --- | --- | --- | --- | --- | --- | --- | --- | --- | --- | --- | --- | --- | --- | --- |
| 702 | 1.6.13.2 | **1. Pav. Superior** | 394d | 2024-02-09 | 2025-09-12 |  | 70d |  |  | 3256h | 114,879.9 |  |  |  |  |  |  |  |
| 703 | 1.6.13.2.1 | 2. Estrutura | 7d | 2024-02-09 | 2024-02-22 | 683 | 415d | 0d | servente estrutura [300%]; aux. Carpinteiro [200%]; aux. ferreiro [200%]; ferreiro [500%]; carpinteiro [200%] | 862.4h | 30,006.55 | 13. Casa 13 | 1. Pav. Superior | 2. Estrutura 1 | Própria |  |  |  |
| 704 | 1.6.13.2.2 | 3. Alvenarias | 5d | 2024-03-13 | 2024-03-20 | 684 | 397d | 0d | servente [400%]; pedreiro [400%] | 352h | 10,101.74 | 13. Casa 13 | 1. Pav. Superior | 3. Alvenarias 1 | Própria |  |  |  |
| 705 | 1.6.13.2.3 | 5. Ref. Inter. Arg (Parede) | 4d | 2024-07-01 | 2024-07-04 | 685 | 340d | 0d | pedreiro [600%]; servente [600%] | 422.4h | 5,398.69 | 13. Casa 13 | 1. Pav. Superior | 5. Ref. Inter. Arg (Parede) 1 | Própria |  |  |  |
| 706 | 1.6.13.2.4 | 6. Revest. Gesso (Parede + Teto) | 4d | 2024-07-10 | 2024-07-16 | 733SF | 361d | 0d | aux. gesseiro [200%]; gesseiro [400%] | 211.2h | 2,119.41 | 13. Casa 13 | 1. Pav. Superior | 6. Revest. Gesso (Parede + Teto) 1 | Própria |  |  |  |
| 707 | 1.6.13.2.5 | 7. Impermeabilização | 1d | 2024-09-05 | 2024-09-05 | 687 | 0d |  | gesseiro [300%]; servente | 35.2h | 2,046.85 | 13. Casa 13 | 1. Pav. Superior | 7. Impermeabilização 1 | Própria |  |  |  |
| 708 | 1.6.13.2.6 | 8. Contrapiso | 2d | 2024-09-11 | 2024-09-13 | 688SF | 0d |  | pedreiro [200%]; servente | 52.8h | 2,476.11 | 13. Casa 13 | 1. Pav. Superior | 8. Contrapiso 1 | Própria |  |  |  |
| 709 | 1.6.13.2.7 | 9.1. Chapisco | 0.5d | 2024-10-17 | 2024-10-17 | 689 | 148.5d | 0d | pedreiro [600%]; servente [400%] | 44h | 5,131.51 | 13. Casa 13 | 1. Pav. Superior | 9. Fachada 1 | Própria |  |  |  |
| 710 | 1.6.13.2.8 | 9.2. Emboço | 1.5d | 2024-12-13 | 2024-12-16 | 643 | 148.5d | 0d | pedreiro [600%]; servente [400%] | 132h | 7,697.26 | 13. Casa 13 | 1. Pav. Superior | 9. Fachada 1 | Própria |  |  |  |
| 711 | 1.6.13.2.9 | 9.3. Pint. 1 Demão | 1d | 2025-02-03 | 2025-02-04 | 644 | 148.5d | 0d | pintor [400%]; aux.pintor [200%] | 52.8h | 1,135.92 | 13. Casa 13 | 1. Pav. Superior | 9. Fachada 1 | Própria |  |  |  |
| 712 | 1.6.13.2.10 | 9.4. Pint. 2 Demão | 2d | 2025-04-30 | 2025-05-05 | 645 | 148.5d | 0d | pintor [400%]; aux.pintor [200%] | 105.6h | 757.28 | 13. Casa 13 | 1. Pav. Superior | 9. Fachada 1 | Própria |  |  |  |
| 713 | 1.6.13.2.11 | 10. Cer. Piso | 4d | 2024-11-04 | 2024-11-07 | 693 | 214d | 0d | servente [200%]; pedreiro [400%] | 211.2h | 19,807.17 | 13. Casa 13 | 1. Pav. Superior | 10. Cer. Piso 1 | Própria | 10 | 10 | 10 |
| 714 | 1.6.13.2.12 | 11. Cer. Parede | 2d | 2025-01-17 | 2025-01-20 | 694 | 214d | 0d | pedreiro [400%]; servente [200%] | 105.6h | 4,238.82 | 13. Casa 13 | 1. Pav. Superior | 11. Cer. Parede 1 | Própria | 11 | 11 | 11 |
| 715 | 1.6.13.2.13 | 12. Forro (WC's e cozinha) | 1d | 2025-02-24 | 2025-02-24 | 695 | 198d | 0d | aux. gesseiro; gesseiro | 17.6h | 895 | 13. Casa 13 | 1. Pav. Superior | 12. Forro (WC's e cozinha) 1 | Própria | 12 | 12 | 12 |
| 716 | 1.6.13.2.14 | 13. Esq. Alumínio | 2d | 2025-04-09 | 2025-04-10 | 696 | 164d | 0d | montador esquadrias | 17.6h | 8,489.61 | 13. Casa 13 | 1. Pav. Superior | 13. Esq. Alumínio 1 | Própria | 13 | 13 | 13 |
| 717 | 1.6.13.2.15 | 14. Portas | 2d | 2025-04-11 | 2025-04-14 | 697 | 162d | 0d | marceneiro [200%] | 35.2h | 1,858.35 | 13. Casa 13 | 1. Pav. Superior | 14. Portas 1 | Própria | 14 | 14 | 14 |
| 718 | 1.6.13.2.16 | 15. Pintura (1ª Demão) | 4d | 2025-05-12 | 2025-05-15 | 698 | 82d | 0d | pintor [600%]; aux.pintor [300%] | 316.8h | 3,764.82 | 13. Casa 13 | 1. Pav. Superior | 15. Pintura (1ª Demão) 1 | Própria | 15 | 15 | 15 |
| 719 | 1.6.13.2.17 | 16. Bancadas | 1d | 2025-07-07 | 2025-07-07 | 699 | 113d | 0d | servente; pedreiro [200%] | 26.4h | 6,972.08 | 13. Casa 13 | 1. Pav. Superior | 16. Bancadas 1 | Própria | 16 | 16 | 16 |
| 720 | 1.6.13.2.18 | 17. Pintura (2ª Demão) | 3d | 2025-07-30 | 2025-08-01 | 700 | 82d | 0d | aux.pintor [300%]; pintor [600%] | 237.6h | 1,563.98 | 13. Casa 13 | 1. Pav. Superior | 17. Pintura (2ª Demão) 1 | Própria | 17 | 17 | 17 |
| 721 | 1.6.13.2.19 | 18. Limp. Interna | 1d | 2025-09-12 | 2025-09-12 | 701 | 0d |  | Diarista [200%] | 17.6h | 418.75 | 13. Casa 13 | 1. Pav. Superior | 18. Limp. Interna 1 | Própria | 18 | 18 | 18 |
| 722 | 1.6.13.3 | **2. Coberta** | 117d | 2024-03-21 | 2024-09-06 |  | 116d |  |  | 536.8h | 58,163.18 |  |  |  |  |  |  |  |
| 723 | 1.6.13.3.1 | 1. Alvenarias | 3d | 2024-03-21 | 2024-03-26 | 704 | 397d | 0d | pedreiro [400%]; servente [400%] | 211.2h | 9,834.12 | 13. Casa 13 | 2. Coberta | 3. Alvenarias 1 | Própria |  |  |  |
| 724 | 1.6.13.3.2 | 2. Impermeabilização | 1d | 2024-09-06 | 2024-09-06 | 707 | 0d |  | aplicador de manta | 8.8h | 24,164.53 | 13. Casa 13 | 2. Coberta | 7. Impermeabilização 1 | Própria |  |  |  |
| 725 | 1.6.13.3.3 | 3. Coberta | 6d | 2024-06-12 | 2024-06-19 | 678 | 361d | 0d | carpinteiro [400%]; aux. Carpinteiro [200%] | 316.8h | 24,164.53 | 13. Casa 13 | 2. Coberta | 4. Coberta 1 | Própria |  |  |  |

| ID | WBS | Task | Duration | Start | Finish | Predecessors | Total slack | Free slack | Resources | Work | Cost | Casa | Pav | Equipe | Empresa | Pacote | Cor | LB |
| --- | --- | --- | --- | --- | --- | --- | --- | --- | --- | --- | --- | --- | --- | --- | --- | --- | --- | --- |
| 726 | 1.6.14 | **14. Casa 14** | 478d | 2023-10-05 | 2025-09-16 |  | 68d |  |  | 7594.4h | 338,552.33 |  |  |  |  |  |  |  |
| 727 | 1.6.14.1 | **0. Térreo** | 477d | 2023-10-05 | 2025-09-15 |  | 69d |  |  | 3801.6h | 165,509.25 |  |  |  |  |  |  |  |
| 728 | 1.6.14.1.1 | 0. Locação | 2d | 2023-10-05 | 2023-10-06 | 681 | 540d | 0d | carpinteiro; aux. Carpinteiro | 35.2h | 456.99 | 14. Casa 14 | 0. Térreo | 0. Locação 1 | Própria |  |  |  |
| 729 | 1.6.14.1.2 | 1. Fundação | 9d | 2023-11-30 | 2023-12-12 | 682 | 482d | 0d | servente estrutura [300%]; aux. Carpinteiro; aux. ferreiro; ferreiro; carpinteiro [200%] | 633.6h | 19,882.86 | 14. Casa 14 | 0. Térreo | 1. Fundação 1 | Própria |  |  |  |
| 730 | 1.6.14.1.3 | 2. Estrutura | 7d | 2024-02-23 | 2024-03-04 | 703 | 415d | 0d | servente estrutura [300%]; aux. Carpinteiro [200%]; aux. ferreiro [200%]; ferreiro [500%]; carpinteiro [200%] | 862.4h | 46,439.03 | 14. Casa 14 | 0. Térreo | 2. Estrutura 1 | Própria |  |  |  |
| 731 | 1.6.14.1.4 | 3. Alvenarias | 5d | 2024-03-27 | 2024-04-03 | 723 | 397d | 0d | pedreiro [400%]; servente [400%] | 352h | 8,388.41 | 14. Casa 14 | 0. Térreo | 3. Alvenarias 1 | Própria |  |  |  |
| 732 | 1.6.14.1.5 | 5. Ref. Inter. Arg (Parede) | 3d | 2024-07-05 | 2024-07-09 | 705 | 340d | 0d | pedreiro [600%]; servente [600%] | 316.8h | 5,776 | 14. Casa 14 | 0. Térreo | 5. Ref. Inter. Arg (Parede) 1 | Própria |  |  |  |
| 733 | 1.6.14.1.6 | 6. Revest. Gesso (Parede + Teto) | 3d | 2024-07-16 | 2024-07-19 | 753SF | 358d | 0d | gesseiro [400%]; aux. gesseiro [200%] | 158.4h | 2,119.41 | 14. Casa 14 | 0. Térreo | 6. Revest. Gesso (Parede + Teto) 1 | Própria |  |  |  |
| 734 | 1.6.14.1.7 | 7. Impermeabilização | 2d | 2024-09-09 | 2024-09-10 | 724 | 0d |  | aplicador de manta | 17.6h | 3,288.15 | 14. Casa 14 | 0. Térreo | 7. Impermeabilização 1 | Própria |  |  |  |
| 735 | 1.6.14.1.8 | 8. Contrapiso | 2d | 2024-09-19 | 2024-09-23 | 802SF | 0d |  | pedreiro [200%]; servente | 52.8h | 3,735.07 | 14. Casa 14 | 0. Térreo | 8. Contrapiso 1 | Própria |  |  |  |
| 736 | 1.6.14.1.9 | 9.1. Chapisco | 0.5d | 2024-10-18 | 2024-10-18 | 709 | 148.5d | 0d | pedreiro [600%]; servente [400%] | 44h | 5,131.51 | 14. Casa 14 | 0. Térreo | 9. Fachada 1 | Própria |  |  |  |
| 737 | 1.6.14.1.10 | 9.2. Emboço | 1.5d | 2024-12-19 | 2024-12-20 | 757 | 148.5d | 0d | pedreiro [600%]; servente [400%] | 132h | 7,697.26 | 14. Casa 14 | 0. Térreo | 9. Fachada 1 | Própria |  |  |  |
| 738 | 1.6.14.1.11 | 9.3. Pint. 1 Demão | 1d | 2025-02-06 | 2025-02-07 | 758 | 148.5d | 0d | pintor [400%]; aux.pintor [200%] | 52.8h | 1,135.92 | 14. Casa 14 | 0. Térreo | 9. Fachada 1 | Própria |  |  |  |
| 739 | 1.6.14.1.12 | 9.4. Pint. 2 Demão | 2d | 2025-05-09 | 2025-05-13 | 759 | 148.5d | 0d | pintor [400%]; aux.pintor [200%] | 105.6h | 757.28 | 14. Casa 14 | 0. Térreo | 9. Fachada 1 | Própria |  |  |  |
| 740 | 1.6.14.1.13 | 10. Cer. Piso | 4d | 2024-11-08 | 2024-11-13 | 713 | 214d | 0d | pedreiro [400%]; servente [200%] | 211.2h | 25,485.98 | 14. Casa 14 | 0. Térreo | 10. Cer. Piso 1 | Própria | 10 | 10 | 10 |
| 741 | 1.6.14.1.14 | 11. Cer. Parede | 3d | 2025-01-21 | 2025-01-23 | 714 | 214d | 0d | pedreiro [400%]; servente [200%] | 158.4h | 4,238.82 | 14. Casa 14 | 0. Térreo | 11. Cer. Parede 1 | Própria | 11 | 11 | 11 |
| 742 | 1.6.14.1.15 | 12. Forro (WC's e cozinha) | 1d | 2025-02-25 | 2025-02-25 | 715 | 198d | 0d | gesseiro; aux. gesseiro | 17.6h | 635.82 | 14. Casa 14 | 0. Térreo | 12. Forro (WC's e cozinha) 1 | Própria | 12 | 12 | 12 |
| 743 | 1.6.14.1.16 | 13. Esq. Alumínio | 2d | 2025-04-11 | 2025-04-14 | 716 | 164d | 0d | montador esquadrias | 17.6h | 11,307.22 | 14. Casa 14 | 0. Térreo | 13. Esq. Alumínio 1 | Própria | 13 | 13 | 13 |
| 744 | 1.6.14.1.17 | 14. Portas | 2d | 2025-04-15 | 2025-04-16 | 717 | 162d | 0d | marceneiro [200%] | 35.2h | 2,827.85 | 14. Casa 14 | 0. Térreo | 14. Portas 1 | Própria | 14 | 14 | 14 |
| 745 | 1.6.14.1.18 | 15. Pintura (1ª Demão) | 4d | 2025-05-16 | 2025-05-21 | 718 | 82d | 0d | pintor [600%]; aux.pintor [300%] | 316.8h | 3,764.82 | 14. Casa 14 | 0. Térreo | 15. Pintura (1ª Demão) 1 | Própria | 15 | 15 | 15 |
| 746 | 1.6.14.1.19 | 16. Bancadas | 1d | 2025-07-08 | 2025-07-08 | 719 | 113d | 0d | pedreiro [200%]; servente | 26.4h | 10,458.12 | 14. Casa 14 | 0. Térreo | 16. Bancadas 1 | Própria | 16 | 16 | 16 |
| 747 | 1.6.14.1.20 | 17. Pintura (2ª Demão) | 3d | 2025-08-04 | 2025-08-06 | 720 | 82d | 0d | aux.pintor [300%]; pintor [600%] | 237.6h | 1,563.98 | 14. Casa 14 | 0. Térreo | 17. Pintura (2ª Demão) 1 | Própria | 17 | 17 | 17 |
| 748 | 1.6.14.1.21 | 18. Limp. Interna | 1d | 2025-09-15 | 2025-09-15 | 721 | 0d |  | Diarista [200%] | 17.6h | 418.75 | 14. Casa 14 | 0. Térreo | 18. Limp. Interna 1 | Própria | 18 | 18 | 18 |
| 749 | 1.6.14.2 | **1. Pav. Superior** | 382d | 2024-03-05 | 2025-09-16 |  | 68d |  |  | 3256h | 114,879.9 |  |  |  |  |  |  |  |
| 750 | 1.6.14.2.1 | 2. Estrutura | 7d | 2024-03-05 | 2024-03-13 | 730 | 415d | 0d | servente estrutura [300%]; aux. Carpinteiro [200%]; aux. ferreiro [200%]; ferreiro [500%]; carpinteiro [200%] | 862.4h | 30,006.55 | 14. Casa 14 | 1. Pav. Superior | 2. Estrutura 1 | Própria |  |  |  |
| 751 | 1.6.14.2.2 | 3. Alvenarias | 5d | 2024-04-04 | 2024-04-10 | 731 | 397d | 0d | servente [400%]; pedreiro [400%] | 352h | 10,101.74 | 14. Casa 14 | 1. Pav. Superior | 3. Alvenarias 1 | Própria |  |  |  |
| 752 | 1.6.14.2.3 | 5. Ref. Inter. Arg (Parede) | 4d | 2024-07-10 | 2024-07-15 | 732 | 340d | 0d | pedreiro [600%]; servente [600%] | 422.4h | 5,398.69 | 14. Casa 14 | 1. Pav. Superior | 5. Ref. Inter. Arg (Parede) 1 | Própria |  |  |  |
| 753 | 1.6.14.2.4 | 6. Revest. Gesso (Parede + Teto) | 4d | 2024-07-19 | 2024-07-25 | 780SF | 354d | 0d | aux. gesseiro [200%]; gesseiro [400%] | 211.2h | 2,119.41 | 14. Casa 14 | 1. Pav. Superior | 6. Revest. Gesso (Parede + Teto) 1 | Própria |  |  |  |
| 754 | 1.6.14.2.5 | 7. Impermeabilização | 1d | 2024-09-11 | 2024-09-11 | 734 | 0d |  | gesseiro [300%]; servente | 35.2h | 2,046.85 | 14. Casa 14 | 1. Pav. Superior | 7. Impermeabilização 1 | Própria |  |  |  |
| 755 | 1.6.14.2.6 | 8. Contrapiso | 2d | 2024-09-17 | 2024-09-19 | 735SF | 0d |  | pedreiro [200%]; servente | 52.8h | 2,476.11 | 14. Casa 14 | 1. Pav. Superior | 8. Contrapiso 1 | Própria |  |  |  |
| 756 | 1.6.14.2.7 | 9.1. Chapisco | 0.5d | 2024-10-18 | 2024-10-18 | 736 | 148.5d | 0d | pedreiro [600%]; servente [400%] | 44h | 5,131.51 | 14. Casa 14 | 1. Pav. Superior | 9. Fachada 1 | Própria |  |  |  |
| 757 | 1.6.14.2.8 | 9.2. Emboço | 1.5d | 2024-12-18 | 2024-12-19 | 690 | 148.5d | 0d | pedreiro [600%]; servente [400%] | 132h | 7,697.26 | 14. Casa 14 | 1. Pav. Superior | 9. Fachada 1 | Própria |  |  |  |
| 758 | 1.6.14.2.9 | 9.3. Pint. 1 Demão | 1d | 2025-02-05 | 2025-02-06 | 691 | 148.5d | 0d | pintor [400%]; aux.pintor [200%] | 52.8h | 1,135.92 | 14. Casa 14 | 1. Pav. Superior | 9. Fachada 1 | Própria |  |  |  |
| 759 | 1.6.14.2.10 | 9.4. Pint. 2 Demão | 2d | 2025-05-07 | 2025-05-09 | 692 | 148.5d | 0d | pintor [400%]; aux.pintor [200%] | 105.6h | 757.28 | 14. Casa 14 | 1. Pav. Superior | 9. Fachada 1 | Própria |  |  |  |
| 760 | 1.6.14.2.11 | 10. Cer. Piso | 4d | 2024-11-14 | 2024-11-20 | 740 | 214d | 0d | pedreiro [400%]; servente [200%] | 211.2h | 19,807.17 | 14. Casa 14 | 1. Pav. Superior | 10. Cer. Piso 1 | Própria | 10 | 10 | 10 |
| 761 | 1.6.14.2.12 | 11. Cer. Parede | 2d | 2025-01-24 | 2025-01-27 | 741 | 214d | 0d | pedreiro [400%]; servente [200%] | 105.6h | 4,238.82 | 14. Casa 14 | 1. Pav. Superior | 11. Cer. Parede 1 | Própria | 11 | 11 | 11 |
| 762 | 1.6.14.2.13 | 12. Forro (WC's e cozinha) | 1d | 2025-02-26 | 2025-02-26 | 742 | 198d | 0d | aux. gesseiro; gesseiro | 17.6h | 895 | 14. Casa 14 | 1. Pav. Superior | 12. Forro (WC's e cozinha) 1 | Própria | 12 | 12 | 12 |
| 763 | 1.6.14.2.14 | 13. Esq. Alumínio | 2d | 2025-04-15 | 2025-04-16 | 743 | 164d | 0d | montador esquadrias | 17.6h | 8,489.61 | 14. Casa 14 | 1. Pav. Superior | 13. Esq. Alumínio 1 | Própria | 13 | 13 | 13 |
| 764 | 1.6.14.2.15 | 14. Portas | 2d | 2025-04-17 | 2025-04-22 | 744 | 162d | 0d | marceneiro [200%] | 35.2h | 1,858.35 | 14. Casa 14 | 1. Pav. Superior | 14. Portas 1 | Própria | 14 | 14 | 14 |
| 765 | 1.6.14.2.16 | 15. Pintura (1ª Demão) | 4d | 2025-05-22 | 2025-05-27 | 745 | 82d | 0d | pintor [600%]; aux.pintor [300%] | 316.8h | 3,764.82 | 14. Casa 14 | 1. Pav. Superior | 15. Pintura (1ª Demão) 1 | Própria | 15 | 15 | 15 |
| 766 | 1.6.14.2.17 | 16. Bancadas | 1d | 2025-07-09 | 2025-07-09 | 746 | 113d | 0d | servente; pedreiro [200%] | 26.4h | 6,972.08 | 14. Casa 14 | 1. Pav. Superior | 16. Bancadas 1 | Própria | 16 | 16 | 16 |
| 767 | 1.6.14.2.18 | 17. Pintura (2ª Demão) | 3d | 2025-08-07 | 2025-08-11 | 747 | 82d | 0d | aux.pintor [300%]; pintor [600%] | 237.6h | 1,563.98 | 14. Casa 14 | 1. Pav. Superior | 17. Pintura (2ª Demão) 1 | Própria | 17 | 17 | 17 |
| 768 | 1.6.14.2.19 | 18. Limp. Interna | 1d | 2025-09-16 | 2025-09-16 | 748 | 0d |  | Diarista [200%] | 17.6h | 418.75 | 14. Casa 14 | 1. Pav. Superior | 18. Limp. Interna 1 | Própria | 18 | 18 | 18 |

| ID | WBS | Task | Duration | Start | Finish | Predecessors | Total slack | Free slack | Resources | Work | Cost | Casa | Pav | Equipe | Empresa | Pacote | Cor | LB |
| --- | --- | --- | --- | --- | --- | --- | --- | --- | --- | --- | --- | --- | --- | --- | --- | --- | --- | --- |
| 769 | 1.6.14.3 | **2. Coberta** | 108d | 2024-04-11 | 2024-09-12 |  | 107d |  |  | 536.8h | 58,163.18 |  |  |  |  |  |  |  |
| 770 | 1.6.14.3.1 | 1. Alvenarias | 3d | 2024-04-11 | 2024-04-15 | 751 | 397d | 0d | pedreiro [400%]; servente [400%] | 211.2h | 9,834.12 | 14. Casa 14 | 2. Coberta | 3. Alvenarias 1 | Própria |  |  |  |
| 771 | 1.6.14.3.2 | 2. Impermeabilização | 1d | 2024-09-12 | 2024-09-12 | 754 | 0d |  | aplicador de manta | 8.8h | 24,164.53 | 14. Casa 14 | 2. Coberta | 7. Impermeabilização 1 | Própria |  |  |  |
| 772 | 1.6.14.3.3 | 3. Coberta | 6d | 2024-06-20 | 2024-06-27 | 725 | 361d | 0d | carpinteiro [400%]; aux. Carpinteiro [200%] | 316.8h | 24,164.53 | 14. Casa 14 | 2. Coberta | 4. Coberta 1 | Própria |  |  |  |
| 773 | 1.6.15 | **15. Casa 15** | 478d | 2023-10-09 | 2025-09-18 |  | 66d |  |  | 7594.4h | 338,552.33 |  |  |  |  |  |  |  |
| 774 | 1.6.15.1 | **0. Térreo** | 477d | 2023-10-09 | 2025-09-17 |  | 67d |  |  | 3801.6h | 165,509.25 |  |  |  |  |  |  |  |
| 775 | 1.6.15.1.1 | 0. Locação | 2d | 2023-10-09 | 2023-10-10 | 728 | 540d | 0d | carpinteiro; aux. Carpinteiro | 35.2h | 456.99 | 15. Casa 15 | 0. Térreo | 0. Locação 1 | Própria |  |  |  |
| 776 | 1.6.15.1.2 | 1. Fundação | 9d | 2023-12-13 | 2024-01-02 | 729 | 482d | 0d | servente estrutura [300%]; aux. Carpinteiro; aux. ferreiro; ferreiro; carpinteiro [200%] | 633.6h | 19,882.86 | 15. Casa 15 | 0. Térreo | 1. Fundação 1 | Própria |  |  |  |
| 777 | 1.6.15.1.3 | 2. Estrutura | 7d | 2024-03-14 | 2024-03-26 | 750 | 415d | 0d | servente estrutura [300%]; aux. Carpinteiro [200%]; aux. ferreiro [200%]; ferreiro [500%]; carpinteiro [200%] | 862.4h | 46,439.03 | 15. Casa 15 | 0. Térreo | 2. Estrutura 1 | Própria |  |  |  |
| 778 | 1.6.15.1.4 | 3. Alvenarias | 5d | 2024-04-16 | 2024-04-22 | 770 | 397d | 0d | pedreiro [400%]; servente [400%] | 352h | 8,388.41 | 15. Casa 15 | 0. Térreo | 3. Alvenarias 1 | Própria |  |  |  |
| 779 | 1.6.15.1.5 | 5. Ref. Inter. Arg (Parede) | 3d | 2024-07-16 | 2024-07-18 | 752 | 340d | 0d | pedreiro [600%]; servente [600%] | 316.8h | 5,776 | 15. Casa 15 | 0. Térreo | 5. Ref. Inter. Arg (Parede) 1 | Própria |  |  |  |
| 780 | 1.6.15.1.6 | 6. Revest. Gesso (Parede + Teto) | 3d | 2024-07-25 | 2024-07-30 | 800SF | 351d | 0d | gesseiro [400%]; aux. gesseiro [200%] | 158.4h | 2,119.41 | 15. Casa 15 | 0. Térreo | 6. Revest. Gesso (Parede + Teto) 1 | Própria |  |  |  |
| 781 | 1.6.15.1.7 | 7. Impermeabilização | 2d | 2024-09-13 | 2024-09-16 | 771 | 0d |  | aplicador de manta | 17.6h | 3,288.15 | 15. Casa 15 | 0. Térreo | 7. Impermeabilização 1 | Própria |  |  |  |
| 782 | 1.6.15.1.8 | 8. Contrapiso | 2d | 2024-09-25 | 2024-09-27 | 849SF | 0d |  | pedreiro [200%]; servente | 52.8h | 3,735.07 | 15. Casa 15 | 0. Térreo | 8. Contrapiso 1 | Própria |  |  |  |
| 783 | 1.6.15.1.9 | 9.1. Chapisco | 0.5d | 2024-10-21 | 2024-10-21 | 756 | 148.5d | 0d | pedreiro [600%]; servente [400%] | 44h | 5,131.51 | 15. Casa 15 | 0. Térreo | 9. Fachada 1 | Própria |  |  |  |
| 784 | 1.6.15.1.10 | 9.2. Emboço | 1.5d | 2024-12-24 | 2024-12-26 | 804 | 148.5d | 0d | pedreiro [600%]; servente [400%] | 132h | 7,697.26 | 15. Casa 15 | 0. Térreo | 9. Fachada 1 | Própria |  |  |  |
| 785 | 1.6.15.1.11 | 9.3. Pint. 1 Demão | 1d | 2025-02-10 | 2025-02-11 | 805 | 148.5d | 0d | pintor [400%]; aux.pintor [200%] | 52.8h | 1,135.92 | 15. Casa 15 | 0. Térreo | 9. Fachada 1 | Própria |  |  |  |
| 786 | 1.6.15.1.12 | 9.4. Pint. 2 Demão | 2d | 2025-05-15 | 2025-05-19 | 806 | 148.5d | 0d | pintor [400%]; aux.pintor [200%] | 105.6h | 757.28 | 15. Casa 15 | 0. Térreo | 9. Fachada 1 | Própria |  |  |  |
| 787 | 1.6.15.1.13 | 10. Cer. Piso | 4d | 2024-11-21 | 2024-11-26 | 760 | 214d | 0d | pedreiro [400%]; servente [200%] | 211.2h | 25,485.98 | 15. Casa 15 | 0. Térreo | 10. Cer. Piso 1 | Própria | 10 | 10 | 10 |
| 788 | 1.6.15.1.14 | 11. Cer. Parede | 3d | 2025-01-28 | 2025-01-30 | 761 | 214d | 0d | pedreiro [400%]; servente [200%] | 158.4h | 4,238.82 | 15. Casa 15 | 0. Térreo | 11. Cer. Parede 1 | Própria | 11 | 11 | 11 |
| 789 | 1.6.15.1.15 | 12. Forro (WC's e cozinha) | 1d | 2025-02-27 | 2025-02-27 | 762 | 198d | 0d | gesseiro; aux. gesseiro | 17.6h | 635.82 | 15. Casa 15 | 0. Térreo | 12. Forro (WC's e cozinha) 1 | Própria | 12 | 12 | 12 |
| 790 | 1.6.15.1.16 | 13. Esq. Alumínio | 2d | 2025-04-17 | 2025-04-22 | 763 | 164d | 0d | montador esquadrias | 17.6h | 11,307.22 | 15. Casa 15 | 0. Térreo | 13. Esq. Alumínio 1 | Própria | 13 | 13 | 13 |
| 791 | 1.6.15.1.17 | 14. Portas | 2d | 2025-04-23 | 2025-04-24 | 764 | 162d | 0d | marceneiro [200%] | 35.2h | 2,827.85 | 15. Casa 15 | 0. Térreo | 14. Portas 1 | Própria | 14 | 14 | 14 |
| 792 | 1.6.15.1.18 | 15. Pintura (1ª Demão) | 4d | 2025-05-28 | 2025-06-02 | 765 | 82d | 0d | pintor [600%]; aux.pintor [300%] | 316.8h | 3,764.82 | 15. Casa 15 | 0. Térreo | 15. Pintura (1ª Demão) 1 | Própria | 15 | 15 | 15 |
| 793 | 1.6.15.1.19 | 16. Bancadas | 1d | 2025-07-10 | 2025-07-10 | 766 | 113d | 0d | pedreiro [200%]; servente | 26.4h | 10,458.12 | 15. Casa 15 | 0. Térreo | 16. Bancadas 1 | Própria | 16 | 16 | 16 |
| 794 | 1.6.15.1.20 | 17. Pintura (2ª Demão) | 3d | 2025-08-12 | 2025-08-14 | 767 | 82d | 0d | aux.pintor [300%]; pintor [600%] | 237.6h | 1,563.98 | 15. Casa 15 | 0. Térreo | 17. Pintura (2ª Demão) 1 | Própria | 17 | 17 | 17 |
| 795 | 1.6.15.1.21 | 18. Limp. Interna | 1d | 2025-09-17 | 2025-09-17 | 768 | 0d |  | Diarista [200%] | 17.6h | 418.75 | 15. Casa 15 | 0. Térreo | 18. Limp. Interna 1 | Própria | 18 | 18 | 18 |

| ID | WBS | Task | Duration | Start | Finish | Predecessors | Total slack | Free slack | Resources | Work | Cost | Casa | Pav | Equipe | Empresa | Pacote | Cor | LB |
| --- | --- | --- | --- | --- | --- | --- | --- | --- | --- | --- | --- | --- | --- | --- | --- | --- | --- | --- |
| 796 | 1.6.15.2 | **1. Pav. Superior** | 370d | 2024-03-27 | 2025-09-18 |  | 64d |  |  | 3256h | 114,879.9 |  |  |  |  |  |  |  |
| 797 | 1.6.15.2.1 | 2. Estrutura | 7d | 2024-03-27 | 2024-04-05 | 777 | 415d | 0d | servente estrutura [300%]; aux. Carpinteiro [200%]; aux. ferreiro [200%]; ferreiro [500%]; carpinteiro [200%] | 862.4h | 30,006.55 | 15. Casa 15 | 1. Pav. Superior | 2. Estrutura 1 | Própria |  |  |  |
| 798 | 1.6.15.2.2 | 3. Alvenarias | 5d | 2024-04-23 | 2024-04-29 | 778 | 397d | 0d | servente [400%]; pedreiro [400%] | 352h | 10,101.74 | 15. Casa 15 | 1. Pav. Superior | 3. Alvenarias 1 | Própria |  |  |  |
| 799 | 1.6.15.2.3 | 5. Ref. Inter. Arg (Parede) | 4d | 2024-07-19 | 2024-07-24 | 779 | 340d | 0d | pedreiro [600%]; servente [600%] | 422.4h | 5,398.69 | 15. Casa 15 | 1. Pav. Superior | 5. Ref. Inter. Arg (Parede) 1 | Própria |  |  |  |
| 800 | 1.6.15.2.4 | 6. Revest. Gesso (Parede + Teto) | 4d | 2024-07-30 | 2024-08-02 | 826 | 340d | 0d | aux. gesseiro [200%]; gesseiro [400%] | 211.2h | 2,119.41 | 15. Casa 15 | 1. Pav. Superior | 6. Revest. Gesso (Parede + Teto) 1 | Própria |  |  |  |
| 801 | 1.6.15.2.5 | 7. Impermeabilização | 1d | 2024-09-17 | 2024-09-17 | 781 | 0d |  | gesseiro [300%]; servente | 35.2h | 2,046.85 | 15. Casa 15 | 1. Pav. Superior | 7. Impermeabilização 1 | Própria |  |  |  |
| 802 | 1.6.15.2.6 | 8. Contrapiso | 2d | 2024-09-23 | 2024-09-25 | 782SF | 0d |  | pedreiro [200%]; servente | 52.8h | 2,476.11 | 15. Casa 15 | 1. Pav. Superior | 8. Contrapiso 1 | Própria |  |  |  |
| 803 | 1.6.15.2.7 | 9.1. Chapisco | 0.5d | 2024-10-21 | 2024-10-21 | 783 | 148.5d | 0d | pedreiro [600%]; servente [400%] | 44h | 5,131.51 | 15. Casa 15 | 1. Pav. Superior | 9. Fachada 1 | Própria |  |  |  |
| 804 | 1.6.15.2.8 | 9.2. Emboço | 1.5d | 2024-12-23 | 2024-12-24 | 737 | 148.5d | 0d | pedreiro [600%]; servente [400%] | 132h | 7,697.26 | 15. Casa 15 | 1. Pav. Superior | 9. Fachada 1 | Própria |  |  |  |
| 805 | 1.6.15.2.9 | 9.3. Pint. 1 Demão | 1d | 2025-02-07 | 2025-02-10 | 738 | 148.5d | 0d | pintor [400%]; aux.pintor [200%] | 52.8h | 1,135.92 | 15. Casa 15 | 1. Pav. Superior | 9. Fachada 1 | Própria |  |  |  |
| 806 | 1.6.15.2.10 | 9.4. Pint. 2 Demão | 2d | 2025-05-13 | 2025-05-15 | 739 | 148.5d | 0d | pintor [400%]; aux.pintor [200%] | 105.6h | 757.28 | 15. Casa 15 | 1. Pav. Superior | 9. Fachada 1 | Própria |  |  |  |
| 807 | 1.6.15.2.11 | 10. Cer. Piso | 4d | 2024-11-27 | 2024-12-02 | 787 | 214d | 0d | servente [200%]; pedreiro [400%] | 211.2h | 19,807.17 | 15. Casa 15 | 1. Pav. Superior | 10. Cer. Piso 1 | Própria | 10 | 10 | 10 |
| 808 | 1.6.15.2.12 | 11. Cer. Parede | 2d | 2025-01-31 | 2025-02-03 | 788 | 214d | 0d | pedreiro [400%]; servente [200%] | 105.6h | 4,238.82 | 15. Casa 15 | 1. Pav. Superior | 11. Cer. Parede 1 | Própria | 11 | 11 | 11 |
| 809 | 1.6.15.2.13 | 12. Forro (WC's e cozinha) | 1d | 2025-02-28 | 2025-02-28 | 789 | 198d | 0d | aux. gesseiro; gesseiro | 17.6h | 895 | 15. Casa 15 | 1. Pav. Superior | 12. Forro (WC's e cozinha) 1 | Própria | 12 | 12 | 12 |
| 810 | 1.6.15.2.14 | 13. Esq. Alumínio | 2d | 2025-04-23 | 2025-04-24 | 790 | 164d | 0d | montador esquadrias | 17.6h | 8,489.61 | 15. Casa 15 | 1. Pav. Superior | 13. Esq. Alumínio 1 | Própria | 13 | 13 | 13 |
| 811 | 1.6.15.2.15 | 14. Portas | 2d | 2025-04-25 | 2025-04-28 | 791 | 162d | 0d | marceneiro [200%] | 35.2h | 1,858.35 | 15. Casa 15 | 1. Pav. Superior | 14. Portas 1 | Própria | 14 | 14 | 14 |
| 812 | 1.6.15.2.16 | 15. Pintura (1ª Demão) | 4d | 2025-06-03 | 2025-06-06 | 792 | 82d | 0d | pintor [600%]; aux.pintor [300%] | 316.8h | 3,764.82 | 15. Casa 15 | 1. Pav. Superior | 15. Pintura (1ª Demão) 1 | Própria | 15 | 15 | 15 |
| 813 | 1.6.15.2.17 | 16. Bancadas | 1d | 2025-07-11 | 2025-07-11 | 793 | 113d | 0d | servente; pedreiro [200%] | 26.4h | 6,972.08 | 15. Casa 15 | 1. Pav. Superior | 16. Bancadas 1 | Própria | 16 | 16 | 16 |
| 814 | 1.6.15.2.18 | 17. Pintura (2ª Demão) | 3d | 2025-08-15 | 2025-08-19 | 794 | 82d | 0d | aux.pintor [300%]; pintor [600%] | 237.6h | 1,563.98 | 15. Casa 15 | 1. Pav. Superior | 17. Pintura (2ª Demão) 1 | Própria | 17 | 17 | 17 |
| 815 | 1.6.15.2.19 | 18. Limp. Interna | 1d | 2025-09-18 | 2025-09-18 | 795 | 0d |  | Diarista [200%] | 17.6h | 418.75 | 15. Casa 15 | 1. Pav. Superior | 18. Limp. Interna 1 | Própria | 18 | 18 | 18 |
| 816 | 1.6.15.3 | **2. Coberta** | 99d | 2024-04-30 | 2024-09-18 |  | 98d |  |  | 536.8h | 58,163.18 |  |  |  |  |  |  |  |
| 817 | 1.6.15.3.1 | 1. Alvenarias | 3d | 2024-04-30 | 2024-05-03 | 798 | 397d | 0d | pedreiro [400%]; servente [400%] | 211.2h | 9,834.12 | 15. Casa 15 | 2. Coberta | 3. Alvenarias 1 | Própria |  |  |  |
| 818 | 1.6.15.3.2 | 2. Impermeabilização | 1d | 2024-09-18 | 2024-09-18 | 801 | 0d |  | aplicador de manta | 8.8h | 24,164.53 | 15. Casa 15 | 2. Coberta | 7. Impermeabilização 1 | Própria |  |  |  |
| 819 | 1.6.15.3.3 | 3. Coberta | 6d | 2024-06-28 | 2024-07-05 | 772 | 361d | 0d | carpinteiro [400%]; aux. Carpinteiro [200%] | 316.8h | 24,164.53 | 15. Casa 15 | 2. Coberta | 4. Coberta 1 | Própria |  |  |  |

| ID | WBS | Task | Duration | Start | Finish | Predecessors | Total slack | Free slack | Resources | Work | Cost | Casa | Pav | Equipe | Empresa | Pacote | Cor | LB |
| --- | --- | --- | --- | --- | --- | --- | --- | --- | --- | --- | --- | --- | --- | --- | --- | --- | --- | --- |
| 820 | 1.6.16 | **16. Casa 16** | 478d | 2023-10-11 | 2025-09-22 |  | 64d |  |  | 7594.4h | 338,552.33 |  |  |  |  |  |  |  |
| 821 | 1.6.16.1 | **0. Térreo** | 477d | 2023-10-11 | 2025-09-19 |  | 65d |  |  | 3801.6h | 165,509.25 |  |  |  |  |  |  |  |
| 822 | 1.6.16.1.1 | 0. Locação | 2d | 2023-10-11 | 2023-10-13 | 775 | 540d |  | carpinteiro; aux. Carpinteiro | 35.2h | 456.99 | 16. Casa 16 | 0. Térreo | 0. Locação 1 | Própria |  |  |  |
| 823 | 1.6.16.1.2 | 1. Fundação | 9d | 2024-01-03 | 2024-01-15 | 776 | 482d | 0d | servente estrutura [300%]; aux. Carpinteiro; aux. ferreiro; ferreiro; carpinteiro [200%] | 633.6h | 19,882.86 | 16. Casa 16 | 0. Térreo | 1. Fundação 1 | Própria |  |  |  |
| 824 | 1.6.16.1.3 | 2. Estrutura | 7d | 2024-04-08 | 2024-04-16 | 797 | 415d | 0d | servente estrutura [300%]; aux. Carpinteiro [200%]; aux. ferreiro [200%]; ferreiro [500%]; carpinteiro [200%] | 862.4h | 46,439.03 | 16. Casa 16 | 0. Térreo | 2. Estrutura 1 | Própria |  |  |  |
| 825 | 1.6.16.1.4 | 3. Alvenarias | 5d | 2024-05-06 | 2024-05-10 | 817 | 397d | 0d | pedreiro [400%]; servente [400%] | 352h | 8,388.41 | 16. Casa 16 | 0. Térreo | 3. Alvenarias 1 | Própria |  |  |  |
| 826 | 1.6.16.1.5 | 5. Ref. Inter. Arg (Parede) | 3d | 2024-07-25 | 2024-07-29 | 799 | 340d | 0d | pedreiro [600%]; servente [600%] | 316.8h | 5,776 | 16. Casa 16 | 0. Térreo | 5. Ref. Inter. Arg (Parede) 1 | Própria |  |  |  |
| 827 | 1.6.16.1.6 | 6. Revest. Gesso (Parede + Teto) | 3d | 2024-08-05 | 2024-08-07 | 800 | 340d | 0d | gesseiro [400%]; aux. gesseiro [200%] | 158.4h | 2,119.41 | 16. Casa 16 | 0. Térreo | 6. Revest. Gesso (Parede + Teto) 1 | Própria |  |  |  |
| 828 | 1.6.16.1.7 | 7. Impermeabilização | 2d | 2024-09-19 | 2024-09-20 | 818 | 0d |  | aplicador de manta | 17.6h | 3,288.15 | 16. Casa 16 | 0. Térreo | 7. Impermeabilização 1 | Própria |  |  |  |
| 829 | 1.6.16.1.8 | 8. Contrapiso | 2d | 2024-10-01 | 2024-10-02 | 849 | 304d |  | pedreiro [200%]; servente | 52.8h | 3,735.07 | 16. Casa 16 | 0. Térreo | 8. Contrapiso 1 | Própria |  |  |  |
| 830 | 1.6.16.1.9 | 9.1. Chapisco | 0.5d | 2024-10-22 | 2024-10-22 | 803 | 148.5d | 0d | pedreiro [600%]; servente [400%] | 44h | 5,131.51 | 16. Casa 16 | 0. Térreo | 9. Fachada 1 | Própria |  |  |  |
| 831 | 1.6.16.1.10 | 9.2. Emboço | 1.5d | 2024-12-30 | 2024-12-31 | 851 | 242d |  | pedreiro [600%]; servente [400%] | 132h | 7,697.26 | 16. Casa 16 | 0. Térreo | 9. Fachada 1 | Própria |  |  |  |
| 832 | 1.6.16.1.11 | 9.3. Pint. 1 Demão | 1d | 2025-02-12 | 2025-02-13 | 852 | 211.5d |  | pintor [400%]; aux.pintor [200%] | 52.8h | 1,135.92 | 16. Casa 16 | 0. Térreo | 9. Fachada 1 | Própria |  |  |  |
| 833 | 1.6.16.1.12 | 9.4. Pint. 2 Demão | 2d | 2025-05-21 | 2025-05-23 | 853 | 148.5d |  | pintor [400%]; aux.pintor [200%] | 105.6h | 757.28 | 16. Casa 16 | 0. Térreo | 9. Fachada 1 | Própria |  |  |  |
| 834 | 1.6.16.1.13 | 10. Cer. Piso | 4d | 2024-12-03 | 2024-12-06 | 807 | 214d | 0d | pedreiro [400%]; servente [200%] | 211.2h | 25,485.98 | 16. Casa 16 | 0. Térreo | 10. Cer. Piso 1 | Própria | 10 | 10 | 10 |
| 835 | 1.6.16.1.14 | 11. Cer. Parede | 3d | 2025-02-04 | 2025-02-06 | 808 | 214d | 0d | pedreiro [400%]; servente [200%] | 158.4h | 4,238.82 | 16. Casa 16 | 0. Térreo | 11. Cer. Parede 1 | Própria | 11 | 11 | 11 |
| 836 | 1.6.16.1.15 | 12. Forro (WC's e cozinha) | 1d | 2025-03-06 | 2025-03-06 | 809 | 198d | 0d | gesseiro; aux. gesseiro | 17.6h | 635.82 | 16. Casa 16 | 0. Térreo | 12. Forro (WC's e cozinha) 1 | Própria | 12 | 12 | 12 |
| 837 | 1.6.16.1.16 | 13. Esq. Alumínio | 2d | 2025-04-25 | 2025-04-28 | 810 | 164d | 0d | montador esquadrias | 17.6h | 11,307.22 | 16. Casa 16 | 0. Térreo | 13. Esq. Alumínio 1 | Própria | 13 | 13 | 13 |
| 838 | 1.6.16.1.17 | 14. Portas | 2d | 2025-04-29 | 2025-04-30 | 811 | 162d | 0d | marceneiro [200%] | 35.2h | 2,827.85 | 16. Casa 16 | 0. Térreo | 14. Portas 1 | Própria | 14 | 14 | 14 |
| 839 | 1.6.16.1.18 | 15. Pintura (1ª Demão) | 4d | 2025-06-09 | 2025-06-12 | 812 | 82d | 0d | pintor [600%]; aux.pintor [300%] | 316.8h | 3,764.82 | 16. Casa 16 | 0. Térreo | 15. Pintura (1ª Demão) 1 | Própria | 15 | 15 | 15 |
| 840 | 1.6.16.1.19 | 16. Bancadas | 1d | 2025-07-14 | 2025-07-14 | 813 | 113d | 0d | pedreiro [200%]; servente | 26.4h | 10,458.12 | 16. Casa 16 | 0. Térreo | 16. Bancadas 1 | Própria | 16 | 16 | 16 |
| 841 | 1.6.16.1.20 | 17. Pintura (2ª Demão) | 3d | 2025-08-20 | 2025-08-22 | 814 | 82d | 0d | aux.pintor [300%]; pintor [600%] | 237.6h | 1,563.98 | 16. Casa 16 | 0. Térreo | 17. Pintura (2ª Demão) 1 | Própria | 17 | 17 | 17 |
| 842 | 1.6.16.1.21 | 18. Limp. Interna | 1d | 2025-09-19 | 2025-09-19 | 815 | 0d |  | Diarista [200%] | 17.6h | 418.75 | 16. Casa 16 | 0. Térreo | 18. Limp. Interna 1 | Própria | 18 | 18 | 18 |
| 843 | 1.6.16.2 | **1. Pav. Superior** | 358d | 2024-04-17 | 2025-09-22 |  | 64d |  |  | 3256h | 114,879.9 |  |  |  |  |  |  |  |
| 844 | 1.6.16.2.1 | 2. Estrutura | 7d | 2024-04-17 | 2024-04-25 | 824 | 415d | 0d | servente estrutura [300%]; aux. Carpinteiro [200%]; aux. ferreiro [200%]; ferreiro [500%]; carpinteiro [200%] | 862.4h | 30,006.55 | 16. Casa 16 | 1. Pav. Superior | 2. Estrutura 1 | Própria |  |  |  |
| 845 | 1.6.16.2.2 | 3. Alvenarias | 5d | 2024-05-13 | 2024-05-17 | 825 | 397d | 0d | servente [400%]; pedreiro [400%] | 352h | 10,101.74 | 16. Casa 16 | 1. Pav. Superior | 3. Alvenarias 1 | Própria |  |  |  |
| 846 | 1.6.16.2.3 | 5. Ref. Inter. Arg (Parede) | 4d | 2024-07-30 | 2024-08-02 | 826 | 347d |  | pedreiro [600%]; servente [600%] | 422.4h | 5,398.69 | 16. Casa 16 | 1. Pav. Superior | 5. Ref. Inter. Arg (Parede) 1 | Própria |  |  |  |
| 847 | 1.6.16.2.4 | 6. Revest. Gesso (Parede + Teto) | 4d | 2024-08-08 | 2024-08-13 | 827 | 340d |  | aux. gesseiro [200%]; gesseiro [400%] | 211.2h | 2,119.41 | 16. Casa 16 | 1. Pav. Superior | 6. Revest. Gesso (Parede + Teto) 1 | Própria |  |  |  |
| 848 | 1.6.16.2.5 | 7. Impermeabilização | 1d | 2024-09-23 | 2024-09-23 | 828 | 0d |  | gesseiro [300%]; servente | 35.2h | 2,046.85 | 16. Casa 16 | 1. Pav. Superior | 7. Impermeabilização 1 | Própria |  |  |  |
| 849 | 1.6.16.2.6 | 8. Contrapiso | 2d | 2024-09-27 | 2024-09-30 | 848FS+3ed | 0d |  | pedreiro [200%]; servente | 52.8h | 2,476.11 | 16. Casa 16 | 1. Pav. Superior | 8. Contrapiso 1 | Própria |  |  |  |
| 850 | 1.6.16.2.7 | 9.1. Chapisco | 0.5d | 2024-10-22 | 2024-10-22 | 830 | 148.5d | 0d | pedreiro [600%]; servente [400%] | 44h | 5,131.51 | 16. Casa 16 | 1. Pav. Superior | 9. Fachada 1 | Própria |  |  |  |
| 851 | 1.6.16.2.8 | 9.2. Emboço | 1.5d | 2024-12-27 | 2024-12-30 | 784 | 148.5d | 0d | pedreiro [600%]; servente [400%] | 132h | 7,697.26 | 16. Casa 16 | 1. Pav. Superior | 9. Fachada 1 | Própria |  |  |  |
| 852 | 1.6.16.2.9 | 9.3. Pint. 1 Demão | 1d | 2025-02-11 | 2025-02-12 | 785 | 148.5d | 0d | pintor [400%]; aux.pintor [200%] | 52.8h | 1,135.92 | 16. Casa 16 | 1. Pav. Superior | 9. Fachada 1 | Própria |  |  |  |
| 853 | 1.6.16.2.10 | 9.4. Pint. 2 Demão | 2d | 2025-05-19 | 2025-05-21 | 786 | 148.5d | 0d | pintor [400%]; aux.pintor [200%] | 105.6h | 757.28 | 16. Casa 16 | 1. Pav. Superior | 9. Fachada 1 | Própria |  |  |  |
| 854 | 1.6.16.2.11 | 10. Cer. Piso | 4d | 2024-12-09 | 2024-12-12 | 834 | 214d | 0d | pedreiro [400%]; servente [200%] | 211.2h | 19,807.17 | 16. Casa 16 | 1. Pav. Superior | 10. Cer. Piso 1 | Própria | 10 | 10 | 10 |
| 855 | 1.6.16.2.12 | 11. Cer. Parede | 2d | 2025-02-07 | 2025-02-10 | 835 | 214d |  | pedreiro [400%]; servente [200%] | 105.6h | 4,238.82 | 16. Casa 16 | 1. Pav. Superior | 11. Cer. Parede 1 | Própria | 11 | 11 | 11 |
| 856 | 1.6.16.2.13 | 12. Forro (WC's e cozinha) | 1d | 2025-03-07 | 2025-03-07 | 836 | 198d |  | aux. gesseiro; gesseiro | 17.6h | 895 | 16. Casa 16 | 1. Pav. Superior | 12. Forro (WC's e cozinha) 1 | Própria | 12 | 12 | 12 |
| 857 | 1.6.16.2.14 | 13. Esq. Alumínio | 2d | 2025-04-29 | 2025-04-30 | 837 | 164d |  | montador esquadrias | 17.6h | 8,489.61 | 16. Casa 16 | 1. Pav. Superior | 13. Esq. Alumínio 1 | Própria | 13 | 13 | 13 |
| 858 | 1.6.16.2.15 | 14. Portas | 2d | 2025-05-02 | 2025-05-05 | 838 | 162d |  | marceneiro [200%] | 35.2h | 1,858.35 | 16. Casa 16 | 1. Pav. Superior | 14. Portas 1 | Própria | 14 | 14 | 14 |
| 859 | 1.6.16.2.16 | 15. Pintura (1ª Demão) | 4d | 2025-06-13 | 2025-06-18 | 839 | 82d | 0d | pintor [600%]; aux.pintor [300%] | 316.8h | 3,764.82 | 16. Casa 16 | 1. Pav. Superior | 15. Pintura (1ª Demão) 1 | Própria | 15 | 15 | 15 |
| 860 | 1.6.16.2.17 | 16. Bancadas | 1d | 2025-07-15 | 2025-07-15 | 840 | 113d |  | servente; pedreiro [200%] | 26.4h | 6,972.08 | 16. Casa 16 | 1. Pav. Superior | 16. Bancadas 1 | Própria | 16 | 16 | 16 |
| 861 | 1.6.16.2.18 | 17. Pintura (2ª Demão) | 3d | 2025-08-25 | 2025-08-27 | 841 | 82d |  | aux.pintor [300%]; pintor [600%] | 237.6h | 1,563.98 | 16. Casa 16 | 1. Pav. Superior | 17. Pintura (2ª Demão) 1 | Própria | 17 | 17 | 17 |
| 862 | 1.6.16.2.19 | 18. Limp. Interna | 1d | 2025-09-22 | 2025-09-22 | 842 | 0d |  | Diarista [200%] | 17.6h | 418.75 | 16. Casa 16 | 1. Pav. Superior | 18. Limp. Interna 1 | Própria | 18 | 18 | 18 |

| ID | WBS | Task | Duration | Start | Finish | Predecessors | Total slack | Free slack | Resources | Work | Cost | Casa | Pav | Equipe | Empresa | Pacote | LB | Cor |
| --- | --- | --- | --- | --- | --- | --- | --- | --- | --- | --- | --- | --- | --- | --- | --- | --- | --- | --- |
| 863 | 1.6.16.3 | **2. Coberta** | 90d | 2024-05-20 | 2024-09-24 |  | 310d |  |  | 536.8h | 58,163.18 |  |  |  |  |  |  |  |
| 864 | 1.6.16.3.1 | 1. Alvenarias | 3d | 2024-05-20 | 2024-05-22 | 845 | 397d |  | pedreiro [400%]; servente [400%] | 211.2h | 9,834.12 | 16. Casa 16 | 2. Coberta | 3. Alvenarias 1 | Própria |  |  |  |
| 865 | 1.6.16.3.2 | 2. Impermeabilização | 1d | 2024-09-24 | 2024-09-24 | 848 | 310d |  | aplicador de manta | 8.8h | 24,164.53 | 16. Casa 16 | 2. Coberta | 7. Impermeabilização 1 | Própria |  |  |  |
| 866 | 1.6.16.3.3 | 3. Coberta | 6d | 2024-07-08 | 2024-07-15 | 819 | 361d |  | carpinteiro [400%]; aux. Carpinteiro [200%] | 316.8h | 24,164.53 | 16. Casa 16 | 2. Coberta | 4. Coberta 1 | Própria |  |  |  |
| 867 | 1.7 | **Obra Instalações** | 485d | 2023-10-02 | 2025-09-22 |  | 64d |  |  | 11264h | 1,152,793.92 |  |  |  |  |  |  |  |
| 868 | 1.7.1 | **1. Casa 1** | 425d | 2023-10-02 | 2025-06-30 |  | 124d |  |  | 704h | 72,049.62 |  |  |  |  |  |  |  |
| 869 | 1.7.1.1 | **0. Térreo** | 423d | 2023-10-02 | 2025-06-26 |  | 126d |  |  | 334.4h | 47,239.83 |  |  |  |  |  |  |  |
| 870 | 1.7.1.1.1 | 1.Inst. Embut. Em Fundações | 2d | 2023-10-02 | 2023-10-03 | 118SS+5d | 547d |  | bombeiro; eletricista | 35.2h | 1,554.25 | 1. Casa 1 | 0. Térreo | 19. Instalações1 | Própria | 19 | 19 |  |
| 871 | 1.7.1.1.2 | 2.Inst. Elétricas Laje | 2d | 2023-10-13 | 2023-10-16 | 119SS+4d | 539d |  | eletricista; aux. eletricista | 35.2h | 6,661.65 | 1. Casa 1 | 0. Térreo | 20. Elétrica1 | Própria | 20 | 20 |  |
| 872 | 1.7.1.1.3 | 3.Inst. Elétricas Paredes | 2d | 2024-03-07 | 2024-03-11 | 882SF | 446d |  | eletricista; aux. eletricista | 35.2h | 1,704.34 | 1. Casa 1 | 0. Térreo | 20. Elétrica1 | Própria | 21 | 21 |  |
| 873 | 1.7.1.1.4 | 4.Inst. Gás | 2d | 2024-06-25 | 2024-06-27 | 883SF | 374d | 0d | aux. bombeiro; bombeiro | 35.2h | 2,592.32 | 1. Casa 1 | 0. Térreo | 21. HS1 | Própria | 22 | 22 |  |
| 874 | 1.7.1.1.5 | 5.Inst. AF e AQ | 2d | 2024-07-11 | 2024-07-12 | 124 | 296d | 0d | aux. bombeiro; bombeiro | 35.2h | 4,586.31 | 1. Casa 1 | 0. Térreo | 21. HS1 | Própria | 23 | 23 |  |
| 875 | 1.7.1.1.6 | 6.Inst. Esgoto | 2d | 2024-03-20 | 2024-03-22 | 885SF | 438d |  | aux. bombeiro; bombeiro | 35.2h | 2,922.8 | 1. Casa 1 | 0. Térreo | 21. HS1 | Própria | 24 | 24 |  |
| 876 | 1.7.1.1.7 | 7.Fiação | 2d | 2025-01-28 | 2025-01-29 | 133 | 64d | 0d | eletricista; aux. eletricista | 35.2h | 11,873.92 | 1. Casa 1 | 0. Térreo | 20. Elétrica1 | Própria | 25 | 25 |  |
| 877 | 1.7.1.1.8 | 8.Interr. Tom e luminárias | 1d | 2025-05-08 | 2025-05-08 | 1261 | 64d | 0d | eletricista; aux. eletricista | 17.6h | 6,963.62 | 1. Casa 1 | 0. Térreo | 20. Elétrica1 | Própria | 26 | 26 |  |
| 878 | 1.7.1.1.9 | 9.Quadro elétrico | 2d | 2025-06-25 | 2025-06-26 | 1262 | 64d | 0d | eletricista; aux. eletricista | 35.2h | 1,788.87 | 1. Casa 1 | 0. Térreo | 20. Elétrica1 | Própria | 27 | 27 |  |
| 879 | 1.7.1.1.10 | 10.Louças e Metais | 2d | 2025-05-30 | 2025-06-02 | 135 | 80d | 0d | aux. bombeiro; bombeiro | 35.2h | 6,591.75 | 1. Casa 1 | 0. Térreo | 21. HS1 | Própria | 28 | 28 | 10 |
| 880 | 1.7.1.2 | **1. Pav. Superior** | 410d | 2023-10-24 | 2025-06-30 |  | 124d |  |  | 299.2h | 21,866.33 |  |  |  |  |  |  |  |
| 881 | 1.7.1.2.1 | 2.Inst. Elétricas Laje | 2d | 2023-10-24 | 2023-10-25 | 139SS+4d | 532d |  | eletricista; aux. eletricista | 35.2h | 2,995.3 | 1. Casa 1 | 1. Pav. Superior | 20. Elétrica1 | Própria | 20 | 20 |  |
| 882 | 1.7.1.2.2 | 3.Inst. Elétricas Paredes | 2d | 2024-03-11 | 2024-03-13 | 897SF | 444d | 0d | eletricista; aux. eletricista | 35.2h | 766.33 | 1. Casa 1 | 1. Pav. Superior | 20. Elétrica1 | Própria | 21 | 21 |  |
| 883 | 1.7.1.2.3 | 4.Inst. Gás | 2d | 2024-06-27 | 2024-07-01 | 898SF | 372d | 0d | aux. bombeiro; bombeiro | 35.2h | 1,371.29 | 1. Casa 1 | 1. Pav. Superior | 21. HS1 | Própria | 22 | 22 |  |
| 884 | 1.7.1.2.4 | 5.Inst. AF e AQ | 2d | 2024-07-15 | 2024-07-16 | 874 | 296d | 0d | aux. bombeiro; bombeiro | 35.2h | 2,426.07 | 1. Casa 1 | 1. Pav. Superior | 21. HS1 | Própria | 23 | 23 |  |
| 885 | 1.7.1.2.5 | 6.Inst. Esgoto | 2d | 2024-03-22 | 2024-03-27 | 900SF | 436d | 0d | aux. bombeiro; bombeiro | 35.2h | 1,546.11 | 1. Casa 1 | 1. Pav. Superior | 21. HS1 | Própria | 24 | 24 |  |
| 886 | 1.7.1.2.6 | 7.Fiação | 2d | 2025-01-30 | 2025-01-31 | 876 | 64d | 0d | eletricista; aux. eletricista | 35.2h | 5,338.91 | 1. Casa 1 | 1. Pav. Superior | 20. Elétrica1 | Própria | 25 | 25 |  |
| 887 | 1.7.1.2.7 | 8.Interr. Tom e luminárias | 1d | 2025-05-09 | 2025-05-09 | 877 | 64d | 0d | eletricista; aux. eletricista | 17.6h | 3,131.08 | 1. Casa 1 | 1. Pav. Superior | 20. Elétrica1 | Própria | 26 | 26 |  |
| 888 | 1.7.1.2.8 | 9.Quadro elétrico | 2d | 2025-06-27 | 2025-06-30 | 878 | 64d | 0d | eletricista; aux. eletricista | 35.2h | 804.33 | 1. Casa 1 | 1. Pav. Superior | 20. Elétrica1 | Própria | 27 | 27 |  |
| 889 | 1.7.1.2.9 | 10.Louças e Metais | 2d | 2025-06-03 | 2025-06-04 | 879 | 80d | 0d | aux. bombeiro; bombeiro | 35.2h | 3,486.91 | 1. Casa 1 | 1. Pav. Superior | 21. HS1 | Própria | 28 | 28 | 10 |

| ID | WBS | Task | Duration | Start | Finish | Predecessors | Total slack | Free slack | Resources | Work | Cost | Casa | Pav | Pacote | Cor | Equipe | Empresa | LB |
| --- | --- | --- | --- | --- | --- | --- | --- | --- | --- | --- | --- | --- | --- | --- | --- | --- | --- | --- |
| 890 | 1.7.1.3 | **2. Coberta** | 4d | 2024-07-17 | 2024-07-22 |  | 296d |  |  | 70.4h | 2,943.46 |  |  |  |  |  |  |  |
| 891 | 1.7.1.3.1 | Barrilette | 2d | 2024-07-17 | 2024-07-18 | 884 | 296d | 0d | aux. bombeiro; bombeiro | 35.2h | 1,177.38 | 1. Casa 1 | 2. Coberta | 29 | 11 | 21. HS1 | Própria | 29 |
| 892 | 1.7.1.3.2 | Caixa D'água | 2d | 2024-07-19 | 2024-07-22 | 891 | 296d | 0d | aux. bombeiro; bombeiro | 35.2h | 1,766.08 | 1. Casa 1 | 2. Coberta | 30 | 11 | 21. HS1 | Própria | 30 |
| 893 | 1.7.2 | **2. Casa 2** | 420d | 2023-10-16 | 2025-07-04 |  | 120d |  |  | 704h | 72,049.62 |  |  |  |  |  |  |  |
| 894 | 1.7.2.1 | **0. Térreo** | 418d | 2023-10-16 | 2025-07-02 |  | 122d |  |  | 334.4h | 47,239.83 |  |  |  |  |  |  |  |
| 895 | 1.7.2.1.1 | 1.Inst. Embut. Em Fundações | 2d | 2023-10-16 | 2023-10-17 | 165SS+5d | 538d |  | bombeiro; eletricista | 35.2h | 1,554.25 | 2. Casa 2 | 0. Térreo | 19 |  | 19. Instalações1 | Própria | 19 |
| 896 | 1.7.2.1.2 | 2.Inst. Elétricas Laje | 2d | 2023-11-03 | 2023-11-06 | 166SS+4d | 525d |  | eletricista; aux. eletricista | 35.2h | 6,661.65 | 2. Casa 2 | 0. Térreo | 20 |  | 20. Elétrica1 | Própria | 20 |
| 897 | 1.7.2.1.3 | 3.Inst. Elétricas Paredes | 2d | 2024-03-13 | 2024-03-15 | 907SF | 442d | 0d | eletricista; aux. eletricista | 35.2h | 1,704.34 | 2. Casa 2 | 0. Térreo | 21 |  | 20. Elétrica1 | Própria | 21 |
| 898 | 1.7.2.1.4 | 4.Inst. Gás | 2d | 2024-07-01 | 2024-07-03 | 908SF | 370d | 0d | aux. bombeiro; bombeiro | 35.2h | 2,592.32 | 2. Casa 2 | 0. Térreo | 22 |  | 21. HS1 | Própria | 22 |
| 899 | 1.7.2.1.5 | 5.Inst. AF e AQ | 2d | 2024-07-17 | 2024-07-18 | 884 | 300d | 0d | aux. bombeiro; bombeiro | 35.2h | 4,586.31 | 2. Casa 2 | 0. Térreo | 23 |  | 21. HS1 | Própria | 23 |
| 900 | 1.7.2.1.6 | 6.Inst. Esgoto | 2d | 2024-03-27 | 2024-04-01 | 910SF | 434d | 0d | aux. bombeiro; bombeiro | 35.2h | 2,922.8 | 2. Casa 2 | 0. Térreo | 24 |  | 21. HS1 | Própria | 24 |
| 901 | 1.7.2.1.7 | 7.Fiação | 2d | 2025-02-03 | 2025-02-04 | 886 | 64d | 0d | eletricista; aux. eletricista | 35.2h | 11,873.92 | 2. Casa 2 | 0. Térreo | 25 |  | 20. Elétrica1 | Própria | 25 |
| 902 | 1.7.2.1.8 | 8.Interr. Tom e luminárias | 1d | 2025-05-12 | 2025-05-12 | 887 | 64d | 0d | eletricista; aux. eletricista | 17.6h | 6,963.62 | 2. Casa 2 | 0. Térreo | 26 |  | 20. Elétrica1 | Própria | 26 |
| 903 | 1.7.2.1.9 | 9.Quadro elétrico | 2d | 2025-07-01 | 2025-07-02 | 888 | 64d | 0d | eletricista; aux. eletricista | 35.2h | 1,788.87 | 2. Casa 2 | 0. Térreo | 27 |  | 20. Elétrica1 | Própria | 27 |
| 904 | 1.7.2.1.10 | 10.Louças e Metais | 2d | 2025-06-05 | 2025-06-06 | 889 | 80d | 0d | aux. bombeiro; bombeiro | 35.2h | 6,591.75 | 2. Casa 2 | 0. Térreo | 28 | 10 | 21. HS1 | Própria | 28 |
| 905 | 1.7.2.2 | **1. Pav. Superior** | 400d | 2023-11-14 | 2025-07-04 |  | 120d |  |  | 299.2h | 21,866.33 |  |  |  |  |  |  |  |
| 906 | 1.7.2.2.1 | 2.Inst. Elétricas Laje | 2d | 2023-11-14 | 2023-11-16 | 186SS+4d | 518d |  | eletricista; aux. eletricista | 35.2h | 2,995.3 | 2. Casa 2 | 1. Pav. Superior | 20 |  | 20. Elétrica1 | Própria | 20 |
| 907 | 1.7.2.2.2 | 3.Inst. Elétricas Paredes | 2d | 2024-03-15 | 2024-03-20 | 922SF | 440d | 0d | eletricista; aux. eletricista | 35.2h | 766.33 | 2. Casa 2 | 1. Pav. Superior | 21 |  | 20. Elétrica1 | Própria | 21 |
| 908 | 1.7.2.2.3 | 4.Inst. Gás | 2d | 2024-07-03 | 2024-07-05 | 923SF | 368d | 0d | aux. bombeiro; bombeiro | 35.2h | 1,371.29 | 2. Casa 2 | 1. Pav. Superior | 22 |  | 21. HS1 | Própria | 22 |
| 909 | 1.7.2.2.4 | 5.Inst. AF e AQ | 2d | 2024-07-19 | 2024-07-22 | 899 | 300d | 0d | aux. bombeiro; bombeiro | 35.2h | 2,426.07 | 2. Casa 2 | 1. Pav. Superior | 23 |  | 21. HS1 | Própria | 23 |
| 910 | 1.7.2.2.5 | 6.Inst. Esgoto | 2d | 2024-04-01 | 2024-04-03 | 925SF | 432d | 0d | aux. bombeiro; bombeiro | 35.2h | 1,546.11 | 2. Casa 2 | 1. Pav. Superior | 24 |  | 21. HS1 | Própria | 24 |
| 911 | 1.7.2.2.6 | 7.Fiação | 2d | 2025-02-05 | 2025-02-06 | 901 | 64d | 0d | eletricista; aux. eletricista | 35.2h | 5,338.91 | 2. Casa 2 | 1. Pav. Superior | 25 |  | 20. Elétrica1 | Própria | 25 |
| 912 | 1.7.2.2.7 | 8.Interr. Tom e luminárias | 1d | 2025-05-13 | 2025-05-13 | 902 | 64d | 0d | eletricista; aux. eletricista | 17.6h | 3,131.08 | 2. Casa 2 | 1. Pav. Superior | 26 |  | 20. Elétrica1 | Própria | 26 |
| 913 | 1.7.2.2.8 | 9.Quadro elétrico | 2d | 2025-07-03 | 2025-07-04 | 903 | 64d | 0d | eletricista; aux. eletricista | 35.2h | 804.33 | 2. Casa 2 | 1. Pav. Superior | 27 |  | 20. Elétrica1 | Própria | 27 |
| 914 | 1.7.2.2.9 | 10.Louças e Metais | 2d | 2025-06-09 | 2025-06-10 | 904 | 80d | 0d | aux. bombeiro; bombeiro | 35.2h | 3,486.91 | 2. Casa 2 | 1. Pav. Superior | 28 | 10 | 21. HS1 | Própria | 28 |

| ID | WBS | Task | Duration | Start | Finish | Predecessors | Total slack | Free slack | Resources | Work | Cost | Casa | Pav | Pacote | Cor | Equipe | Empresa | LB |
| --- | --- | --- | --- | --- | --- | --- | --- | --- | --- | --- | --- | --- | --- | --- | --- | --- | --- | --- |
| 915 | 1.7.2.3 | **2. Coberta** | 4d | 2024-07-23 | 2024-07-26 |  | 296d |  |  | 70.4h | 2,943.46 |  |  |  |  |  |  |  |
| 916 | 1.7.2.3.1 | Barrilette | 2d | 2024-07-23 | 2024-07-24 | 892 | 296d | 0d | aux. bombeiro; bombeiro | 35.2h | 1,177.38 | 2. Casa 2 | 2. Coberta | 29 | 11 | 21. HS1 | Própria | 29 |
| 917 | 1.7.2.3.2 | Caixa D'água | 2d | 2024-07-25 | 2024-07-26 | 916 | 296d | 0d | aux. bombeiro; bombeiro | 35.2h | 1,766.08 | 2. Casa 2 | 2. Coberta | 30 | 11 | 21. HS1 | Própria | 30 |
| 918 | 1.7.3 | **3. Casa 3** | 415d | 2023-10-27 | 2025-07-10 |  | 116d |  |  | 704h | 72,049.62 |  |  |  |  |  |  |  |
| 919 | 1.7.3.1 | **0. Térreo** | 413d | 2023-10-27 | 2025-07-08 |  | 118d |  |  | 334.4h | 47,239.83 |  |  |  |  |  |  |  |
| 920 | 1.7.3.1.1 | 1.Inst. Embut. Em Fundações | 2d | 2023-10-27 | 2023-10-30 | 212SS+5d | 529d |  | bombeiro; eletricista | 35.2h | 1,554.25 | 3. Casa 3 | 0. Térreo | 19 |  | 19. Instalações1 | Própria | 19 |
| 921 | 1.7.3.1.2 | 2.Inst. Elétricas Laje | 2d | 2023-11-24 | 2023-11-27 | 213SS+4d | 511d |  | eletricista; aux. eletricista | 35.2h | 6,661.65 | 3. Casa 3 | 0. Térreo | 20 |  | 20. Elétrica1 | Própria | 20 |
| 922 | 1.7.3.1.3 | 3.Inst. Elétricas Paredes | 2d | 2024-03-20 | 2024-03-22 | 932SF | 438d | 0d | eletricista; aux. eletricista | 35.2h | 1,704.34 | 3. Casa 3 | 0. Térreo | 21 |  | 20. Elétrica1 | Própria | 21 |
| 923 | 1.7.3.1.4 | 4.Inst. Gás | 2d | 2024-07-05 | 2024-07-09 | 933SF | 366d | 0d | aux. bombeiro; bombeiro | 35.2h | 2,592.32 | 3. Casa 3 | 0. Térreo | 22 |  | 21. HS1 | Própria | 22 |
| 924 | 1.7.3.1.5 | 5.Inst. AF e AQ | 2d | 2024-07-23 | 2024-07-24 | 909 | 300d | 0d | aux. bombeiro; bombeiro | 35.2h | 4,586.31 | 3. Casa 3 | 0. Térreo | 23 |  | 21. HS1 | Própria | 23 |
| 925 | 1.7.3.1.6 | 6.Inst. Esgoto | 2d | 2024-04-03 | 2024-04-05 | 935SF | 430d | 0d | aux. bombeiro; bombeiro | 35.2h | 2,922.8 | 3. Casa 3 | 0. Térreo | 24 |  | 21. HS1 | Própria | 24 |
| 926 | 1.7.3.1.7 | 7.Fiação | 2d | 2025-02-07 | 2025-02-10 | 911 | 64d | 0d | eletricista; aux. eletricista | 35.2h | 11,873.92 | 3. Casa 3 | 0. Térreo | 25 |  | 20. Elétrica1 | Própria | 25 |
| 927 | 1.7.3.1.8 | 8.Interr. Tom e luminárias | 1d | 2025-05-14 | 2025-05-14 | 912 | 64d | 0d | eletricista; aux. eletricista | 17.6h | 6,963.62 | 3. Casa 3 | 0. Térreo | 26 |  | 20. Elétrica1 | Própria | 26 |
| 928 | 1.7.3.1.9 | 9.Quadro elétrico | 2d | 2025-07-07 | 2025-07-08 | 913 | 64d | 0d | eletricista; aux. eletricista | 35.2h | 1,788.87 | 3. Casa 3 | 0. Térreo | 27 |  | 20. Elétrica1 | Própria | 27 |
| 929 | 1.7.3.1.10 | 10.Louças e Metais | 2d | 2025-06-11 | 2025-06-12 | 914 | 80d | 0d | aux. bombeiro; bombeiro | 35.2h | 6,591.75 | 3. Casa 3 | 0. Térreo | 28 | 10 | 21. HS1 | Própria | 28 |
| 930 | 1.7.3.2 | **1. Pav. Superior** | 390d | 2023-12-05 | 2025-07-10 |  | 116d |  |  | 299.2h | 21,866.33 |  |  |  |  |  |  |  |
| 931 | 1.7.3.2.1 | 2.Inst. Elétricas Laje | 2d | 2023-12-05 | 2023-12-06 | 233SS+4d | 504d |  | eletricista; aux. eletricista | 35.2h | 2,995.3 | 3. Casa 3 | 1. Pav. Superior | 20 |  | 20. Elétrica1 | Própria | 20 |
| 932 | 1.7.3.2.2 | 3.Inst. Elétricas Paredes | 2d | 2024-03-22 | 2024-03-27 | 947SF | 436d | 0d | eletricista; aux. eletricista | 35.2h | 766.33 | 3. Casa 3 | 1. Pav. Superior | 21 |  | 20. Elétrica1 | Própria | 21 |
| 933 | 1.7.3.2.3 | 4.Inst. Gás | 2d | 2024-07-09 | 2024-07-11 | 948SF | 364d | 0d | aux. bombeiro; bombeiro | 35.2h | 1,371.29 | 3. Casa 3 | 1. Pav. Superior | 22 |  | 21. HS1 | Própria | 22 |
| 934 | 1.7.3.2.4 | 5.Inst. AF e AQ | 2d | 2024-07-25 | 2024-07-26 | 924 | 300d | 0d | aux. bombeiro; bombeiro | 35.2h | 2,426.07 | 3. Casa 3 | 1. Pav. Superior | 23 |  | 21. HS1 | Própria | 23 |
| 935 | 1.7.3.2.5 | 6.Inst. Esgoto | 2d | 2024-04-05 | 2024-04-09 | 950SF | 428d | 0d | aux. bombeiro; bombeiro | 35.2h | 1,546.11 | 3. Casa 3 | 1. Pav. Superior | 24 |  | 21. HS1 | Própria | 24 |
| 936 | 1.7.3.2.6 | 7.Fiação | 2d | 2025-02-11 | 2025-02-12 | 926 | 64d | 0d | eletricista; aux. eletricista | 35.2h | 5,338.91 | 3. Casa 3 | 1. Pav. Superior | 25 |  | 20. Elétrica1 | Própria | 25 |
| 937 | 1.7.3.2.7 | 8.Interr. Tom e luminárias | 1d | 2025-05-15 | 2025-05-15 | 927 | 64d | 0d | eletricista; aux. eletricista | 17.6h | 3,131.08 | 3. Casa 3 | 1. Pav. Superior | 26 |  | 20. Elétrica1 | Própria | 26 |
| 938 | 1.7.3.2.8 | 9.Quadro elétrico | 2d | 2025-07-09 | 2025-07-10 | 928 | 64d | 0d | eletricista; aux. eletricista | 35.2h | 804.33 | 3. Casa 3 | 1. Pav. Superior | 27 |  | 20. Elétrica1 | Própria | 27 |
| 939 | 1.7.3.2.9 | 10.Louças e Metais | 2d | 2025-06-13 | 2025-06-16 | 929 | 80d | 0d | aux. bombeiro; bombeiro | 35.2h | 3,486.91 | 3. Casa 3 | 1. Pav. Superior | 28 | 10 | 21. HS1 | Própria | 28 |

| ID | WBS | Task | Duration | Start | Finish | Predecessors | Total slack | Free slack | Resources | Work | Cost | Casa | Pav | Pacote | Cor | Equipe | Empresa | LB |
| --- | --- | --- | --- | --- | --- | --- | --- | --- | --- | --- | --- | --- | --- | --- | --- | --- | --- | --- |
| 940 | 1.7.3.3 | **2. Coberta** | 4d | 2024-07-29 | 2024-08-01 |  | 296d |  |  | 70.4h | 2,943.46 |  |  |  |  |  |  |  |
| 941 | 1.7.3.3.1 | Barrilette | 2d | 2024-07-29 | 2024-07-30 | 917 | 296d | 0d | aux. bombeiro; bombeiro | 35.2h | 1,177.38 | 3. Casa 3 | 2. Coberta | 29 | 11 | 21. HS1 | Própria | 29 |
| 942 | 1.7.3.3.2 | Caixa D'água | 2d | 2024-07-31 | 2024-08-01 | 941 | 296d | 0d | aux. bombeiro; bombeiro | 35.2h | 1,766.08 | 3. Casa 3 | 2. Coberta | 30 | 11 | 21. HS1 | Própria | 30 |
| 943 | 1.7.4 | **4. Casa 4** | 410d | 2023-11-10 | 2025-07-16 |  | 112d |  |  | 704h | 72,049.62 |  |  |  |  |  |  |  |
| 944 | 1.7.4.1 | **0. Térreo** | 408d | 2023-11-10 | 2025-07-14 |  | 114d |  |  | 334.4h | 47,239.83 |  |  |  |  |  |  |  |
| 945 | 1.7.4.1.1 | 1.Inst. Embut. Em Fundações | 2d | 2023-11-10 | 2023-11-13 | 259SS+5d | 520d |  | bombeiro; eletricista | 35.2h | 1,554.25 | 4. Casa 4 | 0. Térreo | 19 |  | 19. Instalações1 | Própria | 19 |
| 946 | 1.7.4.1.2 | 2.Inst. Elétricas Laje | 2d | 2023-12-14 | 2023-12-15 | 260SS+4d | 497d |  | eletricista; aux. eletricista | 35.2h | 6,661.65 | 4. Casa 4 | 0. Térreo | 20 |  | 20. Elétrica1 | Própria | 20 |
| 947 | 1.7.4.1.3 | 3.Inst. Elétricas Paredes | 2d | 2024-03-27 | 2024-04-01 | 957SF | 434d | 0d | eletricista; aux. eletricista | 35.2h | 1,704.34 | 4. Casa 4 | 0. Térreo | 21 |  | 20. Elétrica1 | Própria | 21 |
| 948 | 1.7.4.1.4 | 4.Inst. Gás | 2d | 2024-07-11 | 2024-07-15 | 958SF | 362d | 0d | aux. bombeiro; bombeiro | 35.2h | 2,592.32 | 4. Casa 4 | 0. Térreo | 22 |  | 21. HS1 | Própria | 22 |
| 949 | 1.7.4.1.5 | 5.Inst. AF e AQ | 2d | 2024-07-29 | 2024-07-30 | 934 | 300d | 0d | aux. bombeiro; bombeiro | 35.2h | 4,586.31 | 4. Casa 4 | 0. Térreo | 23 |  | 21. HS1 | Própria | 23 |
| 950 | 1.7.4.1.6 | 6.Inst. Esgoto | 2d | 2024-04-09 | 2024-04-11 | 960SF | 426d | 0d | aux. bombeiro; bombeiro | 35.2h | 2,922.8 | 4. Casa 4 | 0. Térreo | 24 |  | 21. HS1 | Própria | 24 |
| 951 | 1.7.4.1.7 | 7.Fiação | 2d | 2025-02-13 | 2025-02-14 | 936 | 64d | 0d | eletricista; aux. eletricista | 35.2h | 11,873.92 | 4. Casa 4 | 0. Térreo | 25 |  | 20. Elétrica1 | Própria | 25 |
| 952 | 1.7.4.1.8 | 8.Interr. Tom e luminárias | 1d | 2025-05-16 | 2025-05-16 | 937 | 64d | 0d | eletricista; aux. eletricista | 17.6h | 6,963.62 | 4. Casa 4 | 0. Térreo | 26 |  | 20. Elétrica1 | Própria | 26 |
| 953 | 1.7.4.1.9 | 9.Quadro elétrico | 2d | 2025-07-11 | 2025-07-14 | 938 | 64d | 0d | eletricista; aux. eletricista | 35.2h | 1,788.87 | 4. Casa 4 | 0. Térreo | 27 |  | 20. Elétrica1 | Própria | 27 |
| 954 | 1.7.4.1.10 | 10.Louças e Metais | 2d | 2025-06-17 | 2025-06-18 | 939 | 80d | 0d | aux. bombeiro; bombeiro | 35.2h | 6,591.75 | 4. Casa 4 | 0. Térreo | 28 | 10 | 21. HS1 | Própria | 28 |
| 955 | 1.7.4.2 | **1. Pav. Superior** | 380d | 2024-01-02 | 2025-07-16 |  | 112d |  |  | 299.2h | 21,866.33 |  |  |  |  |  |  |  |
| 956 | 1.7.4.2.1 | 2.Inst. Elétricas Laje | 2d | 2024-01-02 | 2024-01-03 | 280SS+4d | 490d |  | eletricista; aux. eletricista | 35.2h | 2,995.3 | 4. Casa 4 | 1. Pav. Superior | 20 |  | 20. Elétrica1 | Própria | 20 |
| 957 | 1.7.4.2.2 | 3.Inst. Elétricas Paredes | 2d | 2024-04-01 | 2024-04-03 | 972SF | 432d | 0d | eletricista; aux. eletricista | 35.2h | 766.33 | 4. Casa 4 | 1. Pav. Superior | 21 |  | 20. Elétrica1 | Própria | 21 |
| 958 | 1.7.4.2.3 | 4.Inst. Gás | 2d | 2024-07-15 | 2024-07-17 | 973SF | 360d | 0d | aux. bombeiro; bombeiro | 35.2h | 1,371.29 | 4. Casa 4 | 1. Pav. Superior | 22 |  | 21. HS1 | Própria | 22 |
| 959 | 1.7.4.2.4 | 5.Inst. AF e AQ | 2d | 2024-07-31 | 2024-08-01 | 949 | 300d | 0d | aux. bombeiro; bombeiro | 35.2h | 2,426.07 | 4. Casa 4 | 1. Pav. Superior | 23 |  | 21. HS1 | Própria | 23 |
| 960 | 1.7.4.2.5 | 6.Inst. Esgoto | 2d | 2024-04-11 | 2024-04-15 | 975SF | 424d | 0d | aux. bombeiro; bombeiro | 35.2h | 1,546.11 | 4. Casa 4 | 1. Pav. Superior | 24 |  | 21. HS1 | Própria | 24 |
| 961 | 1.7.4.2.6 | 7.Fiação | 2d | 2025-02-17 | 2025-02-18 | 951 | 64d | 0d | eletricista; aux. eletricista | 35.2h | 5,338.91 | 4. Casa 4 | 1. Pav. Superior | 25 |  | 20. Elétrica1 | Própria | 25 |
| 962 | 1.7.4.2.7 | 8.Interr. Tom e luminárias | 1d | 2025-05-19 | 2025-05-19 | 952 | 64d | 0d | eletricista; aux. eletricista | 17.6h | 3,131.08 | 4. Casa 4 | 1. Pav. Superior | 26 |  | 20. Elétrica1 | Própria | 26 |
| 963 | 1.7.4.2.8 | 9.Quadro elétrico | 2d | 2025-07-15 | 2025-07-16 | 953 | 64d | 0d | eletricista; aux. eletricista | 35.2h | 804.33 | 4. Casa 4 | 1. Pav. Superior | 27 |  | 20. Elétrica1 | Própria | 27 |
| 964 | 1.7.4.2.9 | 10.Louças e Metais | 2d | 2025-06-23 | 2025-06-24 | 954 | 80d | 0d | aux. bombeiro; bombeiro | 35.2h | 3,486.91 | 4. Casa 4 | 1. Pav. Superior | 28 | 10 | 21. HS1 | Própria | 28 |

| ID | WBS | Task | Duration | Start | Finish | Predecessors | Total slack | Free slack | Resources | Work | Cost | Casa | Pav | Pacote | Cor | Equipe | Empresa | LB |
| --- | --- | --- | --- | --- | --- | --- | --- | --- | --- | --- | --- | --- | --- | --- | --- | --- | --- | --- |
| 965 | 1.7.4.3 | **2. Coberta** | 4d | 2024-08-02 | 2024-08-07 |  | 296d |  |  | 70.4h | 2,943.46 |  |  |  |  |  |  |  |
| 966 | 1.7.4.3.1 | Barrilette | 2d | 2024-08-02 | 2024-08-05 | 942 | 296d | 0d | aux. bombeiro; bombeiro | 35.2h | 1,177.38 | 4. Casa 4 | 2. Coberta | 29 | 11 | 21. HS1 | Própria | 29 |
| 967 | 1.7.4.3.2 | Caixa D'água | 2d | 2024-08-06 | 2024-08-07 | 966 | 296d | 0d | aux. bombeiro; bombeiro | 35.2h | 1,766.08 | 4. Casa 4 | 2. Coberta | 30 | 11 | 21. HS1 | Própria | 30 |
| 968 | 1.7.5 | **5. Casa 5** | 405d | 2023-11-24 | 2025-07-22 |  | 108d |  |  | 704h | 72,049.62 |  |  |  |  |  |  |  |
| 969 | 1.7.5.1 | **0. Térreo** | 403d | 2023-11-24 | 2025-07-18 |  | 110d |  |  | 334.4h | 47,239.83 |  |  |  |  |  |  |  |
| 970 | 1.7.5.1.1 | 1.Inst. Embut. Em Fundações | 2d | 2023-11-24 | 2023-11-27 | 306SS+5d | 511d |  | bombeiro; eletricista | 35.2h | 1,554.25 | 5. Casa 5 | 0. Térreo | 19 |  | 19. Instalações1 | Própria | 19 |
| 971 | 1.7.5.1.2 | 2.Inst. Elétricas Laje | 2d | 2024-01-11 | 2024-01-12 | 307SS+4d | 483d |  | eletricista; aux. eletricista | 35.2h | 6,661.65 | 5. Casa 5 | 0. Térreo | 20 |  | 20. Elétrica1 | Própria | 20 |
| 972 | 1.7.5.1.3 | 3.Inst. Elétricas Paredes | 2d | 2024-04-03 | 2024-04-05 | 982SF | 430d | 0d | eletricista; aux. eletricista | 35.2h | 1,704.34 | 5. Casa 5 | 0. Térreo | 21 |  | 20. Elétrica1 | Própria | 21 |
| 973 | 1.7.5.1.4 | 4.Inst. Gás | 2d | 2024-07-17 | 2024-07-19 | 983SF | 358d | 0d | aux. bombeiro; bombeiro | 35.2h | 2,592.32 | 5. Casa 5 | 0. Térreo | 22 |  | 21. HS1 | Própria | 22 |
| 974 | 1.7.5.1.5 | 5.Inst. AF e AQ | 2d | 2024-08-02 | 2024-08-05 | 959 | 300d | 0d | aux. bombeiro; bombeiro | 35.2h | 4,586.31 | 5. Casa 5 | 0. Térreo | 23 |  | 21. HS1 | Própria | 23 |
| 975 | 1.7.5.1.6 | 6.Inst. Esgoto | 2d | 2024-04-15 | 2024-04-17 | 985SF | 422d | 0d | aux. bombeiro; bombeiro | 35.2h | 2,922.8 | 5. Casa 5 | 0. Térreo | 24 |  | 21. HS1 | Própria | 24 |
| 976 | 1.7.5.1.7 | 7.Fiação | 2d | 2025-02-19 | 2025-02-20 | 961 | 64d | 0d | eletricista; aux. eletricista | 35.2h | 11,873.92 | 5. Casa 5 | 0. Térreo | 25 |  | 20. Elétrica1 | Própria | 25 |
| 977 | 1.7.5.1.8 | 8.Interr. Tom e luminárias | 1d | 2025-05-20 | 2025-05-20 | 962 | 64d | 0d | eletricista; aux. eletricista | 17.6h | 6,963.62 | 5. Casa 5 | 0. Térreo | 26 |  | 20. Elétrica1 | Própria | 26 |
| 978 | 1.7.5.1.9 | 9.Quadro elétrico | 2d | 2025-07-17 | 2025-07-18 | 963 | 64d | 0d | eletricista; aux. eletricista | 35.2h | 1,788.87 | 5. Casa 5 | 0. Térreo | 27 |  | 20. Elétrica1 | Própria | 27 |
| 979 | 1.7.5.1.10 | 10.Louças e Metais | 2d | 2025-06-25 | 2025-06-26 | 964 | 80d | 0d | aux. bombeiro; bombeiro | 35.2h | 6,591.75 | 5. Casa 5 | 0. Térreo | 28 | 10 | 21. HS1 | Própria | 28 |
| 980 | 1.7.5.2 | **1. Pav. Superior** | 370d | 2024-01-22 | 2025-07-22 |  | 108d |  |  | 299.2h | 21,866.33 |  |  |  |  |  |  |  |
| 981 | 1.7.5.2.1 | 2.Inst. Elétricas Laje | 2d | 2024-01-22 | 2024-01-23 | 327SS+4d | 476d |  | eletricista; aux. eletricista | 35.2h | 2,995.3 | 5. Casa 5 | 1. Pav. Superior | 20 |  | 20. Elétrica1 | Própria | 20 |
| 982 | 1.7.5.2.2 | 3.Inst. Elétricas Paredes | 2d | 2024-04-05 | 2024-04-09 | 997SF | 428d | 0d | eletricista; aux. eletricista | 35.2h | 766.33 | 5. Casa 5 | 1. Pav. Superior | 21 |  | 20. Elétrica1 | Própria | 21 |
| 983 | 1.7.5.2.3 | 4.Inst. Gás | 2d | 2024-07-19 | 2024-07-23 | 998SF | 356d | 0d | aux. bombeiro; bombeiro | 35.2h | 1,371.29 | 5. Casa 5 | 1. Pav. Superior | 22 |  | 21. HS1 | Própria | 22 |
| 984 | 1.7.5.2.4 | 5.Inst. AF e AQ | 2d | 2024-08-06 | 2024-08-07 | 974 | 300d | 0d | aux. bombeiro; bombeiro | 35.2h | 2,426.07 | 5. Casa 5 | 1. Pav. Superior | 23 |  | 21. HS1 | Própria | 23 |
| 985 | 1.7.5.2.5 | 6.Inst. Esgoto | 2d | 2024-04-17 | 2024-04-19 | 1000SF | 420d | 0d | aux. bombeiro; bombeiro | 35.2h | 1,546.11 | 5. Casa 5 | 1. Pav. Superior | 24 |  | 21. HS1 | Própria | 24 |
| 986 | 1.7.5.2.6 | 7.Fiação | 2d | 2025-02-21 | 2025-02-24 | 976 | 64d | 0d | eletricista; aux. eletricista | 35.2h | 5,338.91 | 5. Casa 5 | 1. Pav. Superior | 25 |  | 20. Elétrica1 | Própria | 25 |
| 987 | 1.7.5.2.7 | 8.Interr. Tom e luminárias | 1d | 2025-05-21 | 2025-05-21 | 977 | 64d | 0d | eletricista; aux. eletricista | 17.6h | 3,131.08 | 5. Casa 5 | 1. Pav. Superior | 26 |  | 20. Elétrica1 | Própria | 26 |
| 988 | 1.7.5.2.8 | 9.Quadro elétrico | 2d | 2025-07-21 | 2025-07-22 | 978 | 64d | 0d | eletricista; aux. eletricista | 35.2h | 804.33 | 5. Casa 5 | 1. Pav. Superior | 27 |  | 20. Elétrica1 | Própria | 27 |
| 989 | 1.7.5.2.9 | 10.Louças e Metais | 2d | 2025-06-27 | 2025-06-30 | 979 | 80d | 0d | aux. bombeiro; bombeiro | 35.2h | 3,486.91 | 5. Casa 5 | 1. Pav. Superior | 28 | 10 | 21. HS1 | Própria | 28 |

| ID | WBS | Task | Duration | Start | Finish | Predecessors | Total slack | Free slack | Resources | Work | Cost | Casa | Pav | Pacote | Cor | Equipe | Empresa | LB |
| --- | --- | --- | --- | --- | --- | --- | --- | --- | --- | --- | --- | --- | --- | --- | --- | --- | --- | --- |
| 990 | 1.7.5.3 | **2. Coberta** | 4d | 2024-08-08 | 2024-08-13 |  | 296d |  |  | 70.4h | 2,943.46 |  |  |  |  |  |  |  |
| 991 | 1.7.5.3.1 | Barrilette | 2d | 2024-08-08 | 2024-08-09 | 967 | 296d | 0d | aux. bombeiro; bombeiro | 35.2h | 1,177.38 | 5. Casa 5 | 2. Coberta | 29 | 11 | 21. HS1 | Própria | 29 |
| 992 | 1.7.5.3.2 | Caixa D'água | 2d | 2024-08-12 | 2024-08-13 | 991 | 296d | 0d | aux. bombeiro; bombeiro | 35.2h | 1,766.08 | 5. Casa 5 | 2. Coberta | 30 | 11 | 21. HS1 | Própria | 30 |
| 993 | 1.7.6 | **6. Casa 6** | 400d | 2023-12-07 | 2025-07-28 |  | 104d |  |  | 704h | 72,049.62 |  |  |  |  |  |  |  |
| 994 | 1.7.6.1 | **0. Térreo** | 398d | 2023-12-07 | 2025-07-24 |  | 106d |  |  | 334.4h | 47,239.83 |  |  |  |  |  |  |  |
| 995 | 1.7.6.1.1 | 1.Inst. Embut. Em Fundações | 2d | 2023-12-07 | 2023-12-08 | 353SS+5d | 502d |  | bombeiro; eletricista | 35.2h | 1,554.25 | 6. Casa 6 | 0. Térreo | 19 |  | 19. Instalações1 | Própria | 19 |
| 996 | 1.7.6.1.2 | 2.Inst. Elétricas Laje | 2d | 2024-01-31 | 2024-02-01 | 354SS+4d | 469d |  | eletricista; aux. eletricista | 35.2h | 6,661.65 | 6. Casa 6 | 0. Térreo | 20 |  | 20. Elétrica1 | Própria | 20 |
| 997 | 1.7.6.1.3 | 3.Inst. Elétricas Paredes | 2d | 2024-04-09 | 2024-04-11 | 1007SF | 426d | 0d | eletricista; aux. eletricista | 35.2h | 1,704.34 | 6. Casa 6 | 0. Térreo | 21 |  | 20. Elétrica1 | Própria | 21 |
| 998 | 1.7.6.1.4 | 4.Inst. Gás | 2d | 2024-07-23 | 2024-07-25 | 1008SF | 354d | 0d | aux. bombeiro; bombeiro | 35.2h | 2,592.32 | 6. Casa 6 | 0. Térreo | 22 |  | 21. HS1 | Própria | 22 |
| 999 | 1.7.6.1.5 | 5.Inst. AF e AQ | 2d | 2024-08-08 | 2024-08-09 | 984 | 300d | 0d | aux. bombeiro; bombeiro | 35.2h | 4,586.31 | 6. Casa 6 | 0. Térreo | 23 |  | 21. HS1 | Própria | 23 |
| 1000 | 1.7.6.1.6 | 6.Inst. Esgoto | 2d | 2024-04-19 | 2024-04-23 | 1010SF | 418d | 0d | aux. bombeiro; bombeiro | 35.2h | 2,922.8 | 6. Casa 6 | 0. Térreo | 24 |  | 21. HS1 | Própria | 24 |
| 1001 | 1.7.6.1.7 | 7.Fiação | 2d | 2025-02-25 | 2025-02-26 | 986 | 64d | 0d | eletricista; aux. eletricista | 35.2h | 11,873.92 | 6. Casa 6 | 0. Térreo | 25 |  | 20. Elétrica1 | Própria | 25 |
| 1002 | 1.7.6.1.8 | 8.Interr. Tom e luminárias | 1d | 2025-05-22 | 2025-05-22 | 987 | 64d | 0d | eletricista; aux. eletricista | 17.6h | 6,963.62 | 6. Casa 6 | 0. Térreo | 26 |  | 20. Elétrica1 | Própria | 26 |
| 1003 | 1.7.6.1.9 | 9.Quadro elétrico | 2d | 2025-07-23 | 2025-07-24 | 988 | 64d | 0d | eletricista; aux. eletricista | 35.2h | 1,788.87 | 6. Casa 6 | 0. Térreo | 27 |  | 20. Elétrica1 | Própria | 27 |
| 1004 | 1.7.6.1.10 | 10.Louças e Metais | 2d | 2025-07-01 | 2025-07-02 | 989 | 80d | 0d | aux. bombeiro; bombeiro | 35.2h | 6,591.75 | 6. Casa 6 | 0. Térreo | 28 | 10 | 21. HS1 | Própria | 28 |
| 1005 | 1.7.6.2 | **1. Pav. Superior** | 360d | 2024-02-09 | 2025-07-28 |  | 104d |  |  | 299.2h | 21,866.33 |  |  |  |  |  |  |  |
| 1006 | 1.7.6.2.1 | 2.Inst. Elétricas Laje | 2d | 2024-02-09 | 2024-02-15 | 374SS+4d | 462d |  | eletricista; aux. eletricista | 35.2h | 2,995.3 | 6. Casa 6 | 1. Pav. Superior | 20 |  | 20. Elétrica1 | Própria | 20 |
| 1007 | 1.7.6.2.2 | 3.Inst. Elétricas Paredes | 2d | 2024-04-11 | 2024-04-15 | 1022SF | 424d | 0d | eletricista; aux. eletricista | 35.2h | 766.33 | 6. Casa 6 | 1. Pav. Superior | 21 |  | 20. Elétrica1 | Própria | 21 |
| 1008 | 1.7.6.2.3 | 4.Inst. Gás | 2d | 2024-07-25 | 2024-07-29 | 1023SF | 352d | 0d | aux. bombeiro; bombeiro | 35.2h | 1,371.29 | 6. Casa 6 | 1. Pav. Superior | 22 |  | 21. HS1 | Própria | 22 |
| 1009 | 1.7.6.2.4 | 5.Inst. AF e AQ | 2d | 2024-08-12 | 2024-08-13 | 999 | 300d | 0d | aux. bombeiro; bombeiro | 35.2h | 2,426.07 | 6. Casa 6 | 1. Pav. Superior | 23 |  | 21. HS1 | Própria | 23 |
| 1010 | 1.7.6.2.5 | 6.Inst. Esgoto | 2d | 2024-04-23 | 2024-04-25 | 1025SF | 416d | 0d | aux. bombeiro; bombeiro | 35.2h | 1,546.11 | 6. Casa 6 | 1. Pav. Superior | 24 |  | 21. HS1 | Própria | 24 |
| 1011 | 1.7.6.2.6 | 7.Fiação | 2d | 2025-02-27 | 2025-02-28 | 1001 | 64d | 0d | eletricista; aux. eletricista | 35.2h | 5,338.91 | 6. Casa 6 | 1. Pav. Superior | 25 |  | 20. Elétrica1 | Própria | 25 |
| 1012 | 1.7.6.2.7 | 8.Interr. Tom e luminárias | 1d | 2025-05-23 | 2025-05-23 | 1002 | 64d | 0d | eletricista; aux. eletricista | 17.6h | 3,131.08 | 6. Casa 6 | 1. Pav. Superior | 26 |  | 20. Elétrica1 | Própria | 26 |
| 1013 | 1.7.6.2.8 | 9.Quadro elétrico | 2d | 2025-07-25 | 2025-07-28 | 1003 | 64d | 0d | eletricista; aux. eletricista | 35.2h | 804.33 | 6. Casa 6 | 1. Pav. Superior | 27 |  | 20. Elétrica1 | Própria | 27 |
| 1014 | 1.7.6.2.9 | 10.Louças e Metais | 2d | 2025-07-03 | 2025-07-04 | 1004 | 80d | 0d | aux. bombeiro; bombeiro | 35.2h | 3,486.91 | 6. Casa 6 | 1. Pav. Superior | 28 | 10 | 21. HS1 | Própria | 28 |

| ID | WBS | Task | Duration | Start | Finish | Predecessors | Total slack | Free slack | Resources | Work | Cost | Casa | Pav | Pacote | Cor | Equipe | Empresa | LB |
| --- | --- | --- | --- | --- | --- | --- | --- | --- | --- | --- | --- | --- | --- | --- | --- | --- | --- | --- |
| 1015 | 1.7.6.3 | **2. Coberta** | 4d | 2024-08-14 | 2024-08-19 |  | 296d |  |  | 70.4h | 2,943.46 |  |  |  |  |  |  |  |
| 1016 | 1.7.6.3.1 | Barrilette | 2d | 2024-08-14 | 2024-08-15 | 992 | 296d | 0d | aux. bombeiro; bombeiro | 35.2h | 1,177.38 | 6. Casa 6 | 2. Coberta | 29 | 11 | 21. HS1 | Própria | 29 |
| 1017 | 1.7.6.3.2 | Caixa D'água | 2d | 2024-08-16 | 2024-08-19 | 1016 | 296d | 0d | aux. bombeiro; bombeiro | 35.2h | 1,766.08 | 6. Casa 6 | 2. Coberta | 30 | 11 | 21. HS1 | Própria | 30 |
| 1018 | 1.7.7 | **7. Casa 7** | 395d | 2023-12-20 | 2025-08-01 |  | 100d |  |  | 704h | 72,049.62 |  |  |  |  |  |  |  |
| 1019 | 1.7.7.1 | **0. Térreo** | 393d | 2023-12-20 | 2025-07-30 |  | 102d |  |  | 334.4h | 47,239.83 |  |  |  |  |  |  |  |
| 1020 | 1.7.7.1.1 | 1.Inst. Embut. Em Fundações | 2d | 2023-12-20 | 2023-12-21 | 400SS+5d | 493d |  | bombeiro; eletricista | 35.2h | 1,554.25 | 7. Casa 7 | 0. Térreo | 19 |  | 19. Instalações1 | Própria | 19 |
| 1021 | 1.7.7.1.2 | 2.Inst. Elétricas Laje | 2d | 2024-02-23 | 2024-02-26 | 401SS+4d | 455d |  | eletricista; aux. eletricista | 35.2h | 6,661.65 | 7. Casa 7 | 0. Térreo | 20 |  | 20. Elétrica1 | Própria | 20 |
| 1022 | 1.7.7.1.3 | 3.Inst. Elétricas Paredes | 2d | 2024-04-15 | 2024-04-17 | 1032SF | 422d | 0d | eletricista; aux. eletricista | 35.2h | 1,704.34 | 7. Casa 7 | 0. Térreo | 21 |  | 20. Elétrica1 | Própria | 21 |
| 1023 | 1.7.7.1.4 | 4.Inst. Gás | 2d | 2024-07-29 | 2024-07-31 | 1033SF | 350d | 0d | aux. bombeiro; bombeiro | 35.2h | 2,592.32 | 7. Casa 7 | 0. Térreo | 22 |  | 21. HS1 | Própria | 22 |
| 1024 | 1.7.7.1.5 | 5.Inst. AF e AQ | 2d | 2024-08-14 | 2024-08-15 | 1009 | 300d | 0d | aux. bombeiro; bombeiro | 35.2h | 4,586.31 | 7. Casa 7 | 0. Térreo | 23 |  | 21. HS1 | Própria | 23 |
| 1025 | 1.7.7.1.6 | 6.Inst. Esgoto | 2d | 2024-04-25 | 2024-04-29 | 1035SF | 414d | 0d | aux. bombeiro; bombeiro | 35.2h | 2,922.8 | 7. Casa 7 | 0. Térreo | 24 |  | 21. HS1 | Própria | 24 |
| 1026 | 1.7.7.1.7 | 7.Fiação | 2d | 2025-03-06 | 2025-03-07 | 1011 | 64d | 0d | eletricista; aux. eletricista | 35.2h | 11,873.92 | 7. Casa 7 | 0. Térreo | 25 |  | 20. Elétrica1 | Própria | 25 |
| 1027 | 1.7.7.1.8 | 8.Interr. Tom e luminárias | 1d | 2025-05-26 | 2025-05-26 | 1012 | 64d | 0d | eletricista; aux. eletricista | 17.6h | 6,963.62 | 7. Casa 7 | 0. Térreo | 26 |  | 20. Elétrica1 | Própria | 26 |
| 1028 | 1.7.7.1.9 | 9.Quadro elétrico | 2d | 2025-07-29 | 2025-07-30 | 1013 | 64d | 0d | eletricista; aux. eletricista | 35.2h | 1,788.87 | 7. Casa 7 | 0. Térreo | 27 |  | 20. Elétrica1 | Própria | 27 |
| 1029 | 1.7.7.1.10 | 10.Louças e Metais | 2d | 2025-07-07 | 2025-07-08 | 1014 | 80d | 0d | aux. bombeiro; bombeiro | 35.2h | 6,591.75 | 7. Casa 7 | 0. Térreo | 28 | 10 | 21. HS1 | Própria | 28 |
| 1030 | 1.7.7.2 | **1. Pav. Superior** | 350d | 2024-03-05 | 2025-08-01 |  | 100d |  |  | 299.2h | 21,866.33 |  |  |  |  |  |  |  |
| 1031 | 1.7.7.2.1 | 2.Inst. Elétricas Laje | 2d | 2024-03-05 | 2024-03-06 | 421SS+4d | 448d |  | eletricista; aux. eletricista | 35.2h | 2,995.3 | 7. Casa 7 | 1. Pav. Superior | 20 |  | 20. Elétrica1 | Própria | 20 |
| 1032 | 1.7.7.2.2 | 3.Inst. Elétricas Paredes | 2d | 2024-04-17 | 2024-04-19 | 1047SF | 420d | 0d | eletricista; aux. eletricista | 35.2h | 766.33 | 7. Casa 7 | 1. Pav. Superior | 21 |  | 20. Elétrica1 | Própria | 21 |
| 1033 | 1.7.7.2.3 | 4.Inst. Gás | 2d | 2024-07-31 | 2024-08-02 | 1048SF | 348d | 0d | aux. bombeiro; bombeiro | 35.2h | 1,371.29 | 7. Casa 7 | 1. Pav. Superior | 22 |  | 21. HS1 | Própria | 22 |
| 1034 | 1.7.7.2.4 | 5.Inst. AF e AQ | 2d | 2024-08-16 | 2024-08-19 | 1024 | 300d | 0d | aux. bombeiro; bombeiro | 35.2h | 2,426.07 | 7. Casa 7 | 1. Pav. Superior | 23 |  | 21. HS1 | Própria | 23 |
| 1035 | 1.7.7.2.5 | 6.Inst. Esgoto | 2d | 2024-04-29 | 2024-05-02 | 1050SF | 412d | 0d | aux. bombeiro; bombeiro | 35.2h | 1,546.11 | 7. Casa 7 | 1. Pav. Superior | 24 |  | 21. HS1 | Própria | 24 |
| 1036 | 1.7.7.2.6 | 7.Fiação | 2d | 2025-03-10 | 2025-03-11 | 1026 | 64d | 0d | eletricista; aux. eletricista | 35.2h | 5,338.91 | 7. Casa 7 | 1. Pav. Superior | 25 |  | 20. Elétrica1 | Própria | 25 |
| 1037 | 1.7.7.2.7 | 8.Interr. Tom e luminárias | 1d | 2025-05-27 | 2025-05-27 | 1027 | 64d | 0d | eletricista; aux. eletricista | 17.6h | 3,131.08 | 7. Casa 7 | 1. Pav. Superior | 26 |  | 20. Elétrica1 | Própria | 26 |
| 1038 | 1.7.7.2.8 | 9.Quadro elétrico | 2d | 2025-07-31 | 2025-08-01 | 1028 | 64d | 0d | eletricista; aux. eletricista | 35.2h | 804.33 | 7. Casa 7 | 1. Pav. Superior | 27 |  | 20. Elétrica1 | Própria | 27 |
| 1039 | 1.7.7.2.9 | 10.Louças e Metais | 2d | 2025-07-09 | 2025-07-10 | 1029 | 80d | 0d | aux. bombeiro; bombeiro | 35.2h | 3,486.91 | 7. Casa 7 | 1. Pav. Superior | 28 | 10 | 21. HS1 | Própria | 28 |

| ID | WBS | Task | Duration | Start | Finish | Predecessors | Total slack | Free slack | Resources | Work | Cost | Casa | Pav | Pacote | Cor | Equipe | Empresa | LB |
| --- | --- | --- | --- | --- | --- | --- | --- | --- | --- | --- | --- | --- | --- | --- | --- | --- | --- | --- |
| 1040 | 1.7.7.3 | **2. Coberta** | 4d | 2024-08-20 | 2024-08-23 |  | 296d |  |  | 70.4h | 2,943.46 |  |  |  |  |  |  |  |
| 1041 | 1.7.7.3.1 | Barrilette | 2d | 2024-08-20 | 2024-08-21 | 1017 | 296d | 0d | aux. bombeiro; bombeiro | 35.2h | 1,177.38 | 7. Casa 7 | 2. Coberta | 29 | 11 | 21. HS1 | Própria | 29 |
| 1042 | 1.7.7.3.2 | Caixa D'água | 2d | 2024-08-22 | 2024-08-23 | 1041 | 296d | 0d | aux. bombeiro; bombeiro | 35.2h | 1,766.08 | 7. Casa 7 | 2. Coberta | 30 | 11 | 21. HS1 | Própria | 30 |
| 1043 | 1.7.8 | **8. Casa 8** | 390d | 2024-01-10 | 2025-08-07 |  | 96d |  |  | 704h | 72,049.62 |  |  |  |  |  |  |  |
| 1044 | 1.7.8.1 | **0. Térreo** | 388d | 2024-01-10 | 2025-08-05 |  | 98d |  |  | 334.4h | 47,239.83 |  |  |  |  |  |  |  |
| 1045 | 1.7.8.1.1 | 1.Inst. Embut. Em Fundações | 2d | 2024-01-10 | 2024-01-11 | 447SS+5d | 484d |  | bombeiro; eletricista | 35.2h | 1,554.25 | 8. Casa 8 | 0. Térreo | 19 |  | 19. Instalações1 | Própria | 19 |
| 1046 | 1.7.8.1.2 | 2.Inst. Elétricas Laje | 2d | 2024-03-14 | 2024-03-15 | 448SS+4d | 441d |  | eletricista; aux. eletricista | 35.2h | 6,661.65 | 8. Casa 8 | 0. Térreo | 20 |  | 20. Elétrica1 | Própria | 20 |
| 1047 | 1.7.8.1.3 | 3.Inst. Elétricas Paredes | 2d | 2024-04-19 | 2024-04-23 | 1057SF | 418d | 0d | eletricista; aux. eletricista | 35.2h | 1,704.34 | 8. Casa 8 | 0. Térreo | 21 |  | 20. Elétrica1 | Própria | 21 |
| 1048 | 1.7.8.1.4 | 4.Inst. Gás | 2d | 2024-08-02 | 2024-08-06 | 1058SF | 346d | 0d | aux. bombeiro; bombeiro | 35.2h | 2,592.32 | 8. Casa 8 | 0. Térreo | 22 |  | 21. HS1 | Própria | 22 |
| 1049 | 1.7.8.1.5 | 5.Inst. AF e AQ | 2d | 2024-08-20 | 2024-08-21 | 1034 | 300d | 0d | aux. bombeiro; bombeiro | 35.2h | 4,586.31 | 8. Casa 8 | 0. Térreo | 23 |  | 21. HS1 | Própria | 23 |
| 1050 | 1.7.8.1.6 | 6.Inst. Esgoto | 2d | 2024-05-02 | 2024-05-06 | 1060SF | 410d | 0d | aux. bombeiro; bombeiro | 35.2h | 2,922.8 | 8. Casa 8 | 0. Térreo | 24 |  | 21. HS1 | Própria | 24 |
| 1051 | 1.7.8.1.7 | 7.Fiação | 2d | 2025-03-12 | 2025-03-13 | 1036 | 64d | 0d | eletricista; aux. eletricista | 35.2h | 11,873.92 | 8. Casa 8 | 0. Térreo | 25 |  | 20. Elétrica1 | Própria | 25 |
| 1052 | 1.7.8.1.8 | 8.Interr. Tom e luminárias | 1d | 2025-05-28 | 2025-05-28 | 1037 | 64d | 0d | eletricista; aux. eletricista | 17.6h | 6,963.62 | 8. Casa 8 | 0. Térreo | 26 |  | 20. Elétrica1 | Própria | 26 |
| 1053 | 1.7.8.1.9 | 9.Quadro elétrico | 2d | 2025-08-04 | 2025-08-05 | 1038 | 64d | 0d | eletricista; aux. eletricista | 35.2h | 1,788.87 | 8. Casa 8 | 0. Térreo | 27 |  | 20. Elétrica1 | Própria | 27 |
| 1054 | 1.7.8.1.10 | 10.Louças e Metais | 2d | 2025-07-11 | 2025-07-14 | 1039 | 80d | 0d | aux. bombeiro; bombeiro | 35.2h | 6,591.75 | 8. Casa 8 | 0. Térreo | 28 | 10 | 21. HS1 | Própria | 28 |
| 1055 | 1.7.8.2 | **1. Pav. Superior** | 340d | 2024-03-27 | 2025-08-07 |  | 96d |  |  | 299.2h | 21,866.33 |  |  |  |  |  |  |  |
| 1056 | 1.7.8.2.1 | 2.Inst. Elétricas Laje | 2d | 2024-03-27 | 2024-03-28 | 468SS+4d | 434d |  | eletricista; aux. eletricista | 35.2h | 2,995.3 | 8. Casa 8 | 1. Pav. Superior | 20 |  | 20. Elétrica1 | Própria | 20 |
| 1057 | 1.7.8.2.2 | 3.Inst. Elétricas Paredes | 2d | 2024-04-23 | 2024-04-24 | 469 | 416d | 0d | eletricista; aux. eletricista | 35.2h | 766.33 | 8. Casa 8 | 1. Pav. Superior | 21 |  | 20. Elétrica1 | Própria | 21 |
| 1058 | 1.7.8.2.3 | 4.Inst. Gás | 2d | 2024-08-06 | 2024-08-08 | 1073SF | 344d | 0d | aux. bombeiro; bombeiro | 35.2h | 1,371.29 | 8. Casa 8 | 1. Pav. Superior | 22 |  | 21. HS1 | Própria | 22 |
| 1059 | 1.7.8.2.4 | 5.Inst. AF e AQ | 2d | 2024-08-22 | 2024-08-23 | 1049 | 300d | 0d | aux. bombeiro; bombeiro | 35.2h | 2,426.07 | 8. Casa 8 | 1. Pav. Superior | 23 |  | 21. HS1 | Própria | 23 |
| 1060 | 1.7.8.2.5 | 6.Inst. Esgoto | 2d | 2024-05-06 | 2024-05-08 | 1075SF | 408d | 0d | aux. bombeiro; bombeiro | 35.2h | 1,546.11 | 8. Casa 8 | 1. Pav. Superior | 24 |  | 21. HS1 | Própria | 24 |
| 1061 | 1.7.8.2.6 | 7.Fiação | 2d | 2025-03-14 | 2025-03-17 | 1051 | 64d | 0d | eletricista; aux. eletricista | 35.2h | 5,338.91 | 8. Casa 8 | 1. Pav. Superior | 25 |  | 20. Elétrica1 | Própria | 25 |
| 1062 | 1.7.8.2.7 | 8.Interr. Tom e luminárias | 1d | 2025-05-29 | 2025-05-29 | 1052 | 64d | 0d | eletricista; aux. eletricista | 17.6h | 3,131.08 | 8. Casa 8 | 1. Pav. Superior | 26 |  | 20. Elétrica1 | Própria | 26 |
| 1063 | 1.7.8.2.8 | 9.Quadro elétrico | 2d | 2025-08-06 | 2025-08-07 | 1053 | 64d | 0d | eletricista; aux. eletricista | 35.2h | 804.33 | 8. Casa 8 | 1. Pav. Superior | 27 |  | 20. Elétrica1 | Própria | 27 |
| 1064 | 1.7.8.2.9 | 10.Louças e Metais | 2d | 2025-07-15 | 2025-07-16 | 1054 | 80d | 0d | aux. bombeiro; bombeiro | 35.2h | 3,486.91 | 8. Casa 8 | 1. Pav. Superior | 28 | 10 | 21. HS1 | Própria | 28 |

| ID | WBS | Task | Duration | Start | Finish | Predecessors | Total slack | Free slack | Resources | Work | Cost | Casa | Pav | Pacote | Cor | Equipe | Empresa | LB |
| --- | --- | --- | --- | --- | --- | --- | --- | --- | --- | --- | --- | --- | --- | --- | --- | --- | --- | --- |
| 1065 | 1.7.8.3 | **2. Coberta** | 4d | 2024-08-26 | 2024-08-29 |  | 296d |  |  | 70.4h | 2,943.46 |  |  |  |  |  |  |  |
| 1066 | 1.7.8.3.1 | Barrilette | 2d | 2024-08-26 | 2024-08-27 | 1042 | 296d | 0d | aux. bombeiro; bombeiro | 35.2h | 1,177.38 | 8. Casa 8 | 2. Coberta | 29 | 11 | 21. HS1 | Própria | 29 |
| 1067 | 1.7.8.3.2 | Caixa D'água | 2d | 2024-08-28 | 2024-08-29 | 1066 | 296d | 0d | aux. bombeiro; bombeiro | 35.2h | 1,766.08 | 8. Casa 8 | 2. Coberta | 30 | 11 | 21. HS1 | Própria | 30 |
| 1068 | 1.7.9 | **9. Casa 9** | 457d | 2023-10-02 | 2025-08-13 |  | 92d |  |  | 704h | 72,049.62 |  |  |  |  |  |  |  |
| 1069 | 1.7.9.1 | **0. Térreo** | 455d | 2023-10-02 | 2025-08-11 |  | 94d |  |  | 334.4h | 47,239.83 |  |  |  |  |  |  |  |
| 1070 | 1.7.9.1.1 | 1.Inst. Embut. Em Fundações | 2d | 2023-10-02 | 2023-10-03 | 494SS+5d | 547d |  | bombeiro; eletricista | 35.2h | 1,554.25 | 9. Casa 9 | 0. Térreo | 19 |  | 19. Instalações1 | Própria | 19 |
| 1071 | 1.7.9.1.2 | 2.Inst. Elétricas Laje | 2d | 2023-11-09 | 2023-11-10 | 495SS+4d | 521d |  | eletricista; aux. eletricista | 35.2h | 6,661.65 | 9. Casa 9 | 0. Térreo | 20 |  | 20. Elétrica1 | Própria | 20 |
| 1072 | 1.7.9.1.3 | 3.Inst. Elétricas Paredes | 2d | 2024-04-05 | 2024-04-09 | 1082SF | 428d |  | eletricista; aux. eletricista | 35.2h | 1,704.34 | 9. Casa 9 | 0. Térreo | 21 |  | 20. Elétrica1 | Própria | 21 |
| 1073 | 1.7.9.1.4 | 4.Inst. Gás | 2d | 2024-08-08 | 2024-08-12 | 1083SF | 342d | 0d | aux. bombeiro; bombeiro | 35.2h | 2,592.32 | 9. Casa 9 | 0. Térreo | 22 |  | 21. HS1 | Própria | 22 |
| 1074 | 1.7.9.1.5 | 5.Inst. AF e AQ | 2d | 2024-08-26 | 2024-08-27 | 1059 | 300d | 0d | aux. bombeiro; bombeiro | 35.2h | 4,586.31 | 9. Casa 9 | 0. Térreo | 23 |  | 21. HS1 | Própria | 23 |
| 1075 | 1.7.9.1.6 | 6.Inst. Esgoto | 2d | 2024-05-08 | 2024-05-10 | 1085SF | 406d | 0d | aux. bombeiro; bombeiro | 35.2h | 2,922.8 | 9. Casa 9 | 0. Térreo | 24 |  | 21. HS1 | Própria | 24 |
| 1076 | 1.7.9.1.7 | 7.Fiação | 2d | 2025-03-18 | 2025-03-20 | 1061 | 64d | 0d | eletricista; aux. eletricista | 35.2h | 11,873.92 | 9. Casa 9 | 0. Térreo | 25 |  | 20. Elétrica1 | Própria | 25 |
| 1077 | 1.7.9.1.8 | 8.Interr. Tom e luminárias | 1d | 2025-05-30 | 2025-05-30 | 1062 | 64d | 0d | eletricista; aux. eletricista | 17.6h | 6,963.62 | 9. Casa 9 | 0. Térreo | 26 |  | 20. Elétrica1 | Própria | 26 |
| 1078 | 1.7.9.1.9 | 9.Quadro elétrico | 2d | 2025-08-08 | 2025-08-11 | 1063 | 64d | 0d | eletricista; aux. eletricista | 35.2h | 1,788.87 | 9. Casa 9 | 0. Térreo | 27 |  | 20. Elétrica1 | Própria | 27 |
| 1079 | 1.7.9.1.10 | 10.Louças e Metais | 2d | 2025-07-17 | 2025-07-18 | 1064 | 80d | 0d | aux. bombeiro; bombeiro | 35.2h | 6,591.75 | 9. Casa 9 | 0. Térreo | 28 | 10 | 21. HS1 | Própria | 28 |
| 1080 | 1.7.9.2 | **1. Pav. Superior** | 424d | 2023-11-21 | 2025-08-13 |  | 92d |  |  | 299.2h | 21,866.33 |  |  |  |  |  |  |  |
| 1081 | 1.7.9.2.1 | 2.Inst. Elétricas Laje | 2d | 2023-11-21 | 2023-11-22 | 515SS+4d | 514d |  | eletricista; aux. eletricista | 35.2h | 2,995.3 | 9. Casa 9 | 1. Pav. Superior | 20 |  | 20. Elétrica1 | Própria | 20 |
| 1082 | 1.7.9.2.2 | 3.Inst. Elétricas Paredes | 2d | 2024-04-09 | 2024-04-11 | 1097SF | 426d | 0d | eletricista; aux. eletricista | 35.2h | 766.33 | 9. Casa 9 | 1. Pav. Superior | 21 |  | 20. Elétrica1 | Própria | 21 |
| 1083 | 1.7.9.2.3 | 4.Inst. Gás | 2d | 2024-08-12 | 2024-08-14 | 1098SF | 340d | 0d | aux. bombeiro; bombeiro | 35.2h | 1,371.29 | 9. Casa 9 | 1. Pav. Superior | 22 |  | 21. HS1 | Própria | 22 |
| 1084 | 1.7.9.2.4 | 5.Inst. AF e AQ | 2d | 2024-08-28 | 2024-08-29 | 1074 | 300d | 0d | aux. bombeiro; bombeiro | 35.2h | 2,426.07 | 9. Casa 9 | 1. Pav. Superior | 23 |  | 21. HS1 | Própria | 23 |
| 1085 | 1.7.9.2.5 | 6.Inst. Esgoto | 2d | 2024-05-10 | 2024-05-14 | 1100SF | 404d | 0d | aux. bombeiro; bombeiro | 35.2h | 1,546.11 | 9. Casa 9 | 1. Pav. Superior | 24 |  | 21. HS1 | Própria | 24 |
| 1086 | 1.7.9.2.6 | 7.Fiação | 2d | 2025-03-21 | 2025-03-24 | 1076 | 64d | 0d | eletricista; aux. eletricista | 35.2h | 5,338.91 | 9. Casa 9 | 1. Pav. Superior | 25 |  | 20. Elétrica1 | Própria | 25 |
| 1087 | 1.7.9.2.7 | 8.Interr. Tom e luminárias | 1d | 2025-06-02 | 2025-06-02 | 1077 | 64d | 0d | eletricista; aux. eletricista | 17.6h | 3,131.08 | 9. Casa 9 | 1. Pav. Superior | 26 |  | 20. Elétrica1 | Própria | 26 |
| 1088 | 1.7.9.2.8 | 9.Quadro elétrico | 2d | 2025-08-12 | 2025-08-13 | 1078 | 64d | 0d | eletricista; aux. eletricista | 35.2h | 804.33 | 9. Casa 9 | 1. Pav. Superior | 27 |  | 20. Elétrica1 | Própria | 27 |
| 1089 | 1.7.9.2.9 | 10.Louças e Metais | 2d | 2025-07-21 | 2025-07-22 | 1079 | 80d | 0d | aux. bombeiro; bombeiro | 35.2h | 3,486.91 | 9. Casa 9 | 1. Pav. Superior | 28 | 10 | 21. HS1 | Própria | 28 |

| ID | WBS | Task | Duration | Start | Finish | Predecessors | Total slack | Free slack | Resources | Work | Cost | Casa | Pav | Pacote | Cor | Equipe | Empresa | LB |
| --- | --- | --- | --- | --- | --- | --- | --- | --- | --- | --- | --- | --- | --- | --- | --- | --- | --- | --- |
| 1090 | 1.7.9.3 | **2. Coberta** | 4d | 2024-08-30 | 2024-09-04 |  | 296d |  |  | 70.4h | 2,943.46 |  |  |  |  |  |  |  |
| 1091 | 1.7.9.3.1 | Barrilette | 2d | 2024-08-30 | 2024-09-02 | 1067 | 296d | 0d | aux. bombeiro; bombeiro | 35.2h | 1,177.38 | 9. Casa 9 | 2. Coberta | 29 | 11 | 21. HS1 | Própria | 29 |
| 1092 | 1.7.9.3.2 | Caixa D'água | 2d | 2024-09-03 | 2024-09-04 | 1091 | 296d | 0d | aux. bombeiro; bombeiro | 35.2h | 1,766.08 | 9. Casa 9 | 2. Coberta | 30 | 11 | 21. HS1 | Própria | 30 |
| 1093 | 1.7.10 | **10. Casa 10** | 452d | 2023-10-16 | 2025-08-19 |  | 88d |  |  | 704h | 72,049.62 |  |  |  |  |  |  |  |
| 1094 | 1.7.10.1 | **0. Térreo** | 450d | 2023-10-16 | 2025-08-15 |  | 90d |  |  | 334.4h | 47,239.83 |  |  |  |  |  |  |  |
| 1095 | 1.7.10.1.1 | 1.Inst. Embut. Em Fundações | 2d | 2023-10-16 | 2023-10-17 | 541SS+5d | 538d |  | bombeiro; eletricista | 35.2h | 1,554.25 | 10. Casa 10 | 0. Térreo | 19 |  | 19. Instalações1 | Própria | 19 |
| 1096 | 1.7.10.1.2 | 2.Inst. Elétricas Laje | 2d | 2023-11-30 | 2023-12-01 | 542SS+4d | 507d |  | eletricista; aux. eletricista | 35.2h | 6,661.65 | 10. Casa 10 | 0. Térreo | 20 |  | 20. Elétrica1 | Própria | 20 |
| 1097 | 1.7.10.1.3 | 3.Inst. Elétricas Paredes | 2d | 2024-04-11 | 2024-04-15 | 1107SF | 424d | 0d | eletricista; aux. eletricista | 35.2h | 1,704.34 | 10. Casa 10 | 0. Térreo | 21 |  | 20. Elétrica1 | Própria | 21 |
| 1098 | 1.7.10.1.4 | 4.Inst. Gás | 2d | 2024-08-14 | 2024-08-16 | 1108SF | 338d | 0d | aux. bombeiro; bombeiro | 35.2h | 2,592.32 | 10. Casa 10 | 0. Térreo | 22 |  | 21. HS1 | Própria | 22 |
| 1099 | 1.7.10.1.5 | 5.Inst. AF e AQ | 2d | 2024-08-30 | 2024-09-02 | 1084 | 300d | 0d | aux. bombeiro; bombeiro | 35.2h | 4,586.31 | 10. Casa 10 | 0. Térreo | 23 |  | 21. HS1 | Própria | 23 |
| 1100 | 1.7.10.1.6 | 6.Inst. Esgoto | 2d | 2024-05-14 | 2024-05-16 | 1110SF | 402d | 0d | aux. bombeiro; bombeiro | 35.2h | 2,922.8 | 1 0. Casa 10 | 0. Térreo | 24 |  | 21. HS1 | Própria | 24 |
| 1101 | 1.7.10.1.7 | 7.Fiação | 2d | 2025-03-26 | 2025-03-27 | 1086 | 64d | 0d | eletricista; aux. eletricista | 35.2h | 11,873.92 | 10. Casa 10 | 0. Térreo | 25 |  | 20. Elétrica1 | Própria | 25 |
| 1102 | 1.7.10.1.8 | 8.Interr. Tom e luminárias | 1d | 2025-06-03 | 2025-06-03 | 1087 | 64d | 0d | eletricista; aux. eletricista | 17.6h | 6,963.62 | 10. Casa 10 | 0. Térreo | 26 |  | 20. Elétrica1 | Própria | 26 |
| 1103 | 1.7.10.1.9 | 9.Quadro elétrico | 2d | 2025-08-14 | 2025-08-15 | 1088 | 64d | 0d | eletricista; aux. eletricista | 35.2h | 1,788.87 | 10. Casa 10 | 0. Térreo | 27 |  | 20. Elétrica1 | Própria | 27 |
| 1104 | 1.7.10.1.10 | 10.Louças e Metais | 2d | 2025-07-23 | 2025-07-24 | 1089 | 80d | 0d | aux. bombeiro; bombeiro | 35.2h | 6,591.75 | 10. Casa 10 | 0. Térreo | 28 | 10 | 21. HS1 | Própria | 28 |
| 1105 | 1.7.10.2 | **1. Pav. Superior** | 414d | 2023-12-11 | 2025-08-19 |  | 88d |  |  | 299.2h | 21,866.33 |  |  |  |  |  |  |  |
| 1106 | 1.7.10.2.1 | 2.Inst. Elétricas Laje | 2d | 2023-12-11 | 2023-12-12 | 562SS+4d | 500d |  | eletricista; aux. eletricista | 35.2h | 2,995.3 | 10. Casa 10 | 1. Pav. Superior | 20 |  | 20. Elétrica1 | Própria | 20 |
| 1107 | 1.7.10.2.2 | 3.Inst. Elétricas Paredes | 2d | 2024-04-15 | 2024-04-17 | 1122SF | 422d | 0d | eletricista; aux. eletricista | 35.2h | 766.33 | 10. Casa 10 | 1. Pav. Superior | 21 |  | 20. Elétrica1 | Própria | 21 |
| 1108 | 1.7.10.2.3 | 4.Inst. Gás | 2d | 2024-08-16 | 2024-08-20 | 1123SF | 336d | 0d | aux. bombeiro; bombeiro | 35.2h | 1,371.29 | 10. Casa 10 | 1. Pav. Superior | 22 |  | 21. HS1 | Própria | 22 |
| 1109 | 1.7.10.2.4 | 5.Inst. AF e AQ | 2d | 2024-09-03 | 2024-09-04 | 1099 | 300d | 0d | aux. bombeiro; bombeiro | 35.2h | 2,426.07 | 10. Casa 10 | 1. Pav. Superior | 23 |  | 21. HS1 | Própria | 23 |
| 1110 | 1.7.10.2.5 | 6.Inst. Esgoto | 2d | 2024-05-16 | 2024-05-20 | 1125SF | 400d | 0d | aux. bombeiro; bombeiro | 35.2h | 1,546.11 | 10. Casa 10 | 1. Pav. Superior | 24 |  | 21. HS1 | Própria | 24 |
| 1111 | 1.7.10.2.6 | 7.Fiação | 2d | 2025-03-28 | 2025-03-31 | 1101 | 64d | 0d | eletricista; aux. eletricista | 35.2h | 5,338.91 | 10. Casa 10 | 1. Pav. Superior | 25 |  | 20. Elétrica1 | Própria | 25 |
| 1112 | 1.7.10.2.7 | 8.Interr. Tom e luminárias | 1d | 2025-06-04 | 2025-06-04 | 1102 | 64d | 0d | eletricista; aux. eletricista | 17.6h | 3,131.08 | 10. Casa 10 | 1. Pav. Superior | 26 |  | 20. Elétrica1 | Própria | 26 |
| 1113 | 1.7.10.2.8 | 9.Quadro elétrico | 2d | 2025-08-18 | 2025-08-19 | 1103 | 64d | 0d | eletricista; aux. eletricista | 35.2h | 804.33 | 10. Casa 10 | 1. Pav. Superior | 27 |  | 20. Elétrica1 | Própria | 27 |
| 1114 | 1.7.10.2.9 | 10.Louças e Metais | 2d | 2025-07-25 | 2025-07-28 | 1104 | 80d | 0d | aux. bombeiro; bombeiro | 35.2h | 3,486.91 | 10. Casa 10 | 1. Pav. Superior | 28 | 10 | 21. HS1 | Própria | 28 |

| ID | WBS | Task | Duration | Start | Finish | Predecessors | Total slack | Free slack | Resources | Work | Cost | Casa | Pav | Pacote | Cor | Equipe | Empresa | LB |
| --- | --- | --- | --- | --- | --- | --- | --- | --- | --- | --- | --- | --- | --- | --- | --- | --- | --- | --- |
| 1115 | 1.7.10.3 | **2. Coberta** | 4d | 2024-09-05 | 2024-09-10 |  | 296d |  |  | 70.4h | 2,943.46 |  |  |  |  |  |  |  |
| 1116 | 1.7.10.3.1 | Barrilette | 2d | 2024-09-05 | 2024-09-06 | 1092 | 296d | 0d | aux. bombeiro; bombeiro | 35.2h | 1,177.38 | 10. Casa 10 | 2. Coberta | 29 | 11 | 21. HS1 | Própria | 29 |
| 1117 | 1.7.10.3.2 | Caixa D'água | 2d | 2024-09-09 | 2024-09-10 | 1116 | 296d | 0d | aux. bombeiro; bombeiro | 35.2h | 1,766.08 | 10. Casa 10 | 2. Coberta | 30 | 11 | 21. HS1 | Própria | 30 |
| 1118 | 1.7.11 | **11. Casa 11** | 447d | 2023-10-27 | 2025-08-25 |  | 84d |  |  | 704h | 72,049.62 |  |  |  |  |  |  |  |
| 1119 | 1.7.11.1 | **0. Térreo** | 445d | 2023-10-27 | 2025-08-21 |  | 86d |  |  | 334.4h | 47,239.83 |  |  |  |  |  |  |  |
| 1120 | 1.7.11.1.1 | 1.Inst. Embut. Em Fundações | 2d | 2023-10-27 | 2023-10-30 | 588SS+5d | 529d |  | bombeiro; eletricista | 35.2h | 1,554.25 | 11. Casa 11 | 0. Térreo | 19 |  | 19. Instalações1 | Própria | 19 |
| 1121 | 1.7.11.1.2 | 2.Inst. Elétricas Laje | 2d | 2023-12-20 | 2023-12-21 | 589SS+4d | 493d |  | eletricista; aux. eletricista | 35.2h | 6,661.65 | 11. Casa 11 | 0. Térreo | 20 |  | 20. Elétrica1 | Própria | 20 |
| 1122 | 1.7.11.1.3 | 3.Inst. Elétricas Paredes | 2d | 2024-04-17 | 2024-04-19 | 1132SF | 420d | 0d | eletricista; aux. eletricista | 35.2h | 1,704.34 | 11. Casa 11 | 0. Térreo | 21 |  | 20. Elétrica1 | Própria | 21 |
| 1123 | 1.7.11.1.4 | 4.Inst. Gás | 2d | 2024-08-20 | 2024-08-22 | 1133SF | 334d | 0d | aux. bombeiro; bombeiro | 35.2h | 2,592.32 | 11. Casa 11 | 0. Térreo | 22 |  | 21. HS1 | Própria | 22 |
| 1124 | 1.7.11.1.5 | 5.Inst. AF e AQ | 2d | 2024-09-05 | 2024-09-06 | 1109 | 300d | 0d | aux. bombeiro; bombeiro | 35.2h | 4,586.31 | 11. Casa 11 | 0. Térreo | 23 |  | 21. HS1 | Própria | 23 |
| 1125 | 1.7.11.1.6 | 6.Inst. Esgoto | 2d | 2024-05-20 | 2024-05-22 | 1135SF | 398d | 0d | aux. bombeiro; bombeiro | 35.2h | 2,922.8 | 11. Casa 11 | 0. Térreo | 24 |  | 21. HS1 | Própria | 24 |
| 1126 | 1.7.11.1.7 | 7.Fiação | 2d | 2025-04-01 | 2025-04-02 | 1111 | 64d | 0d | eletricista; aux. eletricista | 35.2h | 11,873.92 | 11. Casa 11 | 0. Térreo | 25 |  | 20. Elétrica1 | Própria | 25 |
| 1127 | 1.7.11.1.8 | 8.Interr. Tom e luminárias | 1d | 2025-06-05 | 2025-06-05 | 1112 | 64d | 0d | eletricista; aux. eletricista | 17.6h | 6,963.62 | 11. Casa 11 | 0. Térreo | 26 |  | 20. Elétrica1 | Própria | 26 |
| 1128 | 1.7.11.1.9 | 9.Quadro elétrico | 2d | 2025-08-20 | 2025-08-21 | 1113 | 64d | 0d | eletricista; aux. eletricista | 35.2h | 1,788.87 | 11. Casa 11 | 0. Térreo | 27 |  | 20. Elétrica1 | Própria | 27 |
| 1129 | 1.7.11.1.10 | 10.Louças e Metais | 2d | 2025-07-29 | 2025-07-30 | 1114 | 80d | 0d | aux. bombeiro; bombeiro | 35.2h | 6,591.75 | 11. Casa 11 | 0. Térreo | 28 | 10 | 21. HS1 | Própria | 28 |
| 1130 | 1.7.11.2 | **1. Pav. Superior** | 404d | 2024-01-08 | 2025-08-25 |  | 84d |  |  | 299.2h | 21,866.33 |  |  |  |  |  |  |  |
| 1131 | 1.7.11.2.1 | 2.Inst. Elétricas Laje | 2d | 2024-01-08 | 2024-01-09 | 609SS+4d | 486d |  | eletricista; aux. eletricista | 35.2h | 2,995.3 | 11. Casa 11 | 1. Pav. Superior | 20 |  | 20. Elétrica1 | Própria | 20 |
| 1132 | 1.7.11.2.2 | 3.Inst. Elétricas Paredes | 2d | 2024-04-19 | 2024-04-23 | 1147SF | 418d | 0d | eletricista; aux. eletricista | 35.2h | 766.33 | 11. Casa 11 | 1. Pav. Superior | 21 |  | 20. Elétrica1 | Própria | 21 |
| 1133 | 1.7.11.2.3 | 4.Inst. Gás | 2d | 2024-08-22 | 2024-08-26 | 1148SF | 332d | 0d | aux. bombeiro; bombeiro | 35.2h | 1,371.29 | 11. Casa 11 | 1. Pav. Superior | 22 |  | 21. HS1 | Própria | 22 |
| 1134 | 1.7.11.2.4 | 5.Inst. AF e AQ | 2d | 2024-09-09 | 2024-09-10 | 1124 | 300d | 0d | aux. bombeiro; bombeiro | 35.2h | 2,426.07 | 11. Casa 11 | 1. Pav. Superior | 23 |  | 21. HS1 | Própria | 23 |
| 1135 | 1.7.11.2.5 | 6.Inst. Esgoto | 2d | 2024-05-22 | 2024-05-24 | 1150SF | 396d | 0d | aux. bombeiro; bombeiro | 35.2h | 1,546.11 | 11. Casa 11 | 1. Pav. Superior | 24 |  | 21. HS1 | Própria | 24 |
| 1136 | 1.7.11.2.6 | 7.Fiação | 2d | 2025-04-03 | 2025-04-04 | 1126 | 64d | 0d | eletricista; aux. eletricista | 35.2h | 5,338.91 | 11. Casa 11 | 1. Pav. Superior | 25 |  | 20. Elétrica1 | Própria | 25 |
| 1137 | 1.7.11.2.7 | 8.Interr. Tom e luminárias | 1d | 2025-06-06 | 2025-06-06 | 1127 | 64d | 0d | eletricista; aux. eletricista | 17.6h | 3,131.08 | 11. Casa 11 | 1. Pav. Superior | 26 |  | 20. Elétrica1 | Própria | 26 |
| 1138 | 1.7.11.2.8 | 9.Quadro elétrico | 2d | 2025-08-22 | 2025-08-25 | 1128 | 64d | 0d | eletricista; aux. eletricista | 35.2h | 804.33 | 11. Casa 11 | 1. Pav. Superior | 27 |  | 20. Elétrica1 | Própria | 27 |
| 1139 | 1.7.11.2.9 | 10.Louças e Metais | 2d | 2025-07-31 | 2025-08-01 | 1129 | 80d | 0d | aux. bombeiro; bombeiro | 35.2h | 3,486.91 | 11. Casa 11 | 1. Pav. Superior | 28 | 10 | 21. HS1 | Própria | 28 |

| ID | WBS | Task | Duration | Start | Finish | Predecessors | Total slack | Free slack | Resources | Work | Cost | Casa | Pav | Pacote | Cor | Equipe | Empresa | LB |
| --- | --- | --- | --- | --- | --- | --- | --- | --- | --- | --- | --- | --- | --- | --- | --- | --- | --- | --- |
| 1140 | 1.7.11.3 | **2. Coberta** | 4d | 2024-09-11 | 2024-09-16 |  | 296d |  |  | 70.4h | 2,943.46 |  |  |  |  |  |  |  |
| 1141 | 1.7.11.3.1 | Barrilette | 2d | 2024-09-11 | 2024-09-12 | 1117 | 296d | 0d | aux. bombeiro; bombeiro | 35.2h | 1,177.38 | 11. Casa 11 | 2. Coberta | 29 | 11 | 21. HS1 | Própria | 29 |
| 1142 | 1.7.11.3.2 | Caixa D'água | 2d | 2024-09-13 | 2024-09-16 | 1141 | 296d | 0d | aux. bombeiro; bombeiro | 35.2h | 1,766.08 | 11. Casa 11 | 2. Coberta | 30 | 11 | 21. HS1 | Própria | 30 |
| 1143 | 1.7.12 | **12. Casa 12** | 442d | 2023-11-10 | 2025-08-29 |  | 80d |  |  | 704h | 72,049.62 |  |  |  |  |  |  |  |
| 1144 | 1.7.12.1 | **0. Térreo** | 440d | 2023-11-10 | 2025-08-27 |  | 82d |  |  | 334.4h | 47,239.83 |  |  |  |  |  |  |  |
| 1145 | 1.7.12.1.1 | 1.Inst. Embut. Em Fundações | 2d | 2023-11-10 | 2023-11-13 | 635SS+5d | 520d |  | bombeiro; eletricista | 35.2h | 1,554.25 | 12. Casa 12 | 0. Térreo | 19 |  | 19. Instalações1 | Própria | 19 |
| 1146 | 1.7.12.1.2 | 2.Inst. Elétricas Laje | 2d | 2024-01-17 | 2024-01-18 | 636SS+4d | 479d |  | eletricista; aux. eletricista | 35.2h | 6,661.65 | 12. Casa 12 | 0. Térreo | 20 |  | 20. Elétrica1 | Própria | 20 |
| 1147 | 1.7.12.1.3 | 3.Inst. Elétricas Paredes | 2d | 2024-04-23 | 2024-04-25 | 1157SF | 416d | 0d | eletricista; aux. eletricista | 35.2h | 1,704.34 | 12. Casa 12 | 0. Térreo | 21 |  | 20. Elétrica1 | Própria | 21 |
| 1148 | 1.7.12.1.4 | 4.Inst. Gás | 2d | 2024-08-26 | 2024-08-28 | 1158SF | 330d | 0d | aux. bombeiro; bombeiro | 35.2h | 2,592.32 | 12. Casa 12 | 0. Térreo | 22 |  | 21. HS1 | Própria | 22 |
| 1149 | 1.7.12.1.5 | 5.Inst. AF e AQ | 2d | 2024-09-11 | 2024-09-12 | 1134 | 300d | 0d | aux. bombeiro; bombeiro | 35.2h | 4,586.31 | 12. Casa 12 | 0. Térreo | 23 |  | 21. HS1 | Própria | 23 |
| 1150 | 1.7.12.1.6 | 6.Inst. Esgoto | 2d | 2024-05-24 | 2024-05-28 | 1160SF | 394d | 0d | aux. bombeiro; bombeiro | 35.2h | 2,922.8 | 12. Casa 12 | 0. Térreo | 24 |  | 21. HS1 | Própria | 24 |
| 1151 | 1.7.12.1.7 | 7.Fiação | 2d | 2025-04-07 | 2025-04-08 | 1136 | 64d | 0d | eletricista; aux. eletricista | 35.2h | 11,873.92 | 12. Casa 12 | 0. Térreo | 25 |  | 20. Elétrica1 | Própria | 25 |
| 1152 | 1.7.12.1.8 | 8.Interr. Tom e luminárias | 1d | 2025-06-09 | 2025-06-09 | 1137 | 64d | 0d | eletricista; aux. eletricista | 17.6h | 6,963.62 | 12. Casa 12 | 0. Térreo | 26 |  | 20. Elétrica1 | Própria | 26 |
| 1153 | 1.7.12.1.9 | 9.Quadro elétrico | 2d | 2025-08-26 | 2025-08-27 | 1138 | 64d | 0d | eletricista; aux. eletricista | 35.2h | 1,788.87 | 12. Casa 12 | 0. Térreo | 27 |  | 20. Elétrica1 | Própria | 27 |
| 1154 | 1.7.12.1.10 | 10.Louças e Metais | 2d | 2025-08-04 | 2025-08-05 | 1139 | 80d | 0d | aux. bombeiro; bombeiro | 35.2h | 6,591.75 | 12. Casa 12 | 0. Térreo | 28 | 10 | 21. HS1 | Própria | 28 |
| 1155 | 1.7.12.2 | **1. Pav. Superior** | 394d | 2024-01-26 | 2025-08-29 |  | 80d |  |  | 299.2h | 21,866.33 |  |  |  |  |  |  |  |
| 1156 | 1.7.12.2.1 | 2.Inst. Elétricas Laje | 2d | 2024-01-26 | 2024-01-29 | 656SS+4d | 472d |  | eletricista; aux. eletricista | 35.2h | 2,995.3 | 12. Casa 12 | 1. Pav. Superior | 20 |  | 20. Elétrica1 | Própria | 20 |
| 1157 | 1.7.12.2.2 | 3.Inst. Elétricas Paredes | 2d | 2024-04-25 | 2024-04-29 | 1172SF | 414d | 0d | eletricista; aux. eletricista | 35.2h | 766.33 | 12. Casa 12 | 1. Pav. Superior | 21 |  | 20. Elétrica1 | Própria | 21 |
| 1158 | 1.7.12.2.3 | 4.Inst. Gás | 2d | 2024-08-28 | 2024-08-30 | 1173SF | 328d | 0d | aux. bombeiro; bombeiro | 35.2h | 1,371.29 | 12. Casa 12 | 1. Pav. Superior | 22 |  | 21. HS1 | Própria | 22 |
| 1159 | 1.7.12.2.4 | 5.Inst. AF e AQ | 2d | 2024-09-13 | 2024-09-16 | 1149 | 300d | 0d | aux. bombeiro; bombeiro | 35.2h | 2,426.07 | 12. Casa 12 | 1. Pav. Superior | 23 |  | 21. HS1 | Própria | 23 |
| 1160 | 1.7.12.2.5 | 6.Inst. Esgoto | 2d | 2024-05-28 | 2024-06-03 | 1175SF | 392d | 0d | aux. bombeiro; bombeiro | 35.2h | 1,546.11 | 12. Casa 12 | 1. Pav. Superior | 24 |  | 21. HS1 | Própria | 24 |
| 1161 | 1.7.12.2.6 | 7.Fiação | 2d | 2025-04-09 | 2025-04-10 | 1151 | 64d | 0d | eletricista; aux. eletricista | 35.2h | 5,338.91 | 12. Casa 12 | 1. Pav. Superior | 25 |  | 20. Elétrica1 | Própria | 25 |
| 1162 | 1.7.12.2.7 | 8.Interr. Tom e luminárias | 1d | 2025-06-10 | 2025-06-10 | 1152 | 64d | 0d | eletricista; aux. eletricista | 17.6h | 3,131.08 | 12. Casa 12 | 1. Pav. Superior | 26 |  | 20. Elétrica1 | Própria | 26 |
| 1163 | 1.7.12.2.8 | 9.Quadro elétrico | 2d | 2025-08-28 | 2025-08-29 | 1153 | 64d | 0d | eletricista; aux. eletricista | 35.2h | 804.33 | 12. Casa 12 | 1. Pav. Superior | 27 |  | 20. Elétrica1 | Própria | 27 |
| 1164 | 1.7.12.2.9 | 10.Louças e Metais | 2d | 2025-08-06 | 2025-08-07 | 1154 | 80d | 0d | aux. bombeiro; bombeiro | 35.2h | 3,486.91 | 12. Casa 12 | 1. Pav. Superior | 28 | 10 | 21. HS1 | Própria | 28 |

| ID | WBS | Task | Duration | Start | Finish | Predecessors | Total slack | Free slack | Resources | Work | Cost | Casa | Pav | Pacote | Cor | Equipe | Empresa | LB |
| --- | --- | --- | --- | --- | --- | --- | --- | --- | --- | --- | --- | --- | --- | --- | --- | --- | --- | --- |
| 1165 | 1.7.12.3 | **2. Coberta** | 4d | 2024-09-17 | 2024-09-20 |  | 296d |  |  | 70.4h | 2,943.46 |  |  |  |  |  |  |  |
| 1166 | 1.7.12.3.1 | Barrilette | 2d | 2024-09-17 | 2024-09-18 | 1142 | 296d | 0d | aux. bombeiro; bombeiro | 35.2h | 1,177.38 | 12. Casa 12 | 2. Coberta | 29 | 11 | 21. HS1 | Própria | 29 |
| 1167 | 1.7.12.3.2 | Caixa D'água | 2d | 2024-09-19 | 2024-09-20 | 1166 | 296d | 0d | aux. bombeiro; bombeiro | 35.2h | 1,766.08 | 12. Casa 12 | 2. Coberta | 30 | 11 | 21. HS1 | Própria | 30 |
| 1168 | 1.7.13 | **13. Casa 13** | 437d | 2023-11-24 | 2025-09-04 |  | 76d |  |  | 704h | 72,049.62 |  |  |  |  |  |  |  |
| 1169 | 1.7.13.1 | **0. Térreo** | 435d | 2023-11-24 | 2025-09-02 |  | 78d |  |  | 334.4h | 47,239.83 |  |  |  |  |  |  |  |
| 1170 | 1.7.13.1.1 | 1.Inst. Embut. Em Fundações | 2d | 2023-11-24 | 2023-11-27 | 682SS+5d | 511d |  | bombeiro; eletricista | 35.2h | 1,554.25 | 13. Casa 13 | 0. Térreo | 19 |  | 19. Instalações1 | Própria | 19 |
| 1171 | 1.7.13.1.2 | 2.Inst. Elétricas Laje | 2d | 2024-02-06 | 2024-02-07 | 683SS+4d | 465d |  | eletricista; aux. eletricista | 35.2h | 6,661.65 | 13. Casa 13 | 0. Térreo | 20 |  | 20. Elétrica1 | Própria | 20 |
| 1172 | 1.7.13.1.3 | 3.Inst. Elétricas Paredes | 2d | 2024-04-29 | 2024-05-02 | 1182SF | 412d | 0d | eletricista; aux. eletricista | 35.2h | 1,704.34 | 13. Casa 13 | 0. Térreo | 21 |  | 20. Elétrica1 | Própria | 21 |
| 1173 | 1.7.13.1.4 | 4.Inst. Gás | 2d | 2024-08-30 | 2024-09-03 | 1183SF | 326d | 0d | aux. bombeiro; bombeiro | 35.2h | 2,592.32 | 13. Casa 13 | 0. Térreo | 22 |  | 21. HS1 | Própria | 22 |
| 1174 | 1.7.13.1.5 | 5.Inst. AF e AQ | 2d | 2024-09-17 | 2024-09-18 | 1159 | 300d | 0d | aux. bombeiro; bombeiro | 35.2h | 4,586.31 | 13. Casa 13 | 0. Térreo | 23 |  | 21. HS1 | Própria | 23 |
| 1175 | 1.7.13.1.6 | 6.Inst. Esgoto | 2d | 2024-06-03 | 2024-06-05 | 1185SF | 390d | 0d | aux. bombeiro; bombeiro | 35.2h | 2,922.8 | 13. Casa 13 | 0. Térreo | 24 |  | 21. HS1 | Própria | 24 |
| 1176 | 1.7.13.1.7 | 7.Fiação | 2d | 2025-04-11 | 2025-04-14 | 1161 | 64d | 0d | eletricista; aux. eletricista | 35.2h | 11,873.92 | 13. Casa 13 | 0. Térreo | 25 |  | 20. Elétrica1 | Própria | 25 |
| 1177 | 1.7.13.1.8 | 8.Interr. Tom e luminárias | 1d | 2025-06-11 | 2025-06-11 | 1162 | 64d | 0d | eletricista; aux. eletricista | 17.6h | 6,963.62 | 13. Casa 13 | 0. Térreo | 26 |  | 20. Elétrica1 | Própria | 26 |
| 1178 | 1.7.13.1.9 | 9.Quadro elétrico | 2d | 2025-09-01 | 2025-09-02 | 1163 | 64d | 0d | eletricista; aux. eletricista | 35.2h | 1,788.87 | 13. Casa 13 | 0. Térreo | 27 |  | 20. Elétrica1 | Própria | 27 |
| 1179 | 1.7.13.1.10 | 10.Louças e Metais | 2d | 2025-08-08 | 2025-08-11 | 1164 | 80d | 0d | aux. bombeiro; bombeiro | 35.2h | 6,591.75 | 13. Casa 13 | 0. Térreo | 28 | 10 | 21. HS1 | Própria | 28 |
| 1180 | 1.7.13.2 | **1. Pav. Superior** | 384d | 2024-02-20 | 2025-09-04 |  | 76d |  |  | 299.2h | 21,866.33 |  |  |  |  |  |  |  |
| 1181 | 1.7.13.2.1 | 2.Inst. Elétricas Laje | 2d | 2024-02-20 | 2024-02-21 | 703SS+4d | 458d |  | eletricista; aux. eletricista | 35.2h | 2,995.3 | 13. Casa 13 | 1. Pav. Superior | 20 |  | 20. Elétrica1 | Própria | 20 |
| 1182 | 1.7.13.2.2 | 3.Inst. Elétricas Paredes | 2d | 2024-05-02 | 2024-05-06 | 1197SF | 410d | 0d | eletricista; aux. eletricista | 35.2h | 766.33 | 13. Casa 13 | 1. Pav. Superior | 21 |  | 20. Elétrica1 | Própria | 21 |
| 1183 | 1.7.13.2.3 | 4.Inst. Gás | 2d | 2024-09-03 | 2024-09-05 | 1198SF | 324d | 0d | aux. bombeiro; bombeiro | 35.2h | 1,371.29 | 13. Casa 13 | 1. Pav. Superior | 22 |  | 21. HS1 | Própria | 22 |
| 1184 | 1.7.13.2.4 | 5.Inst. AF e AQ | 2d | 2024-09-19 | 2024-09-20 | 1174 | 300d | 0d | aux. bombeiro; bombeiro | 35.2h | 2,426.07 | 13. Casa 13 | 1. Pav. Superior | 23 |  | 21. HS1 | Própria | 23 |
| 1185 | 1.7.13.2.5 | 6.Inst. Esgoto | 2d | 2024-06-05 | 2024-06-07 | 1200SF | 388d | 0d | aux. bombeiro; bombeiro | 35.2h | 1,546.11 | 13. Casa 13 | 1. Pav. Superior | 24 |  | 21. HS1 | Própria | 24 |
| 1186 | 1.7.13.2.6 | 7.Fiação | 2d | 2025-04-15 | 2025-04-16 | 1176 | 64d | 0d | eletricista; aux. eletricista | 35.2h | 5,338.91 | 13. Casa 13 | 1. Pav. Superior | 25 |  | 20. Elétrica1 | Própria | 25 |
| 1187 | 1.7.13.2.7 | 8.Interr. Tom e luminárias | 1d | 2025-06-12 | 2025-06-12 | 1177 | 64d | 0d | eletricista; aux. eletricista | 17.6h | 3,131.08 | 13. Casa 13 | 1. Pav. Superior | 26 |  | 20. Elétrica1 | Própria | 26 |
| 1188 | 1.7.13.2.8 | 9.Quadro elétrico | 2d | 2025-09-03 | 2025-09-04 | 1178 | 64d | 0d | eletricista; aux. eletricista | 35.2h | 804.33 | 13. Casa 13 | 1. Pav. Superior | 27 |  | 20. Elétrica1 | Própria | 27 |
| 1189 | 1.7.13.2.9 | 10.Louças e Metais | 2d | 2025-08-12 | 2025-08-13 | 1179 | 80d | 0d | aux. bombeiro; bombeiro | 35.2h | 3,486.91 | 13. Casa 13 | 1. Pav. Superior | 28 | 10 | 21. HS1 | Própria | 28 |

| ID | WBS | Task | Duration | Start | Finish | Predecessors | Total slack | Free slack | Resources | Work | Cost | Casa | Pav | Pacote | Cor | Equipe | Empresa | LB |
| --- | --- | --- | --- | --- | --- | --- | --- | --- | --- | --- | --- | --- | --- | --- | --- | --- | --- | --- |
| 1190 | 1.7.13.3 | **2. Coberta** | 4d | 2024-09-23 | 2024-09-26 |  | 296d |  |  | 70.4h | 2,943.46 |  |  |  |  |  |  |  |
| 1191 | 1.7.13.3.1 | Barrilette | 2d | 2024-09-23 | 2024-09-24 | 1167 | 296d | 0d | aux. bombeiro; bombeiro | 35.2h | 1,177.38 | 13. Casa 13 | 2. Coberta | 29 | 11 | 21. HS1 | Própria | 29 |
| 1192 | 1.7.13.3.2 | Caixa D'água | 2d | 2024-09-25 | 2024-09-26 | 1191 | 296d | 0d | aux. bombeiro; bombeiro | 35.2h | 1,766.08 | 13. Casa 13 | 2. Coberta | 30 | 11 | 21. HS1 | Própria | 30 |
| 1193 | 1.7.14 | **14. Casa 14** | 432d | 2023-12-07 | 2025-09-10 |  | 72d |  |  | 704h | 72,049.62 |  |  |  |  |  |  |  |
| 1194 | 1.7.14.1 | **0. Térreo** | 430d | 2023-12-07 | 2025-09-08 |  | 74d |  |  | 334.4h | 47,239.83 |  |  |  |  |  |  |  |
| 1195 | 1.7.14.1.1 | 1.Inst. Embut. Em Fundações | 2d | 2023-12-07 | 2023-12-08 | 729SS+5d | 502d |  | bombeiro; eletricista | 35.2h | 1,554.25 | 14. Casa 14 | 0. Térreo | 19 |  | 19. Instalações1 | Própria | 19 |
| 1196 | 1.7.14.1.2 | 2.Inst. Elétricas Laje | 2d | 2024-02-29 | 2024-03-01 | 730SS+4d | 451d |  | eletricista; aux. eletricista | 35.2h | 6,661.65 | 14. Casa 14 | 0. Térreo | 20 |  | 20. Elétrica1 | Própria | 20 |
| 1197 | 1.7.14.1.3 | 3.Inst. Elétricas Paredes | 2d | 2024-05-06 | 2024-05-08 | 1207SF | 408d | 0d | eletricista; aux. eletricista | 35.2h | 1,704.34 | 14. Casa 14 | 0. Térreo | 21 |  | 20. Elétrica1 | Própria | 21 |
| 1198 | 1.7.14.1.4 | 4.Inst. Gás | 2d | 2024-09-05 | 2024-09-09 | 1208SF | 322d | 0d | aux. bombeiro; bombeiro | 35.2h | 2,592.32 | 14. Casa 14 | 0. Térreo | 22 |  | 21. HS1 | Própria | 22 |
| 1199 | 1.7.14.1.5 | 5.Inst. AF e AQ | 2d | 2024-09-23 | 2024-09-24 | 1184 | 300d | 0d | aux. bombeiro; bombeiro | 35.2h | 4,586.31 | 14. Casa 14 | 0. Térreo | 23 |  | 21. HS1 | Própria | 23 |
| 1200 | 1.7.14.1.6 | 6.Inst. Esgoto | 2d | 2024-06-07 | 2024-06-11 | 1210SF | 386d | 0d | aux. bombeiro; bombeiro | 35.2h | 2,922.8 | 14. Casa 14 | 0. Térreo | 24 |  | 21. HS1 | Própria | 24 |
| 1201 | 1.7.14.1.7 | 7.Fiação | 2d | 2025-04-17 | 2025-04-22 | 1186 | 64d | 0d | eletricista; aux. eletricista | 35.2h | 11,873.92 | 14. Casa 14 | 0. Térreo | 25 |  | 20. Elétrica1 | Própria | 25 |
| 1202 | 1.7.14.1.8 | 8.Interr. Tom e luminárias | 1d | 2025-06-13 | 2025-06-13 | 1187 | 64d | 0d | eletricista; aux. eletricista | 17.6h | 6,963.62 | 14. Casa 14 | 0. Térreo | 26 |  | 20. Elétrica1 | Própria | 26 |
| 1203 | 1.7.14.1.9 | 9.Quadro elétrico | 2d | 2025-09-05 | 2025-09-08 | 1188 | 64d | 0d | eletricista; aux. eletricista | 35.2h | 1,788.87 | 14. Casa 14 | 0. Térreo | 27 |  | 20. Elétrica1 | Própria | 27 |
| 1204 | 1.7.14.1.10 | 10.Louças e Metais | 2d | 2025-08-14 | 2025-08-15 | 1189 | 80d | 0d | aux. bombeiro; bombeiro | 35.2h | 6,591.75 | 14. Casa 14 | 0. Térreo | 28 | 10 | 21. HS1 | Própria | 28 |
| 1205 | 1.7.14.2 | **1. Pav. Superior** | 374d | 2024-03-11 | 2025-09-10 |  | 72d |  |  | 299.2h | 21,866.33 |  |  |  |  |  |  |  |
| 1206 | 1.7.14.2.1 | 2.Inst. Elétricas Laje | 2d | 2024-03-11 | 2024-03-12 | 750SS+4d | 444d |  | eletricista; aux. eletricista | 35.2h | 2,995.3 | 14. Casa 14 | 1. Pav. Superior | 20 |  | 20. Elétrica1 | Própria | 20 |
| 1207 | 1.7.14.2.2 | 3.Inst. Elétricas Paredes | 2d | 2024-05-08 | 2024-05-10 | 1222SF | 406d | 0d | eletricista; aux. eletricista | 35.2h | 766.33 | 14. Casa 14 | 1. Pav. Superior | 21 |  | 20. Elétrica1 | Própria | 21 |
| 1208 | 1.7.14.2.3 | 4.Inst. Gás | 2d | 2024-09-09 | 2024-09-11 | 1223SF | 320d | 0d | aux. bombeiro; bombeiro | 35.2h | 1,371.29 | 14. Casa 14 | 1. Pav. Superior | 22 |  | 21. HS1 | Própria | 22 |
| 1209 | 1.7.14.2.4 | 5.Inst. AF e AQ | 2d | 2024-09-25 | 2024-09-26 | 1199 | 300d | 0d | aux. bombeiro; bombeiro | 35.2h | 2,426.07 | 14. Casa 14 | 1. Pav. Superior | 23 |  | 21. HS1 | Própria | 23 |
| 1210 | 1.7.14.2.5 | 6.Inst. Esgoto | 2d | 2024-06-11 | 2024-06-13 | 1225SF | 384d | 0d | aux. bombeiro; bombeiro | 35.2h | 1,546.11 | 14. Casa 14 | 1. Pav. Superior | 24 |  | 21. HS1 | Própria | 24 |
| 1211 | 1.7.14.2.6 | 7.Fiação | 2d | 2025-04-23 | 2025-04-24 | 1201 | 64d | 0d | eletricista; aux. eletricista | 35.2h | 5,338.91 | 14. Casa 14 | 1. Pav. Superior | 25 |  | 20. Elétrica1 | Própria | 25 |
| 1212 | 1.7.14.2.7 | 8.Interr. Tom e luminárias | 1d | 2025-06-16 | 2025-06-16 | 1202 | 64d | 0d | eletricista; aux. eletricista | 17.6h | 3,131.08 | 14. Casa 14 | 1. Pav. Superior | 26 |  | 20. Elétrica1 | Própria | 26 |
| 1213 | 1.7.14.2.8 | 9.Quadro elétrico | 2d | 2025-09-09 | 2025-09-10 | 1203 | 64d | 0d | eletricista; aux. eletricista | 35.2h | 804.33 | 14. Casa 14 | 1. Pav. Superior | 27 |  | 20. Elétrica1 | Própria | 27 |
| 1214 | 1.7.14.2.9 | 10.Louças e Metais | 2d | 2025-08-18 | 2025-08-19 | 1204 | 80d | 0d | aux. bombeiro; bombeiro | 35.2h | 3,486.91 | 14. Casa 14 | 1. Pav. Superior | 28 | 10 | 21. HS1 | Própria | 28 |

| ID | WBS | Task | Duration | Start | Finish | Predecessors | Total slack | Free slack | Resources | Work | Cost | Casa | Pav | Pacote | Cor | Equipe | Empresa | LB |
| --- | --- | --- | --- | --- | --- | --- | --- | --- | --- | --- | --- | --- | --- | --- | --- | --- | --- | --- |
| 1215 | 1.7.14.3 | **2. Coberta** | 4d | 2024-09-27 | 2024-10-02 |  | 296d |  |  | 70.4h | 2,943.46 |  |  |  |  |  |  |  |
| 1216 | 1.7.14.3.1 | Barrilette | 2d | 2024-09-27 | 2024-09-30 | 1192 | 296d | 0d | aux. bombeiro; bombeiro | 35.2h | 1,177.38 | 14. Casa 14 | 2. Coberta | 29 | 11 | 21. HS1 | Própria | 29 |
| 1217 | 1.7.14.3.2 | Caixa D'água | 2d | 2024-10-01 | 2024-10-02 | 1216 | 296d | 0d | aux. bombeiro; bombeiro | 35.2h | 1,766.08 | 14. Casa 14 | 2. Coberta | 30 | 11 | 21. HS1 | Própria | 30 |
| 1218 | 1.7.15 | **15. Casa 15** | 427d | 2023-12-20 | 2025-09-16 |  | 68d |  |  | 704h | 72,049.62 |  |  |  |  |  |  |  |
| 1219 | 1.7.15.1 | **0. Térreo** | 425d | 2023-12-20 | 2025-09-12 |  | 70d |  |  | 334.4h | 47,239.83 |  |  |  |  |  |  |  |
| 1220 | 1.7.15.1.1 | 1.Inst. Embut. Em Fundações | 2d | 2023-12-20 | 2023-12-21 | 776SS+5d | 493d |  | bombeiro; eletricista | 35.2h | 1,554.25 | 15. Casa 15 | 0. Térreo | 19 |  | 19. Instalações1 | Própria | 19 |
| 1221 | 1.7.15.1.2 | 2.Inst. Elétricas Laje | 2d | 2024-03-21 | 2024-03-22 | 777SS+4d | 437d |  | eletricista; aux. eletricista | 35.2h | 6,661.65 | 15. Casa 15 | 0. Térreo | 20 |  | 20. Elétrica1 | Própria | 20 |
| 1222 | 1.7.15.1.3 | 3.Inst. Elétricas Paredes | 2d | 2024-05-10 | 2024-05-14 | 1232SF | 404d | 0d | eletricista; aux. eletricista | 35.2h | 1,704.34 | 15. Casa 15 | 0. Térreo | 21 |  | 20. Elétrica1 | Própria | 21 |
| 1223 | 1.7.15.1.4 | 4.Inst. Gás | 2d | 2024-09-11 | 2024-09-13 | 1233SF | 318d | 0d | aux. bombeiro; bombeiro | 35.2h | 2,592.32 | 15. Casa 15 | 0. Térreo | 22 |  | 21. HS1 | Própria | 22 |
| 1224 | 1.7.15.1.5 | 5.Inst. AF e AQ | 2d | 2024-09-27 | 2024-09-30 | 1209 | 300d | 0d | aux. bombeiro; bombeiro | 35.2h | 4,586.31 | 15. Casa 15 | 0. Térreo | 23 |  | 21. HS1 | Própria | 23 |
| 1225 | 1.7.15.1.6 | 6.Inst. Esgoto | 2d | 2024-06-13 | 2024-06-17 | 1235SF | 382d | 0d | aux. bombeiro; bombeiro | 35.2h | 2,922.8 | 15. Casa 15 | 0. Térreo | 24 |  | 21. HS1 | Própria | 24 |
| 1226 | 1.7.15.1.7 | 7.Fiação | 2d | 2025-04-25 | 2025-04-28 | 1211 | 64d | 0d | eletricista; aux. eletricista | 35.2h | 11,873.92 | 15. Casa 15 | 0. Térreo | 25 |  | 20. Elétrica1 | Própria | 25 |
| 1227 | 1.7.15.1.8 | 8.Interr. Tom e luminárias | 1d | 2025-06-17 | 2025-06-17 | 1212 | 64d | 0d | eletricista; aux. eletricista | 17.6h | 6,963.62 | 15. Casa 15 | 0. Térreo | 26 |  | 20. Elétrica1 | Própria | 26 |
| 1228 | 1.7.15.1.9 | 9.Quadro elétrico | 2d | 2025-09-11 | 2025-09-12 | 1213 | 64d | 0d | eletricista; aux. eletricista | 35.2h | 1,788.87 | 15. Casa 15 | 0. Térreo | 27 |  | 20. Elétrica1 | Própria | 27 |
| 1229 | 1.7.15.1.10 | 10.Louças e Metais | 2d | 2025-08-20 | 2025-08-21 | 1214 | 80d | 0d | aux. bombeiro; bombeiro | 35.2h | 6,591.75 | 15. Casa 15 | 0. Térreo | 28 | 10 | 21. HS1 | Própria | 28 |
| 1230 | 1.7.15.2 | **1. Pav. Superior** | 364d | 2024-04-03 | 2025-09-16 |  | 68d |  |  | 299.2h | 21,866.33 |  |  |  |  |  |  |  |
| 1231 | 1.7.15.2.1 | 2.Inst. Elétricas Laje | 2d | 2024-04-03 | 2024-04-04 | 797SS+4d | 430d |  | eletricista; aux. eletricista | 35.2h | 2,995.3 | 15. Casa 15 | 1. Pav. Superior | 20 |  | 20. Elétrica1 | Própria | 20 |
| 1232 | 1.7.15.2.2 | 3.Inst. Elétricas Paredes | 2d | 2024-05-14 | 2024-05-16 | 1247SF | 402d | 0d | eletricista; aux. eletricista | 35.2h | 766.33 | 15. Casa 15 | 1. Pav. Superior | 21 |  | 20. Elétrica1 | Própria | 21 |
| 1233 | 1.7.15.2.3 | 4.Inst. Gás | 2d | 2024-09-13 | 2024-09-17 | 1248SF | 316d | 0d | aux. bombeiro; bombeiro | 35.2h | 1,371.29 | 15. Casa 15 | 1. Pav. Superior | 22 |  | 21. HS1 | Própria | 22 |
| 1234 | 1.7.15.2.4 | 5.Inst. AF e AQ | 2d | 2024-10-01 | 2024-10-02 | 1224 | 300d | 0d | aux. bombeiro; bombeiro | 35.2h | 2,426.07 | 15. Casa 15 | 1. Pav. Superior | 23 |  | 21. HS1 | Própria | 23 |
| 1235 | 1.7.15.2.5 | 6.Inst. Esgoto | 2d | 2024-06-17 | 2024-06-19 | 1250SF | 380d | 0d | aux. bombeiro; bombeiro | 35.2h | 1,546.11 | 15. Casa 15 | 1. Pav. Superior | 24 |  | 21. HS1 | Própria | 24 |
| 1236 | 1.7.15.2.6 | 7.Fiação | 2d | 2025-04-29 | 2025-04-30 | 1226 | 64d | 0d | eletricista; aux. eletricista | 35.2h | 5,338.91 | 15. Casa 15 | 1. Pav. Superior | 25 |  | 20. Elétrica1 | Própria | 25 |
| 1237 | 1.7.15.2.7 | 8.Interr. Tom e luminárias | 1d | 2025-06-18 | 2025-06-18 | 1227 | 64d | 0d | eletricista; aux. eletricista | 17.6h | 3,131.08 | 15. Casa 15 | 1. Pav. Superior | 26 |  | 20. Elétrica1 | Própria | 26 |
| 1238 | 1.7.15.2.8 | 9.Quadro elétrico | 2d | 2025-09-15 | 2025-09-16 | 1228 | 64d | 0d | eletricista; aux. eletricista | 35.2h | 804.33 | 15. Casa 15 | 1. Pav. Superior | 27 |  | 20. Elétrica1 | Própria | 27 |
| 1239 | 1.7.15.2.9 | 10.Louças e Metais | 2d | 2025-08-22 | 2025-08-25 | 1229 | 80d | 0d | aux. bombeiro; bombeiro | 35.2h | 3,486.91 | 15. Casa 15 | 1. Pav. Superior | 28 | 10 | 21. HS1 | Própria | 28 |

| ID | WBS | Task | Duration | Start | Finish | Predecessors | Total slack | Free slack | Resources | Work | Cost | Casa | Pav | Pacote | Cor | Equipe | Empresa | LB |
| --- | --- | --- | --- | --- | --- | --- | --- | --- | --- | --- | --- | --- | --- | --- | --- | --- | --- | --- |
| 1240 | 1.7.15.3 | **2. Coberta** | 4d | 2024-10-03 | 2024-10-08 |  | 296d |  |  | 70.4h | 2,943.46 |  |  |  |  |  |  |  |
| 1241 | 1.7.15.3.1 | Barrilette | 2d | 2024-10-03 | 2024-10-04 | 1217 | 296d | 0d | aux. bombeiro; bombeiro | 35.2h | 1,177.38 | 15. Casa 15 | 2. Coberta | 29 | 11 | 21. HS1 | Própria | 29 |
| 1242 | 1.7.15.3.2 | Caixa D'água | 2d | 2024-10-07 | 2024-10-08 | 1241 | 296d | 0d | aux. bombeiro; bombeiro | 35.2h | 1,766.08 | 15. Casa 15 | 2. Coberta | 30 | 11 | 21. HS1 | Própria | 30 |
| 1243 | 1.7.16 | **16. Casa 16** | 422d | 2024-01-10 | 2025-09-22 |  | 64d |  |  | 704h | 72,049.62 |  |  |  |  |  |  |  |
| 1244 | 1.7.16.1 | **0. Térreo** | 420d | 2024-01-10 | 2025-09-18 |  | 66d |  |  | 334.4h | 47,239.83 |  |  |  |  |  |  |  |
| 1245 | 1.7.16.1.1 | 1.Inst. Embut. Em Fundações | 2d | 2024-01-10 | 2024-01-11 | 823SS+5d | 484d |  | bombeiro; eletricista | 35.2h | 1,554.25 | 16. Casa 16 | 0. Térreo | 19 |  | 19. Instalações1 | Própria | 19 |
| 1246 | 1.7.16.1.2 | 2.Inst. Elétricas Laje | 2d | 2024-04-12 | 2024-04-15 | 824SS+4d | 423d |  | eletricista; aux. eletricista | 35.2h | 6,661.65 | 16. Casa 16 | 0. Térreo | 20 |  | 20. Elétrica1 | Própria | 20 |
| 1247 | 1.7.16.1.3 | 3.Inst. Elétricas Paredes | 2d | 2024-05-16 | 2024-05-20 | 1257SF | 400d | 0d | eletricista; aux. eletricista | 35.2h | 1,704.34 | 16. Casa 16 | 0. Térreo | 21 |  | 20. Elétrica1 | Própria | 21 |
| 1248 | 1.7.16.1.4 | 4.Inst. Gás | 2d | 2024-09-17 | 2024-09-19 | 1258SF | 314d | 0d | aux. bombeiro; bombeiro | 35.2h | 2,592.32 | 16. Casa 16 | 0. Térreo | 22 |  | 21. HS1 | Própria | 22 |
| 1249 | 1.7.16.1.5 | 5.Inst. AF e AQ | 2d | 2024-10-03 | 2024-10-04 | 1234 | 300d | 0d | aux. bombeiro; bombeiro | 35.2h | 4,586.31 | 16. Casa 16 | 0. Térreo | 23 |  | 21. HS1 | Própria | 23 |
| 1250 | 1.7.16.1.6 | 6.Inst. Esgoto | 2d | 2024-06-19 | 2024-06-21 | 1260SF | 378d | 0d | aux. bombeiro; bombeiro | 35.2h | 2,922.8 | 16. Casa 16 | 0. Térreo | 24 |  | 21. HS1 | Própria | 24 |
| 1251 | 1.7.16.1.7 | 7.Fiação | 2d | 2025-05-02 | 2025-05-05 | 1236 | 64d | 0d | eletricista; aux. eletricista | 35.2h | 11,873.92 | 16. Casa 16 | 0. Térreo | 25 |  | 20. Elétrica1 | Própria | 25 |
| 1252 | 1.7.16.1.8 | 8.Interr. Tom e luminárias | 1d | 2025-06-23 | 2025-06-23 | 1237 | 64d | 0d | eletricista; aux. eletricista | 17.6h | 6,963.62 | 16. Casa 16 | 0. Térreo | 26 |  | 20. Elétrica1 | Própria | 26 |
| 1253 | 1.7.16.1.9 | 9.Quadro elétrico | 2d | 2025-09-17 | 2025-09-18 | 1238 | 64d | 0d | eletricista; aux. eletricista | 35.2h | 1,788.87 | 16. Casa 16 | 0. Térreo | 27 |  | 20. Elétrica1 | Própria | 27 |
| 1254 | 1.7.16.1.10 | 10.Louças e Metais | 2d | 2025-08-26 | 2025-08-27 | 1239 | 80d | 0d | aux. bombeiro; bombeiro | 35.2h | 6,591.75 | 16. Casa 16 | 0. Térreo | 28 | 10 | 21. HS1 | Própria | 28 |
| 1255 | 1.7.16.2 | **1. Pav. Superior** | 354d | 2024-04-23 | 2025-09-22 |  | 64d |  |  | 299.2h | 21,866.33 |  |  |  |  |  |  |  |
| 1256 | 1.7.16.2.1 | 2.Inst. Elétricas Laje | 2d | 2024-04-23 | 2024-04-24 | 844SS+4d | 416d |  | eletricista; aux. eletricista | 35.2h | 2,995.3 | 16. Casa 16 | 1. Pav. Superior | 20 |  | 20. Elétrica1 | Própria | 20 |
| 1257 | 1.7.16.2.2 | 3.Inst. Elétricas Paredes | 2d | 2024-05-20 | 2024-05-21 | 845 | 398d | 0d | eletricista; aux. eletricista | 35.2h | 766.33 | 16. Casa 16 | 1. Pav. Superior | 21 |  | 20. Elétrica1 | Própria | 21 |
| 1258 | 1.7.16.2.3 | 4.Inst. Gás | 2d | 2024-09-19 | 2024-09-23 | 848SF | 312d | 0d | aux. bombeiro; bombeiro | 35.2h | 1,371.29 | 16. Casa 16 | 1. Pav. Superior | 22 |  | 21. HS1 | Própria | 22 |
| 1259 | 1.7.16.2.4 | 5.Inst. AF e AQ | 2d | 2024-10-07 | 2024-10-08 | 1249 | 300d |  | aux. bombeiro; bombeiro | 35.2h | 2,426.07 | 16. Casa 16 | 1. Pav. Superior | 23 |  | 21. HS1 | Própria | 23 |
| 1260 | 1.7.16.2.5 | 6.Inst. Esgoto | 2d | 2024-06-21 | 2024-06-25 | 873SF | 376d | 0d | aux. bombeiro; bombeiro | 35.2h | 1,546.11 | 16. Casa 16 | 1. Pav. Superior | 24 |  | 21. HS1 | Própria | 24 |
| 1261 | 1.7.16.2.6 | 7.Fiação | 2d | 2025-05-06 | 2025-05-07 | 1251 | 64d | 0d | eletricista; aux. eletricista | 35.2h | 5,338.91 | 16. Casa 16 | 1. Pav. Superior | 25 |  | 20. Elétrica1 | Própria | 25 |
| 1262 | 1.7.16.2.7 | 8.Interr. Tom e luminárias | 1d | 2025-06-24 | 2025-06-24 | 1252 | 64d | 0d | eletricista; aux. eletricista | 17.6h | 3,131.08 | 16. Casa 16 | 1. Pav. Superior | 26 |  | 20. Elétrica1 | Própria | 26 |
| 1263 | 1.7.16.2.8 | 9.Quadro elétrico | 2d | 2025-09-19 | 2025-09-22 | 1253 | 64d |  | eletricista; aux. eletricista | 35.2h | 804.33 | 16. Casa 16 | 1. Pav. Superior | 27 |  | 20. Elétrica1 | Própria | 27 |
| 1264 | 1.7.16.2.9 | 10.Louças e Metais | 2d | 2025-08-28 | 2025-08-29 | 1254 | 80d |  | aux. bombeiro; bombeiro | 35.2h | 3,486.91 | 16. Casa 16 | 1. Pav. Superior | 28 | 10 | 21. HS1 | Própria | 28 |

| ID | WBS | Task | Duration | Start | Finish | Predecessors | Total slack | Free slack | Resources | Work | Cost | Casa | Pav | Pacote | Cor | Equipe | Empresa | LB |
| --- | --- | --- | --- | --- | --- | --- | --- | --- | --- | --- | --- | --- | --- | --- | --- | --- | --- | --- |
| 1265 | 1.7.16.3 | **2. Coberta** | 4d | 2024-10-09 | 2024-10-14 |  | 296d |  |  | 70.4h | 2,943.46 |  |  |  |  |  |  |  |
| 1266 | 1.7.16.3.1 | Barrilette | 2d | 2024-10-09 | 2024-10-10 | 1242 | 296d | 0d | aux. bombeiro; bombeiro | 35.2h | 1,177.38 | 16. Casa 16 | 2. Coberta | 29 | 11 | 21. HS1 | Própria | 29 |
| 1267 | 1.7.16.3.2 | Caixa D'água | 2d | 2024-10-11 | 2024-10-14 | 1266 | 296d |  | aux. bombeiro; bombeiro | 35.2h | 1,766.08 | 16. Casa 16 | 2. Coberta | 30 | 11 | 21. HS1 | Própria | 30 |
